# SUBPROYECTO A3

How a schedule from Primavera P6 changed from version to version. A marks actual dates.

## Version 1 (data date 2023-04-25, saved 2023-04-14, file PER2305-9.xer)

| ID | WBS | Task | Duration | Start | Finish | Predecessors | Total float |
| --- | --- | --- | --- | --- | --- | --- | --- |
|  | 0 | **HITOS** |  | 2023-04-25 | 2023-11-03 |  |  |
| A1000 |  | ADJUDICACION DEL SERVICIO | 0d | 2023-04-25 | 2023-04-25 |  | 0d |
| A1010 |  | INICIO DEL SERVICIO | 0d | 2023-05-09 | 2023-05-09 | A1000 FS+11d | 0d |
| A1015 |  | INICIO DE EXCAVACION | 0d | 2023-05-15 | 2023-05-15 | A1010 FS+5d, A1070 SS+3d | 0d |
| A1016 |  | INICIO DE RELLENO DE DIQUE | 0d | 2023-06-06 | 2023-06-06 | A1015 SS+18d, A1340 | 0d |
| A1020 |  | FIN DEL SERVICIO | 0d | 2023-11-03 | 2023-11-03 | A1200, A2220, A2490, A1760, A1780, A1070, A2760, A2700, A1050, A2210, A4020, A3850, A3790, A3780, A3740, A3730, A3670, A3650, A3640, A3630, A3580, A3560, A3550, A3530, A3470, A3450, A3400, A3260, A3160, A3140, A3130, A3080, A2930, A2880 | 0d |
|  | 1 | **DEFENSAS RIBEREÑAS** |  | 2023-05-09 | 2023-11-04 |  |  |
|  | 1 | **OBRAS PRELIMINARES** |  | 2023-05-11 | 2023-10-31 |  |  |
| A1030 |  | CARTEL DE IDENTIFICACIÓN OBRA 4.80 x 3.60 m. | 2d | 2023-05-11 | 2023-05-13 | A1060 SS+2.5d | 1.75d |
| A1040 |  | INSTALACIONES PROVISIONALES PARA LA OBRA | 140d | 2023-05-16 | 2023-10-31 | A1100 SS+1.25d, A1030 | 0d |
| A1050 |  | MANTENIMIENTO DE TRÁNSITO Y SEGURIDAD VIAL | 127d | 2023-05-31 | 2023-10-31 | A1100 | 2.25d |
|  | 2 | **TRABAJOS PRELIMINARES** |  | 2023-05-09 | 2023-11-04 |  |  |
| A1060 |  | MOVILIZACION DE EQUIPOS | 26d | 2023-05-09 | 2023-06-08 | A1010 | 0d |
| A1070 |  | TOPOGRAFÍA Y GEOREFERENCIACIÓN | 144d | 2023-05-11 | 2023-10-31 | A1060 SS+2d | 0d |
| A1080 |  | DESMOVILIZACION DE EQUIPOS | 18d | 2023-10-13 | 2023-11-04 | A1020 FF+1d | 0d |
|  | 3 | **MEJORAMIENTO DE VÍAS EXISTENTES** |  | 2023-05-15 | 2023-07-13 |  |  |
|  | 1 | **MOVIMIENTO DE TIERRAS** |  | 2023-05-15 | 2023-05-31 |  |  |
| A1090 |  | ROCE Y LIMPIEZA DE MALEZA | 14d | 2023-05-15 | 2023-05-31 | A1015 | 0d |
| A1100 |  | MEJORAMIENTO DE VIAS EXISTENTES | 14d | 2023-05-15 | 2023-05-31 | A1090 SS | 0d |
|  | 2 | **REPOSICIÓN DE ESTRUCTURAS** |  | 2023-06-03 | 2023-07-07 |  |  |
| A1150 |  | DEMOLICIÓN DE ESTRUCTURAS EXISTENTES | 2d | 2023-06-03 | 2023-06-06 | A1070 SS+20d | 93.25d |
| A1160 |  | REPOSICIÓN DE PASE DE AGUA TUBO HDPE Ø=18" | 2d | 2023-06-06 | 2023-06-08 | A1150 | 93.25d |
| A1170 |  | REPOSICIÓN DE PASE DE AGUA TUBO HDPE Ø=36" | 2d | 2023-06-06 | 2023-06-08 | A1160 SS | 93.25d |
| A1180 |  | SUMINISTRO Y MONTAJE DE PANELES DE C°A° 1.6mx1.0mx0.20m EN PASE DE AGUA | 24d | 2023-06-08 | 2023-07-07 | A1170 | 93.25d |
| A1190 |  | SUMINISTRO Y MONTAJE DE PANELES DE C°A° 2.20mx1.0mx0.20m EN PASE DE AGUA | 24d | 2023-06-08 | 2023-07-07 | A1180 SS | 93.25d |
|  | 4 | **CABEZAL DE ENTRADA Y SALIDA** |  | 2023-07-07 | 2023-07-13 |  |  |
| A1210 |  | ENCOFRADO Y DESENCOFRADO RECTO | 3d | 2023-07-07 | 2023-07-11 | A1190 | 93.25d |
| A1200 |  | CONCRETOS | 2d | 2023-07-11 | 2023-07-13 | A1210 | 93.25d |
|  | 4 | **DESCOLMATACIÓN DE CAUCE Y OBRAS AUXILIARES** |  | 2023-05-17 | 2023-11-03 |  |  |
|  | 1 | **DESBROCE Y DESCOLMATACIÓN** |  | 2023-05-17 | 2023-08-11 |  |  |
| A1220 |  | DESBROCE Y LIMPIEZA EN ZONA NO BOSCOSA | 61d | 2023-05-17 | 2023-07-31 | A1070 SS+4d, A1015, A1040 SS+1.25d | 0d |
| A1230 |  | DESCOLMATACIÓN DE CAUCE NATURAL DEL RÍO LACRAMARCA - DIQUE A3-D-01 | 8d | 2023-05-17 | 2023-05-26 | A1220 SS | 0d |
| A1880 |  | DESCOLMATACIÓN DE CAUCE NATURAL DEL RÍO LACRAMARCA - DIQUE A3-I-01 | 27d | 2023-05-17 | 2023-06-17 | A1230 SS | 0d |
| A1870 |  | DESCOLMATACIÓN DE CAUCE NATURAL DEL RÍO LACRAMARCA - DIQUE A3-D-02 | 43d | 2023-05-26 | 2023-07-17 | A1230 | 33d |
| A1890 |  | DESCOLMATACIÓN DE CAUCE NATURAL DEL RÍO LACRAMARCA - DIQUE A3-I-02 | 16d | 2023-06-17 | 2023-07-07 | A1880 | 12.75d |
| A1900 |  | DESCOLMATACIÓN DE CAUCE NATURAL DEL RÍO LACRAMARCA - DIQUE A3-I-03 | 28d | 2023-07-07 | 2023-08-11 | A1890 | 14.75d |
|  | 2 | **DESVIO DEL CAUCE** |  | 2023-05-18 | 2023-11-03 |  |  |
|  | 1 | **A3-D-01** |  | 2023-06-17 | 2023-06-28 |  |  |
| A1240 |  | CONFORMACIÓN DE DESVIO EN CAUCE DE RÍO - DIQUE A3-D-01 | 4d | 2023-06-17 | 2023-06-22 | A1230 SS+2d, A1330 FF+1d | 0d |
| A1250 |  | RELLENO NO ESTRUCTURAL CON MATERIAL PROPIO - DIQUE A3-D-01 | 6d | 2023-06-21 | 2023-06-28 | A1330 | 74.75d |
|  | 2 | **A3-D-02** |  | 2023-07-07 | 2023-10-18 |  |  |
| A1790 |  | CONFORMACIÓN DE DESVIO EN CAUCE DE RÍO - DIQUE A3-D-02 - TRAMO 1 | 4d | 2023-07-07 | 2023-07-12 | A1870 SS+2d, A1510 FF+1d | 0d |
| A1800 |  | RELLENO NO ESTRUCTURAL CON MATERIAL PROPIO - DIQUE A3-D-02 - TRAMO 1 | 6d | 2023-07-15 | 2023-07-22 | A1420, A1250 | 60.75d |
| A2630 |  | CONFORMACIÓN DE DESVIO EN CAUCE DE RÍO - DIQUE A3-D-02 - TRAMO 2 | 4d | 2023-07-31 | 2023-08-04 | A1600 FF+1d | 0d |
| A2640 |  | RELLENO NO ESTRUCTURAL CON MATERIAL PROPIO - DIQUE A3-D-02 - TRAMO 2 | 6d | 2023-08-08 | 2023-08-15 | A1980, A1800 | 48.75d |
| A2650 |  | CONFORMACIÓN DE DESVIO EN CAUCE DE RÍO - DIQUE A3-D-02 - TRAMO 3 | 4d | 2023-08-21 | 2023-08-25 | A1690 FF+1d | 0d |
| A2660 |  | RELLENO NO ESTRUCTURAL CON MATERIAL PROPIO - DIQUE A3-D-02 - TRAMO 3 | 6d | 2023-08-29 | 2023-09-06 | A2070, A2640 | 36.75d |
| A2670 |  | CONFORMACIÓN DE DESVIO EN CAUCE DE RÍO - DIQUE A3-D-02 - TRAMO 4 | 4d | 2023-09-12 | 2023-09-16 | A2340 FF+1d | 0d |
| A2680 |  | RELLENO NO ESTRUCTURAL CON MATERIAL PROPIO - DIQUE A3-D-02 - TRAMO 4 | 6d | 2023-09-20 | 2023-09-27 | A2160, A2660 | 24.75d |
| A2690 |  | CONFORMACIÓN DE DESVIO EN CAUCE DE RÍO - DIQUE A3-D-02 - TRAMO 5 | 4d | 2023-10-03 | 2023-10-07 | A2430 FF+1d | 0d |
| A2700 |  | RELLENO NO ESTRUCTURAL CON MATERIAL PROPIO - DIQUE A3-D-02 - TRAMO 5 | 6d | 2023-10-11 | 2023-10-18 | A2250, A2680 | 12.75d |
|  | 3 | **A3-I-01** |  | 2023-05-18 | 2023-07-18 |  |  |
| A1810 |  | CONFORMACIÓN DE DESVIO EN CAUCE DE RÍO - DIQUE A3-I-01 | 4d | 2023-05-18 | 2023-05-23 | A1880 SS+1d | 0d |
| A1820 |  | RELLENO NO ESTRUCTURAL CON MATERIAL PROPIO - DIQUE A3-I-01 | 6d | 2023-07-11 | 2023-07-18 | A1510 | 59.75d |
|  | 4 | **A3-I-02** |  | 2023-06-20 | 2023-08-10 |  |  |
| A1830 |  | CONFORMACIÓN DE DESVIO EN CAUCE DE RÍO - DIQUE A3-I-02 | 4d | 2023-06-20 | 2023-06-24 | A1890 SS+2d, A1330 FF+1d | 12.75d |
| A1840 |  | RELLENO NO ESTRUCTURAL CON MATERIAL PROPIO - DIQUE A3-I-02 | 6d | 2023-08-03 | 2023-08-10 | A1600, A1820 | 48d |
|  | 5 | **A3-I-03** |  | 2023-07-12 | 2023-11-03 |  |  |
| A1850 |  | CONFORMACIÓN DE DESVIO EN CAUCE DE RÍO - DIQUE A3-I-03 - TRAMO 1 | 4d | 2023-07-12 | 2023-07-17 | A1900 SS+2d, A1420 FF+1d | 12.75d |
| A2710 |  | CONFORMACIÓN DE DESVIO EN CAUCE DE RÍO - DIQUE A3-I-03 - TRAMO 2 | 4d | 2023-08-04 | 2023-08-09 | A1980 FF+1d | 12.75d |
| A1860 |  | RELLENO NO ESTRUCTURAL CON MATERIAL PROPIO - DIQUE A3-I-03 -TRAMO 1 | 6d | 2023-08-24 | 2023-09-01 | A1690, A1840 | 36d |
| A2730 |  | CONFORMACIÓN DE DESVIO EN CAUCE DE RÍO - DIQUE A3-I-03 - TRAMO 3 | 4d | 2023-08-25 | 2023-08-31 | A2070 FF+1d | 12.75d |
| A2720 |  | RELLENO NO ESTRUCTURAL CON MATERIAL PROPIO - DIQUE A3-I-03 -TRAMO 2 | 6d | 2023-09-15 | 2023-09-22 | A2340, A1860 | 24d |
| A2750 |  | CONFORMACIÓN DE DESVIO EN CAUCE DE RÍO - DIQUE A3-I-03 - TRAMO 4 | 4d | 2023-09-16 | 2023-09-21 | A2160 FF+1d | 12.75d |
| A2740 |  | RELLENO NO ESTRUCTURAL CON MATERIAL PROPIO - DIQUE A3-I-03 -TRAMO3 | 6d | 2023-10-06 | 2023-10-13 | A2430, A2720 | 12d |
| A2760 |  | RELLENO NO ESTRUCTURAL CON MATERIAL PROPIO - DIQUE A3-I-03 -TRAMO 4 | 5d | 2023-10-27 | 2023-11-03 | A2520, A2740 | 0d |
|  | 5 | **DIQUES DE TIERRA COMPACTADA CON ENROCADO** |  | 2023-05-23 | 2023-10-30 |  |  |
|  | 1 | **DIQUE DE TIERRA COMPACTADA A3-D-01** |  | 2023-05-23 | 2023-06-23 |  |  |
| A1260 |  | EXCAVACIÓN EN TERRENO NATURAL CON EQUIPO | 8d | 2023-05-23 | 2023-06-01 | A1810 | 0d |
| A1270 |  | EXCAVACIÓN DE UÑA CON EQUIPO | 7d | 2023-05-24 | 2023-06-01 | A1260 SS+1.25d | 76.5d |

| ID | WBS | Task | Duration | Start | Finish | Predecessors | Total float |
| --- | --- | --- | --- | --- | --- | --- | --- |
| A1280 |  | PERFILADO Y COMPACTACIÓN EN ZONA DE CORTE | 16d | 2023-05-24 | 2023-06-12 | A1260 SS+1.25d | 0d |
| A1340 |  | PREPARACIÓN DE FUNDACIÓN DE CUERPO DE DIQUE | 11d | 2023-05-24 | 2023-06-06 | A1280 SS | 0d |
| A1290 |  | CONFORMACIÓN DE CUERPO DE DIQUE CON MATERIAL PROPIO | 4d | 2023-06-06 | 2023-06-10 | A1016 | 0d |
| A1310 |  | GEOTEXTIL NO TEJIDO 400 G/M2, INC. COLOCACIÓN | 5d | 2023-06-08 | 2023-06-14 | A1290 SS+1.25d | 0d |
| A1320 |  | COLOCACION Y ACOMODO DE ROCA EN UÑA DE DIQUE | 5d | 2023-06-09 | 2023-06-15 | A1310 SS+1.25d | 0d |
| A1330 |  | COLOCACION Y ACOMODO DE ROCA EN TALUD DE DIQUE | 9d | 2023-06-10 | 2023-06-21 | A1320 SS+1.25d | 0d |
| A1300 |  | CONFORMACIÓN DE CORONA DE DIQUE CON MATERIAL PROPIO | 5d | 2023-06-17 | 2023-06-23 | A1330 FF+2d | 83.75d |
|  | 2 | **DIQUE DE TIERRA COMPACTADA A3-D-02** |  | 2023-06-24 | 2023-10-13 |  |  |
|  | 1 | **TRAMO 1** |  | 2023-06-24 | 2023-07-18 |  |  |
| A1350 |  | EXCAVACIÓN EN TERRENO NATURAL CON EQUIPO | 7d | 2023-06-24 | 2023-07-04 | A1830 | 12.75d |
| A1360 |  | EXCAVACIÓN DE UÑA CON EQUIPO | 9d | 2023-06-26 | 2023-07-07 | A1350 SS+1.25d, A1270 | 55.5d |
| A1370 |  | PERFILADO Y COMPACTACIÓN EN ZONA DE CORTE | 10d | 2023-06-26 | 2023-07-08 | A1350 SS+1.25d | 12.75d |
| A1400 |  | GEOTEXTIL NO TEJIDO 400 G/M2, INC. COLOCACIÓN | 10d | 2023-06-28 | 2023-07-11 | A1370 SS+1.25d | 12.75d |
| A1410 |  | COLOCACION Y ACOMODO DE ROCA EN UÑA DE DIQUE | 13d | 2023-06-30 | 2023-07-15 | A1400 SS+1.25d | 12.75d |
| A1420 |  | COLOCACION Y ACOMODO DE ROCA EN TALUD DE DIQUE | 12d | 2023-07-01 | 2023-07-15 | A1410 SS+1.25d | 12.75d |
| A1430 |  | PREPARACIÓN DE FUNDACIÓN DE CUERPO DE DIQUE | 4d | 2023-07-04 | 2023-07-08 | A1350 | 79.75d |
| A1380 |  | CONFORMACIÓN DE CUERPO DE DIQUE CON MATERIAL PROPIO | 4d | 2023-07-05 | 2023-07-10 | A1430 SS+1d | 79.75d |
| A1390 |  | CONFORMACIÓN DE CORONA DE DIQUE CON MATERIAL PROPIO | 5d | 2023-07-12 | 2023-07-18 | A1420 FF+2d, A1300 | 68.75d |
|  | 2 | **TRAMO 2** |  | 2023-07-17 | 2023-08-10 |  |  |
| A1910 |  | EXCAVACIÓN EN TERRENO NATURAL CON EQUIPO | 7d | 2023-07-17 | 2023-07-25 | A1850 | 12.75d |
| A1920 |  | EXCAVACIÓN DE UÑA CON EQUIPO | 9d | 2023-07-18 | 2023-07-31 | A1910 SS+1.25d, A1360 | 46.5d |
| A1930 |  | PERFILADO Y COMPACTACIÓN EN ZONA DE CORTE | 10d | 2023-07-18 | 2023-08-01 | A1910 SS+1.25d | 12.75d |
| A1960 |  | GEOTEXTIL NO TEJIDO 400 G/M2, INC. COLOCACIÓN | 10d | 2023-07-20 | 2023-08-03 | A1930 SS+1.25d | 12.75d |
| A1970 |  | COLOCACION Y ACOMODO DE ROCA EN UÑA DE DIQUE | 13d | 2023-07-21 | 2023-08-08 | A1960 SS+1.25d | 12.75d |
| A1980 |  | COLOCACION Y ACOMODO DE ROCA EN TALUD DE DIQUE | 12d | 2023-07-22 | 2023-08-08 | A1970 SS+1.25d | 12.75d |
| A1990 |  | PREPARACIÓN DE FUNDACIÓN DE CUERPO DE DIQUE | 4d | 2023-07-25 | 2023-08-01 | A1910 | 65.75d |
| A1940 |  | CONFORMACIÓN DE CUERPO DE DIQUE CON MATERIAL PROPIO | 4d | 2023-07-26 | 2023-08-02 | A1990 SS+1d, A1380 | 65.75d |
| A1950 |  | CONFORMACIÓN DE CORONA DE DIQUE CON MATERIAL PROPIO | 5d | 2023-08-04 | 2023-08-10 | A1980 FF+2d, A1390 | 55.75d |
|  | 3 | **TRAMO 3** |  | 2023-08-09 | 2023-09-01 |  |  |
| A2000 |  | EXCAVACIÓN EN TERRENO NATURAL CON EQUIPO | 7d | 2023-08-09 | 2023-08-17 | A2710 | 12.75d |
| A2010 |  | EXCAVACIÓN DE UÑA CON EQUIPO | 9d | 2023-08-10 | 2023-08-21 | A2000 SS+1.25d, A1920 | 37.5d |
| A2020 |  | PERFILADO Y COMPACTACIÓN EN ZONA DE CORTE | 10d | 2023-08-10 | 2023-08-22 | A2000 SS+1.25d | 12.75d |
| A2050 |  | GEOTEXTIL NO TEJIDO 400 G/M2, INC. COLOCACIÓN | 10d | 2023-08-12 | 2023-08-24 | A2020 SS+1.25d | 12.75d |
| A2060 |  | COLOCACION Y ACOMODO DE ROCA EN UÑA DE DIQUE | 13d | 2023-08-14 | 2023-08-29 | A2050 SS+1.25d | 12.75d |
| A2070 |  | COLOCACION Y ACOMODO DE ROCA EN TALUD DE DIQUE | 12d | 2023-08-15 | 2023-08-29 | A2060 SS+1.25d | 12.75d |
| A2080 |  | PREPARACIÓN DE FUNDACIÓN DE CUERPO DE DIQUE | 4d | 2023-08-17 | 2023-08-22 | A2000 | 51.75d |
| A2030 |  | CONFORMACIÓN DE CUERPO DE DIQUE CON MATERIAL PROPIO | 4d | 2023-08-18 | 2023-08-23 | A2080 SS+1d, A1940 | 51.75d |
| A2040 |  | CONFORMACIÓN DE CORONA DE DIQUE CON MATERIAL PROPIO | 5d | 2023-08-25 | 2023-09-01 | A2070 FF+2d, A1950 | 42.75d |
|  | 4 | **TRAMO 4** |  | 2023-08-31 | 2023-09-22 |  |  |
| A2090 |  | EXCAVACIÓN EN TERRENO NATURAL CON EQUIPO | 7d | 2023-08-31 | 2023-09-08 | A2730 | 12.75d |
| A2100 |  | EXCAVACIÓN DE UÑA CON EQUIPO | 9d | 2023-09-01 | 2023-09-12 | A2090 SS+1.25d, A2010 | 28.5d |
| A2110 |  | PERFILADO Y COMPACTACIÓN EN ZONA DE CORTE | 10d | 2023-09-01 | 2023-09-13 | A2090 SS+1.25d | 12.75d |
| A2140 |  | GEOTEXTIL NO TEJIDO 400 G/M2, INC. COLOCACIÓN | 10d | 2023-09-04 | 2023-09-15 | A2110 SS+1.25d | 12.75d |
| A2150 |  | COLOCACION Y ACOMODO DE ROCA EN UÑA DE DIQUE | 13d | 2023-09-05 | 2023-09-20 | A2140 SS+1.25d | 12.75d |
| A2160 |  | COLOCACION Y ACOMODO DE ROCA EN TALUD DE DIQUE | 12d | 2023-09-06 | 2023-09-20 | A2150 SS+1.25d | 12.75d |
| A2170 |  | PREPARACIÓN DE FUNDACIÓN DE CUERPO DE DIQUE | 4d | 2023-09-08 | 2023-09-13 | A2090 | 37.75d |
| A2120 |  | CONFORMACIÓN DE CUERPO DE DIQUE CON MATERIAL PROPIO | 4d | 2023-09-09 | 2023-09-14 | A2170 SS+1d, A2030 | 37.75d |
| A2130 |  | CONFORMACIÓN DE CORONA DE DIQUE CON MATERIAL PROPIO | 5d | 2023-09-16 | 2023-09-22 | A2160 FF+2d, A2040 | 29.75d |
|  | 5 | **TRAMO 5** |  | 2023-09-21 | 2023-10-13 |  |  |
| A2180 |  | EXCAVACIÓN EN TERRENO NATURAL CON EQUIPO | 7d | 2023-09-21 | 2023-09-29 | A2750 | 12.75d |
| A2190 |  | EXCAVACIÓN DE UÑA CON EQUIPO | 9d | 2023-09-22 | 2023-10-03 | A2180 SS+1.25d, A2100 | 19.5d |
| A2200 |  | PERFILADO Y COMPACTACIÓN EN ZONA DE CORTE | 10d | 2023-09-22 | 2023-10-04 | A2180 SS+1.25d | 12.75d |
| A2230 |  | GEOTEXTIL NO TEJIDO 400 G/M2, INC. COLOCACIÓN | 10d | 2023-09-25 | 2023-10-06 | A2200 SS+1.25d | 12.75d |
| A2240 |  | COLOCACION Y ACOMODO DE ROCA EN UÑA DE DIQUE | 13d | 2023-09-26 | 2023-10-11 | A2230 SS+1.25d | 12.75d |
| A2250 |  | COLOCACION Y ACOMODO DE ROCA EN TALUD DE DIQUE | 12d | 2023-09-27 | 2023-10-11 | A2240 SS+1.25d | 12.75d |
| A2260 |  | PREPARACIÓN DE FUNDACIÓN DE CUERPO DE DIQUE | 4d | 2023-09-29 | 2023-10-04 | A2180 | 23.75d |
| A2210 |  | CONFORMACIÓN DE CUERPO DE DIQUE CON MATERIAL PROPIO | 4d | 2023-09-30 | 2023-10-05 | A2260 SS+1d, A2120 | 23.75d |
| A2220 |  | CONFORMACIÓN DE CORONA DE DIQUE CON MATERIAL PROPIO | 5d | 2023-10-07 | 2023-10-13 | A2250 FF+2d, A2130 | 16.75d |
|  | 3 | **DIQUE DE TIERRA COMPACTADA A3-I-01** |  | 2023-06-22 | 2023-07-13 |  |  |
| A1440 |  | EXCAVACIÓN EN TERRENO NATURAL CON EQUIPO | 9d | 2023-06-22 | 2023-07-04 | A1240 | 0d |
| A1450 |  | EXCAVACIÓN DE UÑA CON EQUIPO | 8d | 2023-06-23 | 2023-07-04 | A1440 SS+1.25d | 49.5d |
| A1460 |  | PERFILADO Y COMPACTACIÓN EN ZONA DE CORTE | 9d | 2023-06-23 | 2023-07-05 | A1440 SS+1.25d | 0d |
| A1520 |  | PREPARACIÓN DE FUNDACIÓN DE CUERPO DE DIQUE | 9d | 2023-06-23 | 2023-07-05 | A1460 SS | 0d |
| A1470 |  | CONFORMACIÓN DE CUERPO DE DIQUE CON MATERIAL PROPIO | 6d | 2023-06-24 | 2023-07-03 | A1520 SS+1d | 0d |
| A1490 |  | GEOTEXTIL NO TEJIDO 400 G/M2, INC. COLOCACIÓN | 5d | 2023-06-27 | 2023-07-04 | A1470 SS+1.25d | 0d |
| A1500 |  | COLOCACION Y ACOMODO DE ROCA EN UÑA DE DIQUE | 5d | 2023-06-28 | 2023-07-05 | A1490 SS+1.25d | 0d |
| A1510 |  | COLOCACION Y ACOMODO DE ROCA EN TALUD DE DIQUE | 9d | 2023-06-30 | 2023-07-11 | A1500 SS+1.25d | 0d |
| A1480 |  | CONFORMACIÓN DE CORONA DE DIQUE CON MATERIAL PROPIO | 4d | 2023-07-08 | 2023-07-13 | A1510 FF+2d | 26.25d |
|  | 4 | **DIQUE DE TIERRA COMPACTADA A3-I-02** |  | 2023-07-12 | 2023-08-05 |  |  |
| A1530 |  | EXCAVACIÓN EN TERRENO NATURAL CON EQUIPO | 12d | 2023-07-12 | 2023-07-26 | A1790 | 0d |

| ID | WBS | Task | Duration | Start | Finish | Predecessors | Total float |
| --- | --- | --- | --- | --- | --- | --- | --- |
| A1540 |  | EXCAVACIÓN DE UÑA CON EQUIPO | 11d | 2023-07-13 | 2023-07-26 | A1530 SS+1.25d, A1450 | 41.5d |
| A1550 |  | PERFILADO Y COMPACTACIÓN EN ZONA DE CORTE | 9d | 2023-07-15 | 2023-07-26 | A1530 SS+3d | 0d |
| A1580 |  | GEOTEXTIL NO TEJIDO 400 G/M2, INC. COLOCACIÓN | 9d | 2023-07-17 | 2023-07-27 | A1550 SS+1.25d | 0d |
| A1590 |  | COLOCACION Y ACOMODO DE ROCA EN UÑA DE DIQUE | 8d | 2023-07-19 | 2023-07-28 | A1580 SS+1.25d | 0d |
| A1600 |  | COLOCACION Y ACOMODO DE ROCA EN TALUD DE DIQUE | 10d | 2023-07-20 | 2023-08-03 | A1590 SS+1.25d | 0d |
| A1610 |  | PREPARACIÓN DE FUNDACIÓN DE CUERPO DE DIQUE | 2d | 2023-07-21 | 2023-07-24 | A1530 SS+8d | 60.75d |
| A1560 |  | CONFORMACIÓN DE CUERPO DE DIQUE CON MATERIAL PROPIO | 2d | 2023-07-22 | 2023-07-25 | A1610 SS+1d | 60.75d |
| A1570 |  | CONFORMACIÓN DE CORONA DE DIQUE CON MATERIAL PROPIO | 5d | 2023-07-31 | 2023-08-05 | A1600 FF+2d, A1480 | 13.5d |
|  | 5 | **DIQUE DE TIERRA COMPACTADA A3-I-03** |  | 2023-08-04 | 2023-10-30 |  |  |
|  | 1 | **TRAMO 1** |  | 2023-08-04 | 2023-08-26 |  |  |
| A1620 |  | EXCAVACIÓN EN TERRENO NATURAL CON EQUIPO | 6d | 2023-08-04 | 2023-08-11 | A2630 | 0d |
| A1630 |  | EXCAVACIÓN DE UÑA CON EQUIPO | 9d | 2023-08-05 | 2023-08-16 | A1620 SS+1.25d, A1540 | 34.75d |
| A1640 |  | PERFILADO Y COMPACTACIÓN EN ZONA DE CORTE | 10d | 2023-08-05 | 2023-08-17 | A1620 SS+1.25d | 0d |
| A1670 |  | GEOTEXTIL NO TEJIDO 400 G/M2, INC. COLOCACIÓN | 10d | 2023-08-07 | 2023-08-18 | A1640 SS+1.25d | 0d |
| A1680 |  | COLOCACION Y ACOMODO DE ROCA EN UÑA DE DIQUE | 13d | 2023-08-09 | 2023-08-24 | A1670 SS+1.25d | 0d |
| A1690 |  | COLOCACION Y ACOMODO DE ROCA EN TALUD DE DIQUE | 12d | 2023-08-10 | 2023-08-24 | A1680 SS+1.25d | 0d |
| A1700 |  | PREPARACIÓN DE FUNDACIÓN DE CUERPO DE DIQUE | 4d | 2023-08-11 | 2023-08-16 | A1620 | 47d |
| A1650 |  | CONFORMACIÓN DE CUERPO DE DIQUE CON MATERIAL PROPIO | 4d | 2023-08-12 | 2023-08-17 | A1700 SS+1d, A1560 | 47d |
| A1660 |  | CONFORMACIÓN DE CORONA DE DIQUE CON MATERIAL PROPIO | 5d | 2023-08-21 | 2023-08-26 | A1690 FF+2d, A1570 | 42d |
|  | 2 | **TRAMO 2** |  | 2023-08-25 | 2023-09-18 |  |  |
| A2270 |  | EXCAVACIÓN EN TERRENO NATURAL CON EQUIPO | 6d | 2023-08-25 | 2023-09-02 | A2650 | 0d |
| A2280 |  | EXCAVACIÓN DE UÑA CON EQUIPO | 9d | 2023-08-26 | 2023-09-07 | A2270 SS+1.25d, A1630 | 25.75d |
| A2290 |  | PERFILADO Y COMPACTACIÓN EN ZONA DE CORTE | 10d | 2023-08-26 | 2023-09-08 | A2270 SS+1.25d | 0d |
| A2320 |  | GEOTEXTIL NO TEJIDO 400 G/M2, INC. COLOCACIÓN | 10d | 2023-08-28 | 2023-09-09 | A2290 SS+1.25d | 0d |
| A2330 |  | COLOCACION Y ACOMODO DE ROCA EN UÑA DE DIQUE | 13d | 2023-08-31 | 2023-09-15 | A2320 SS+1.25d | 0d |
| A2340 |  | COLOCACION Y ACOMODO DE ROCA EN TALUD DE DIQUE | 12d | 2023-09-01 | 2023-09-15 | A2330 SS+1.25d | 0d |
| A2350 |  | PREPARACIÓN DE FUNDACIÓN DE CUERPO DE DIQUE | 4d | 2023-09-02 | 2023-09-07 | A2270 | 33d |
| A2300 |  | CONFORMACIÓN DE CUERPO DE DIQUE CON MATERIAL PROPIO | 4d | 2023-09-04 | 2023-09-08 | A2350 SS+1d, A1650 | 33d |
| A2310 |  | CONFORMACIÓN DE CORONA DE DIQUE CON MATERIAL PROPIO | 5d | 2023-09-12 | 2023-09-18 | A2340 FF+2d, A1660 | 29d |
|  | 3 | **TRAMO 3** |  | 2023-09-16 | 2023-10-09 |  |  |
| A2360 |  | EXCAVACIÓN EN TERRENO NATURAL CON EQUIPO | 6d | 2023-09-16 | 2023-09-23 | A2670 | 0d |
| A2370 |  | EXCAVACIÓN DE UÑA CON EQUIPO | 9d | 2023-09-18 | 2023-09-28 | A2360 SS+1.25d, A2280 | 16.75d |
| A2380 |  | PERFILADO Y COMPACTACIÓN EN ZONA DE CORTE | 10d | 2023-09-18 | 2023-09-29 | A2360 SS+1.25d | 0d |
| A2410 |  | GEOTEXTIL NO TEJIDO 400 G/M2, INC. COLOCACIÓN | 10d | 2023-09-19 | 2023-09-30 | A2380 SS+1.25d | 0d |
| A2420 |  | COLOCACION Y ACOMODO DE ROCA EN UÑA DE DIQUE | 13d | 2023-09-21 | 2023-10-06 | A2410 SS+1.25d | 0d |
| A2430 |  | COLOCACION Y ACOMODO DE ROCA EN TALUD DE DIQUE | 12d | 2023-09-22 | 2023-10-06 | A2420 SS+1.25d | 0d |
| A2440 |  | PREPARACIÓN DE FUNDACIÓN DE CUERPO DE DIQUE | 4d | 2023-09-23 | 2023-09-28 | A2360 | 19d |
| A2390 |  | CONFORMACIÓN DE CUERPO DE DIQUE CON MATERIAL PROPIO | 4d | 2023-09-25 | 2023-09-29 | A2440 SS+1d, A2300 | 19d |
| A2400 |  | CONFORMACIÓN DE CORONA DE DIQUE CON MATERIAL PROPIO | 5d | 2023-10-03 | 2023-10-09 | A2430 FF+2d, A2310 | 16d |
|  | 4 | **TRAMO 4** |  | 2023-10-07 | 2023-10-30 |  |  |
| A2450 |  | EXCAVACIÓN EN TERRENO NATURAL CON EQUIPO | 6d | 2023-10-07 | 2023-10-14 | A2690 | 0d |
| A2460 |  | EXCAVACIÓN DE UÑA CON EQUIPO | 9d | 2023-10-09 | 2023-10-19 | A2450 SS+1.25d, A2370 | 7.75d |
| A2470 |  | PERFILADO Y COMPACTACIÓN EN ZONA DE CORTE | 10d | 2023-10-09 | 2023-10-20 | A2450 SS+1.25d | 0d |
| A2500 |  | GEOTEXTIL NO TEJIDO 400 G/M2, INC. COLOCACIÓN | 10d | 2023-10-10 | 2023-10-21 | A2470 SS+1.25d | 0d |
| A2510 |  | COLOCACION Y ACOMODO DE ROCA EN UÑA DE DIQUE | 13d | 2023-10-12 | 2023-10-27 | A2500 SS+1.25d | 0d |
| A2520 |  | COLOCACION Y ACOMODO DE ROCA EN TALUD DE DIQUE | 12d | 2023-10-13 | 2023-10-27 | A2510 SS+1.25d | 0d |
| A2530 |  | PREPARACIÓN DE FUNDACIÓN DE CUERPO DE DIQUE | 4d | 2023-10-14 | 2023-10-19 | A2450 | 5d |
| A2480 |  | CONFORMACIÓN DE CUERPO DE DIQUE CON MATERIAL PROPIO | 4d | 2023-10-16 | 2023-10-20 | A2530 SS+1d, A2390 | 5d |
| A2490 |  | CONFORMACIÓN DE CORONA DE DIQUE CON MATERIAL PROPIO | 5d | 2023-10-24 | 2023-10-30 | A2520 FF+2d, A2400 | 3d |
|  | 6 | **RAMPAS** |  | 2023-10-03 | 2023-10-24 |  |  |
|  | 1 | **A3-RA-D-01** |  | 2023-10-03 | 2023-10-07 |  |  |
| A1710 |  | EXCAVACIÓN EN TERRENO NATURAL CON EQUIPO | 2d | 2023-10-03 | 2023-10-05 | A2190 | 19.5d |
| A1720 |  | CONFORMACIÓN DE CUERPO DE RAMPA CON MATERIAL PROPIO | 2d | 2023-10-05 | 2023-10-07 | A1710 | 19.5d |
| A1730 |  | CONFORMACIÓN DE CORONACIÓN DE RAMPA | 2d | 2023-10-05 | 2023-10-07 | A1720 SS | 19.5d |
|  | 2 | **A3-RA-I-01** |  | 2023-10-19 | 2023-10-24 |  |  |
| A1740 |  | EXCAVACIÓN EN TERRENO NATURAL CON EQUIPO | 2d | 2023-10-19 | 2023-10-21 | A2460 | 7.75d |
| A1750 |  | CONFORMACIÓN DE CUERPO DE RAMPA CON MATERIAL PROPIO | 2d | 2023-10-21 | 2023-10-24 | A1740 | 7.75d |
| A1760 |  | CONFORMACIÓN DE CORONACIÓN DE RAMPA | 2d | 2023-10-21 | 2023-10-24 | A1750 SS, A1730 | 7.75d |
|  | 2 | **OBRAS DE ARTE** |  | 2023-05-15 | 2023-10-31 |  |  |
|  | 1 | **CAPTACIÓN A3-CP-23-95** |  | 2023-05-27 | 2023-09-24 |  |  |
|  | 1 | **MOVIMIENTO DE TIERRAS** |  | 2023-05-27 | 2023-07-17 |  |  |
| A2770 |  | EXCAVACIÓN ESTRUCTURAL PARA OBRAS DE ARTE | 5d | 2023-05-27 | 2023-06-02 | A3390 | 33.25d |
| A2780 |  | RELLENO ESTRUCTURAL PARA OBRAS DE ARTE, CON MATERIAL PROPIO | 4d | 2023-07-12 | 2023-07-17 | A2800 FS+12d | 76.75d |
|  | 2 | **OBRAS DE CONCRETO** |  | 2023-06-02 | 2023-06-27 |  |  |
| A2790 |  | CONCRETO f'c=100 kg/cm2 | 2d | 2023-06-02 | 2023-06-05 | A2770 | 44.25d |
| A2810 |  | CONCRETO CICLÓPEO f'c=280 kg/cm2 + 30% P.G. | 2d | 2023-06-05 | 2023-06-07 | A2790 | 44.25d |
| A2830 |  | ACERO DE REFUERZO fy=4200 kg/cm2 | 11d | 2023-06-07 | 2023-06-20 | A2810 | 44.25d |
| A2820 |  | ENCOFRADO Y DESENCOFRADO RECTO | 8d | 2023-06-12 | 2023-06-21 | A2830 FF+1d | 45.75d |
| A2800 |  | CONCRETO f'c=280 kg/cm2 | 10d | 2023-06-15 | 2023-06-27 | A2820 SS+3d | 46.75d |
|  | 3 | **ESTRUCTURAS METALICAS** |  | 2023-07-12 | 2023-07-24 |  |  |

| ID | WBS | Task | Duration | Start | Finish | Predecessors | Total float |
| --- | --- | --- | --- | --- | --- | --- | --- |
| A2840 |  | COMPUERTA METALICA PLANA DESLIZANTE DE 1.0x1.0m | 2d | 2023-07-12 | 2023-07-14 | A2800 FS+12d | 83.75d |
| A2850 |  | REJILLA DE 1.00x1.00m CON VARILLA DE 1/2" CADA 6,25cm | 2d | 2023-07-14 | 2023-07-17 | A2840 | 83.75d |
| A2860 |  | BARANDA DE FIERRO GALVANIZADO 1 1/2" | 2d | 2023-07-17 | 2023-07-19 | A2850 | 83.75d |
| A2870 |  | ESCALERA TIPO GATO | 2d | 2023-07-19 | 2023-07-21 | A2860 | 83.75d |
| A2880 |  | TAPA METALICA CIRCULAR DN600 MM | 2d | 2023-07-21 | 2023-07-24 | A2870 | 83.75d |
|  | 4 | **TUBERIAS** |  | 2023-06-02 | 2023-07-31 |  |  |
| A2890 |  | EXCAVACIÓN ESTRUCTURAL PARA OBRAS DE ARTE (Buzones) | 2d | 2023-06-02 | 2023-06-05 | A2770 | 33.25d |
| A2900 |  | EXCAVACIÓN DE ZANJA | 21d | 2023-06-05 | 2023-06-30 | A2890 | 33.25d |
| A2920 |  | CAMA DE ARENA | 21d | 2023-06-08 | 2023-07-04 | A2900 SS+3d | 79.75d |
| A2940 |  | CONCRETO f'c=100 kg/cm2 (Buzones) | 2d | 2023-06-08 | 2023-06-10 | A2900 SS+3d, A2790 | 52.25d |
| A2990 |  | SUMINISTRO E INSTALACIÓN DE TUBERÍA GRP DN600 mm SN2500 | 21d | 2023-06-09 | 2023-07-05 | A2920 SS+1d | 79.75d |
| A2980 |  | ACERO DE REFUERZO fy=4200 kg/cm2 (Buzones) | 2.5d | 2023-06-20 | 2023-06-23 | A2940, A2830 | 44.25d |
| A2960 |  | ENCOFRADO Y DESENCOFRADO RECTO | 4d | 2023-06-23 | 2023-06-28 | A2820, A2980 | 44.25d |
| A2970 |  | ENCOFRADO Y DESENCOFRADO CURVO | 4d | 2023-06-23 | 2023-06-28 | A2960 SS | 44.25d |
| A2950 |  | CONCRETO f'c=280 kg/cm2 (Buzones) | 2d | 2023-06-28 | 2023-07-01 | A2970, A2800 | 46.25d |
| A2930 |  | RELLENO COMÚN PARA ZANJAS | 20d | 2023-07-05 | 2023-07-31 | A2990 | 79.75d |
| A2910 |  | RELLENO ESTRUCTURAL PARA OBRAS DE ARTE CON MATERIAL PROPIO (Buzones) | 2d | 2023-07-17 | 2023-07-19 | A2950 FS+12d, A2780 | 76.75d |
|  | 5 | **CANAL** |  | 2023-06-30 | 2023-09-06 |  |  |
| A3000 |  | EXCAVACIÓN ESTRUCTURAL PARA OBRAS DE ARTE | 5d | 2023-06-30 | 2023-07-06 | A2900 | 33.25d |
| A3020 |  | COLOCACIÓN DE CONCRETO f'c=100 kg/cm2 | 2.5d | 2023-07-06 | 2023-07-09 | A2940, A3000 | 33.25d |
| A3050 |  | ACERO DE REFUERZO fy=4200 kg/cm2 | 22d | 2023-07-10 | 2023-08-06 | A2980, A3020 | 33.25d |
| A3040 |  | ENCOFRADO Y DESENCOFRADO RECTO | 43d | 2023-07-12 | 2023-09-03 | A2970, A3050 SS+2d | 33.25d |
| A3030 |  | COLOCACIÓN DE CONCRETO f'c=280 kg/cm2 | 43d | 2023-07-14 | 2023-09-06 | A2950 SS, A3040 SS+2d | 33.25d |
| A3060 |  | JUNTA WATER STOP SIN BULBO 150 mm | 43d | 2023-07-14 | 2023-09-06 | A3030 SS | 47.25d |
| A3010 |  | RELLENO ESTRUCTURAL PARA CANALES, CON MATERIAL PROPIO | 9d | 2023-07-19 | 2023-08-01 | A2910 | 76.75d |
|  | 6 | **OBRAS DE DESCARGA** |  | 2023-07-06 | 2023-09-24 |  |  |
| A3070 |  | EXCAVACIÓN ESTRUCTURAL PARA OBRAS DE ARTE | 2d | 2023-07-06 | 2023-07-08 | A3000 | 74.75d |
| A3090 |  | CONCRETO f'c=100 kg/cm2 | 2d | 2023-07-10 | 2023-07-12 | A3070, A3020 | 74.25d |
| A3120 |  | ACERO DE REFUERZO fy=4200 kg/cm2 | 2d | 2023-08-07 | 2023-08-09 | A3090, A3050 | 54.25d |
| A3110 |  | ENCOFRADO Y DESENCOFRADO RECTO | 2d | 2023-09-04 | 2023-09-06 | A3120, A3040 | 33.25d |
| A3100 |  | CONCRETO f'c=280 kg/cm2 | 2d | 2023-09-06 | 2023-09-08 | A3110, A3030 | 33.25d |
| A3130 |  | JUNTA WATER STOP SIN BULBO 150 mm | 2d | 2023-09-08 | 2023-09-10 | A3100, A3060 | 45.25d |
| A3080 |  | RELLENO ESTRUCTURAL PARA OBRAS DE ARTE CON MATERIAL PROPIO | 2d | 2023-09-22 | 2023-09-24 | A3100 FS+12d, A3010 | 33.25d |
| A3140 |  | COMPUERTA METALICA PLANA DESLIZANTE | 2d | 2023-09-22 | 2023-09-24 | A3100 FS+12d | 33.25d |
|  | 2 | **CAPTACIÓN A3-CP-21-05** |  | 2023-05-18 | 2023-08-15 |  |  |
|  | 1 | **MOVIMIENTO DE TIERRAS** |  | 2023-05-18 | 2023-07-08 |  |  |
| A3150 |  | EXCAVACIÓN ESTRUCTURAL PARA OBRAS DE ARTE | 2.5d | 2023-05-18 | 2023-05-20 | A1070 SS+6d | 33.25d |
| A3160 |  | RELLENO ESTRUCTURAL PARA OBRAS DE ARTE, CON MATERIAL PROPIO | 4d | 2023-07-04 | 2023-07-08 | A3180 FS+12d | 96.75d |
|  | 2 | **OBRAS DE CONCRETO** |  | 2023-05-20 | 2023-06-19 |  |  |
| A3170 |  | CONCRETO f'c=100 kg/cm2 | 2d | 2023-05-20 | 2023-05-23 | A3150 | 66.75d |
| A3190 |  | CONCRETO CICLÓPEO f'c=280 kg/cm2 + 30% P.G. | 2d | 2023-05-23 | 2023-05-25 | A3170 | 66.75d |
| A3210 |  | ACERO DE REFUERZO fy=4200 kg/cm2 | 17d | 2023-05-25 | 2023-06-14 | A3190 | 66.75d |
| A3200 |  | ENCOFRADO Y DESENCOFRADO RECTO | 12d | 2023-06-01 | 2023-06-15 | A3210 SS+6d | 68.75d |
| A3180 |  | CONCRETO f'c=280 kg/cm2 | 9d | 2023-06-08 | 2023-06-19 | A3200 SS+6d | 89.75d |
|  | 3 | **ESTRUCTURAS METALICAS** |  | 2023-07-04 | 2023-07-15 |  |  |
| A3220 |  | COMPUERTA METALICA PLANA DESLIZANTE DE 1.0x1.0m | 2d | 2023-07-04 | 2023-07-06 | A3180 FS+12d | 90.75d |
| A3230 |  | REJILLA DE 1.00x1.00m CON VARILLA DE 1/2 CADA 6,25cm | 2d | 2023-07-06 | 2023-07-08 | A3220 | 90.75d |
| A3240 |  | BARANDA DE FIERRO GALVANIZADO 1 1/2" | 2d | 2023-07-08 | 2023-07-11 | A3230 | 90.75d |
| A3250 |  | ESCALERA TIPO GATO | 2d | 2023-07-11 | 2023-07-13 | A3240 | 90.75d |
| A3260 |  | TAPA METALICA CIRCULAR DN600 MM | 2d | 2023-07-13 | 2023-07-15 | A3250 | 90.75d |
|  | 4 | **TUBERIA** |  | 2023-05-20 | 2023-07-08 |  |  |
| A3270 |  | EXCAVACIÓN ESTRUCTURAL PARA OBRAS DE ARTE (Buzones) | 2d | 2023-05-20 | 2023-05-23 | A3150 | 33.25d |
| A3280 |  | EXCAVACIÓN DE ZANJA | 2d | 2023-05-23 | 2023-05-25 | A3270 | 122.75d |
| A3330 |  | CONCRETO f'c=100 kg/cm2 (Buzones) | 2d | 2023-05-23 | 2023-05-25 | A3270, A3170 | 83.75d |
| A3300 |  | CAMA DE ARENA | 2d | 2023-05-25 | 2023-05-27 | A3280 | 122.75d |
| A3380 |  | SUMINISTRO E INSTALACIÓN DE TUBERÍA GRP DN600 mm SN2500 | 2d | 2023-05-27 | 2023-05-30 | A3300 | 122.75d |
| A3310 |  | RELLENO SELECCIONADO PARA ZANJAS CON MATERIAL PROPIO | 2d | 2023-05-30 | 2023-06-01 | A3320 SS | 122.75d |
| A3320 |  | RELLENO COMÚN PARA ZANJAS | 2d | 2023-05-30 | 2023-06-01 | A3380 | 122.75d |
| A3370 |  | ACERO DE REFUERZO fy=4200 kg/cm2 | 2d | 2023-06-14 | 2023-06-16 | A3330, A3210 | 66.75d |
| A3350 |  | ENCOFRADO Y DESENCOFRADO RECTO | 2d | 2023-06-16 | 2023-06-19 | A3370, A3200 | 67.75d |
| A3360 |  | ENCOFRADO Y DESENCOFRADO CURVO | 2d | 2023-06-16 | 2023-06-19 | A3350 SS | 67.75d |
| A3340 |  | CONCRETO f'c=280 kg/cm2 (Buzones) | 2d | 2023-06-19 | 2023-06-21 | A3360, A3180 | 89.75d |
| A3290 |  | RELLENO ESTRUCTURAL PARA OBRAS DE ARTE CON MATERIAL PROPIO | 2d | 2023-07-06 | 2023-07-08 | A3340 FS+12d | 91.75d |
|  | 5 | **CANALES** |  | 2023-05-23 | 2023-08-15 |  |  |
| A3390 |  | EXCAVACIÓN ESTRUCTURAL PARA OBRAS DE ARTE | 4d | 2023-05-23 | 2023-05-27 | A3270, A3270 FF | 33.25d |
| A3410 |  | COLOCACIÓN DE CONCRETO f'c=100 kg/cm2 | 2d | 2023-05-27 | 2023-05-30 | A3390, A3330 | 81.75d |
| A3440 |  | ACERO DE REFUERZO fy=4200 kg/cm2 | 10d | 2023-06-16 | 2023-06-28 | A3410, A3370 | 66.75d |
| A3430 |  | ENCOFRADO Y DESENCOFRADO | 24d | 2023-06-20 | 2023-07-19 | A3440 SS+3d, A3360 | 66.75d |
| A3420 |  | COLOCACIÓN DE CONCRETO f'c=280 kg/cm2 | 4d | 2023-07-19 | 2023-07-24 | A3430, A3340 | 66.75d |
| A3450 |  | JUNTA WATER STOP SIN BULBO 150 mm | 2d | 2023-07-19 | 2023-07-21 | A3420 SS | 85.75d |

| ID | WBS | Task | Duration | Start | Finish | Predecessors | Total float |
| --- | --- | --- | --- | --- | --- | --- | --- |
| A3400 |  | RELLENO ESTRUCTURAL PARA CANALES, CON MATERIAL PROPIO | 5d | 2023-08-09 | 2023-08-15 | A3420 FS+12d, A3290, A3310 | 66.75d |
|  | 3 | **RETORNO A3-OA-RE-D-21-55** |  | 2023-05-15 | 2023-07-07 |  |  |
|  | 1 | **MOVIMIENTO DE TIERRAS** |  | 2023-05-15 | 2023-07-05 |  |  |
| A3460 |  | EXCAVACIÓN ESTRUCTURAL PARA OBRAS DE ARTE | 2d | 2023-05-15 | 2023-05-17 | A1070 SS+3d | 97.75d |
| A3470 |  | RELLENO ESTRUCTURAL PARA OBRAS DE ARTE, CON MATERIAL PROPIO | 2d | 2023-07-03 | 2023-07-05 | A3490 FS+12d | 100.25d |
|  | 2 | **OBRAS DE CONCRETO** |  | 2023-05-17 | 2023-06-17 |  |  |
| A3480 |  | CONCRETO f'c=100 kg/cm2 | 2d | 2023-05-17 | 2023-05-19 | A3460 | 97.75d |
| A3500 |  | CONCRETO CICLÓPEO f'c=280 kg/cm2 + 30% P.G. | 4d | 2023-05-19 | 2023-05-24 | A3480 | 97.75d |
| A3520 |  | ACERO DE REFUERZO fy=4200 kg/cm2 | 20d | 2023-05-19 | 2023-06-11 | A3500 SS | 97.75d |
| A3510 |  | ENCOFRADO Y DESENCOFRADO | 15d | 2023-05-26 | 2023-06-13 | A3520 SS+6d | 97.75d |
| A3490 |  | CONCRETO f'c=280 kg/cm2 | 4d | 2023-06-13 | 2023-06-17 | A3510 | 97.75d |
| A3530 |  | JUNTA WATER STOP SIN BULBO 150 mm | 4d | 2023-06-13 | 2023-06-17 | A3490 SS | 114.25d |
|  | 3 | **ESTRUCTURAS METALICAS** |  | 2023-07-03 | 2023-07-07 |  |  |
| A3540 |  | COMPUERTA METALICA PLANA DESLIZANTE DE 1.0x1.6 m | 2.5d | 2023-07-03 | 2023-07-05 | A3490 FS+12d | 97.75d |
| A3550 |  | BARANDA DE FIERRO GALVANIZADO 1 1/2" | 2d | 2023-07-05 | 2023-07-07 | A3540 | 97.75d |
|  | 4 | **REPOSICIÓN DE CANALES** |  | 2023-06-01 | 2023-10-31 |  |  |
|  | 1 | **REPOSICIÓN DE CANAL 1** |  | 2023-07-26 | 2023-10-31 |  |  |
|  | 1 | **MOVIMIENTO DE TIERRAS** |  | 2023-07-26 | 2023-10-31 |  |  |
| A3560 |  | DEMOLICIÓN DE ESTRUCTURAS EXISTENTES | 13d | 2023-07-26 | 2023-08-12 | A1530 | 68.75d |
| A3570 |  | EXCAVACIÓN EN TERRENO NATURAL CON EQUIPO | 29d | 2023-08-03 | 2023-09-07 | A1600 | 2d |
| A3580 |  | RELLENO ESTRUCTURAL PARA OBRAS DE ARTE CON MATERIAL PROPIO | 32d | 2023-09-23 | 2023-10-31 | A3620 SS+16d | 2d |
|  | 2 | **OBRAS DE CONCRETO** |  | 2023-08-10 | 2023-10-28 |  |  |
| A3610 |  | CONCRETO f'c=100 kg/cm2 | 29d | 2023-08-10 | 2023-09-14 | A3570 SS+6d | 2d |
| A3600 |  | ACERO DE REFUERZO fy=4200 kg/cm2 | 58d | 2023-08-14 | 2023-10-21 | A3610 SS+3d | 2d |
| A3590 |  | ENCOFRADO Y DESENCOFRADO RECTO | 52d | 2023-08-21 | 2023-10-21 | A3600 SS+6d | 2d |
| A3620 |  | CONCRETO f'c=280 kg/cm2 | 44d | 2023-09-05 | 2023-10-26 | A3590 SS+12d | 2d |
| A3630 |  | JUNTA WATER STOP 6" | 44d | 2023-09-05 | 2023-10-26 | A3620 SS | 6d |
| A3640 |  | MAMPOSTERIA DE PIEDRA, e=20cm, ACABADO CARA VISTA | 2d | 2023-10-26 | 2023-10-28 | A3620 | 4d |
|  | 2 | **REPOSICIÓN DE CANAL 3** |  | 2023-06-01 | 2023-07-27 |  |  |
|  | 1 | **MOVIMIENTO DE TIERRAS** |  | 2023-06-01 | 2023-07-27 |  |  |
| A3650 |  | DEMOLICIÓN DE ESTRUCTURAS EXISTENTES | 8d | 2023-06-01 | 2023-06-10 | A1260 | 119.75d |
| A3660 |  | EXCAVACIÓN EN TERRENO NATURAL CON EQUIPO | 2.5d | 2023-06-21 | 2023-06-24 | A1330 | 80.75d |
| A3670 |  | RELLENO ESTRUCTURAL PARA OBRAS DE ARTE CON MATERIAL PROPIO | 2d | 2023-07-25 | 2023-07-27 | A3720 FS+6d | 80.75d |
|  | 2 | **OBRAS DE CONCRETO** |  | 2023-06-24 | 2023-07-20 |  |  |
| A3710 |  | CONCRETO f'c=100 kg/cm2 | 2.5d | 2023-06-24 | 2023-06-27 | A3660 | 80.75d |
| A3700 |  | MALLA ELECTROSOLDADA DE DN6mm EN CUADRICULA 15x15 cm | 12d | 2023-06-27 | 2023-07-12 | A3710 | 80.75d |
| A3680 |  | ENCOFRADO Y DESENCOFRADO PARA REVESTIMIENTO DE CANALES (CERCHAS) | 10d | 2023-07-01 | 2023-07-13 | A3700 SS+3d | 80.75d |
| A3690 |  | ENCOFRADO Y DESENCOFRADO RECTO | 10d | 2023-07-01 | 2023-07-13 | A3680 SS | 80.75d |
| A3730 |  | SELLO DE JUNTA CONSTRUCCIÓN CON MATERIAL ELASTOMÉRICO | 8d | 2023-07-01 | 2023-07-11 | A3680 SS | 94.75d |
| A3720 |  | CONCRETO f'c=280 kg/cm2 | 4d | 2023-07-13 | 2023-07-18 | A3690 | 80.75d |
| A3740 |  | MAMPOSTERIA DE PIEDRA, e=20cm, ACABADO CARA VISTA | 2d | 2023-07-18 | 2023-07-20 | A3720 | 86.75d |
|  | 5 | **REPOSICIÓN SIFON INOPERATIVO** |  | 2023-06-17 | 2023-07-26 |  |  |
| A3750 |  | DEMOLICIÓN DE ESTRUCTURAS EXISTENTES | 2d | 2023-06-17 | 2023-06-20 | A1230, A1880 | 81.75d |
| A3760 |  | EXCAVACIÓN ESTRUCTURAL PARA OBRAS DE ARTE | 8d | 2023-06-20 | 2023-06-30 | A3750 | 81.75d |
| A3770 |  | COLOCACIÓN CAMA DE ARENA | 2d | 2023-06-30 | 2023-07-03 | A3760 | 89.75d |
| A3810 |  | CONCRETO f'c=100 kg/cm2 | 2d | 2023-06-30 | 2023-07-03 | A3760 | 81.75d |
| A3800 |  | TUBERÍAS DE 14" HDPE SDR21 DN 355mm | 5d | 2023-07-03 | 2023-07-08 | A3770 | 89.75d |
| A3840 |  | ACERO DE REFUERZO fy=4200 kg/cm2 | 2d | 2023-07-03 | 2023-07-05 | A3810 | 81.75d |
| A3850 |  | CODOS HDPE DE 14" DN 355mm | 5d | 2023-07-03 | 2023-07-08 | A3800 SS | 96.75d |
| A3830 |  | ENCOFRADO Y DESENCOFRADO RECTO | 2d | 2023-07-05 | 2023-07-07 | A3840 | 81.75d |
| A3820 |  | CONCRETO f'c=280 kg/cm2 | 2d | 2023-07-07 | 2023-07-10 | A3830 | 81.75d |
| A3790 |  | RELLENO COMÚN | 7d | 2023-07-08 | 2023-07-17 | A3800 | 89.75d |
| A3780 |  | RELLENO ESTRUCTURAL PARA OBRAS DE ARTE CON MATERIAL PROPIO | 2d | 2023-07-24 | 2023-07-26 | A3820 FS+12d | 81.75d |
|  | 3 | **ARQUITECTURA Y PAISAJISMO** |  | 2023-08-05 | 2023-10-17 |  |  |
|  | 1 | **OBRAS PRELIMINARES** |  | 2023-08-05 | 2023-10-17 |  |  |
| A3860 |  | MOVILIZACIÓN DE EQUIPOS Y HERRAMIENTAS (ARQUITECTURA Y PAISAJISMO) | 2d | 2023-08-05 | 2023-08-08 | A1570 | 13.5d |
| A3870 |  | TRAZO Y REPLANTEO PRELIMINAR | 2.5d | 2023-08-08 | 2023-08-10 | A3860 | 13.5d |
| A4020 |  | DEMOVILIZACIÓN DE EQUIPOS Y HERRAMIENTAS (ARQUITECTURA Y PAISAJISMO) | 2d | 2023-10-14 | 2023-10-17 | A4010, A3900 | 13.5d |
|  | 2 | **MOVIMIENTO DE TIERRAS** |  | 2023-08-10 | 2023-08-26 |  |  |
| A3880 |  | EXCAVACIÓN MANUAL PARA INSTALACIÓN DE BORDILLOS Y CIMENTACIONES | 2d | 2023-08-10 | 2023-08-12 | A3870 | 13.5d |
| A3900 |  | ELIMINACION DE MATERIAL EXCEDENTE (DME´S) | 14d | 2023-08-10 | 2023-08-26 | A3880 SS | 54.5d |
| A3890 |  | EXCAVACIÓN PARA MEJORAMIENTO DE SUELO CON TIERRA VEGETAL | 12d | 2023-08-12 | 2023-08-26 | A3880 | 13.5d |
|  | 3 | **PAVIMENTOS, RECUBRIMIENTOS Y BORDILLOS** |  | 2023-08-26 | 2023-09-07 |  |  |
| A3910 |  | PISO DE GRAVILLA | 2d | 2023-08-26 | 2023-08-29 | A3890 | 13.5d |
| A3920 |  | RECUBRIMIENTO DE PIEDRA DEL LUGAR e=0.05cm | 2.5d | 2023-08-29 | 2023-09-02 | A3910 | 13.5d |
| A3930 |  | BORDILLOS DE PIEDRA DEL LUGAR | 4d | 2023-09-02 | 2023-09-07 | A3920 | 13.5d |
|  | 4 | **MOBILIARIOS, BARANDAS Y ESCALERAS** |  | 2023-09-07 | 2023-10-12 |  |  |
| A3940 |  | ESCALERA DE CONCRETO SOBRE ENROCADO, CIMENTACION Y ANCLAJE | 8d | 2023-09-07 | 2023-09-16 | A3930 | 13.5d |
| A3950 |  | BARANDA DE MADERA EUCALIPTO CON SOGA, INCLUYE CIMENTACIÓN | 4d | 2023-09-16 | 2023-09-21 | A3940 | 13.5d |
| A3960 |  | TACHOS DE BASURA, INCLUYE CIMENTACIÓN | 2d | 2023-09-21 | 2023-09-23 | A3950 | 13.5d |

| ID | WBS | Task | Duration | Start | Finish | Predecessors | Total float |
| --- | --- | --- | --- | --- | --- | --- | --- |
| A3970 |  | BANCAS DE CONCRETO, INCLUYE CIMENTACIÓN | 8d | 2023-09-23 | 2023-10-03 | A3960 | 13.5d |
| A3980 |  | POSTES DE ILUMINACIÓN, INCLUYE LUMINARIA Y CIMENTACIÓN | 4d | 2023-10-03 | 2023-10-07 | A3970 | 13.5d |
| A3990 |  | SEÑALETICA INFORMATIVA | 2d | 2023-10-07 | 2023-10-10 | A3980 | 13.5d |
| A4000 |  | BOLARDOS DE PIEDRA | 2.5d | 2023-10-10 | 2023-10-12 | A3990 | 13.5d |
|  | 5 | **INSTALACIÓN DE ALCORQUES** |  | 2023-10-12 | 2023-10-14 |  |  |
| A4010 |  | ALCORQUES DE PIEDRA DE CANTO RODADO PARA ARBOLES | 2d | 2023-10-12 | 2023-10-14 | A4000 | 13.5d |
|  | 4 | **PROGRAMA DE CIERRE DE OBRA** |  | 2023-05-17 | 2023-10-31 |  |  |
| A1770 |  | ACONDICIONAMIENTO DE DEPOSITOS DE MATERIALES EXCEDENTES (DME) | 133d | 2023-05-17 | 2023-10-24 | A1220 SS | 1.75d |
| A1780 |  | RESTAURACIÓN DE ÁREAS DE INSTALACIONES PROVISIONALES | 6d | 2023-10-24 | 2023-10-31 | A2480, A1770 | 1.75d |

## Version 2 (data date 2023-10-15, saved 2023-10-09, file Cronograma de Licitacion Sub Projecto A3 rev01.xer)

Last finish 2023-11-04 → 2024-04-27 (+175d).

Added:

| ID | Task | Duration | Start | Finish | Predecessors |
| --- | --- | --- | --- | --- | --- |
| A5200 | CONFORMACIÓN DE DESVIO EN CAUCE DE RÍO | 68d | 2023-11-07 | 2024-01-13 | A1015 FS+2d |
| A5210 | RELLENO NO ESTRUCTURAL CON MATERIAL PROPIO | 89d | 2024-01-14 | 2024-04-11 | A5200 |
| 1 | **SIN AFECTACIÓN A3-D-01** |  | 2023-11-12 | 2023-11-26 |  |
| 2 | **CON AFECTACIÓN A3-D-01** |  | 2024-03-07 | 2024-03-30 |  |
| 1 | **SIN AFECTACIÓN A3-D-02** |  | 2023-11-27 | 2024-01-04 |  |
| 2 | **CON AFECTACIÓN A3-D-02** |  | 2024-01-05 | 2024-03-06 |  |
| 3 | **POR LIBERAR A3-D-02** |  | 2024-03-31 | 2024-04-22 |  |
| 1 | **SIN AFECTACIÓN A3-I-01** |  | 2023-11-13 | 2023-12-02 |  |
| 3 | **CON AFECTACIÓN A3-I-01** |  | 2024-02-26 | 2024-03-09 |  |
| 2 | **Sector por Liberar - Km 20+980 - km 21+300** |  | 2024-03-10 | 2024-04-05 |  |
| 1 | **SIN AFECTACIÓN A3-I-03** |  | 2023-12-03 | 2024-01-24 |  |
| 3 | **CON AFECTACIÓN A3-I-03** |  | 2024-01-25 | 2024-02-25 |  |
| 2 | **POR LIBERAR A3-I-03** |  | 2024-04-06 | 2024-04-25 |  |

Removed: A3-D-01; A1240 CONFORMACIÓN DE DESVIO EN CAUCE DE RÍO - DIQUE A3-D-01; A1250 RELLENO NO ESTRUCTURAL CON MATERIAL PROPIO - DIQUE A3-D-01; A3-D-02; A1790 CONFORMACIÓN DE DESVIO EN CAUCE DE RÍO - DIQUE A3-D-02 - TRAMO 1; A1800 RELLENO NO ESTRUCTURAL CON MATERIAL PROPIO - DIQUE A3-D-02 - TRAMO 1; A2630 CONFORMACIÓN DE DESVIO EN CAUCE DE RÍO - DIQUE A3-D-02 - TRAMO 2; A2640 RELLENO NO ESTRUCTURAL CON MATERIAL PROPIO - DIQUE A3-D-02 - TRAMO 2; A2650 CONFORMACIÓN DE DESVIO EN CAUCE DE RÍO - DIQUE A3-D-02 - TRAMO 3; A2660 RELLENO NO ESTRUCTURAL CON MATERIAL PROPIO - DIQUE A3-D-02 - TRAMO 3; A2670 CONFORMACIÓN DE DESVIO EN CAUCE DE RÍO - DIQUE A3-D-02 - TRAMO 4; A2680 RELLENO NO ESTRUCTURAL CON MATERIAL PROPIO - DIQUE A3-D-02 - TRAMO 4; A2690 CONFORMACIÓN DE DESVIO EN CAUCE DE RÍO - DIQUE A3-D-02 - TRAMO 5; A2700 RELLENO NO ESTRUCTURAL CON MATERIAL PROPIO - DIQUE A3-D-02 - TRAMO 5; A3-I-01; A1810 CONFORMACIÓN DE DESVIO EN CAUCE DE RÍO - DIQUE A3-I-01; A1820 RELLENO NO ESTRUCTURAL CON MATERIAL PROPIO - DIQUE A3-I-01; A3-I-02; A1830 CONFORMACIÓN DE DESVIO EN CAUCE DE RÍO - DIQUE A3-I-02; A1840 RELLENO NO ESTRUCTURAL CON MATERIAL PROPIO - DIQUE A3-I-02; A3-I-03; A1850 CONFORMACIÓN DE DESVIO EN CAUCE DE RÍO - DIQUE A3-I-03 - TRAMO 1; A2710 CONFORMACIÓN DE DESVIO EN CAUCE DE RÍO - DIQUE A3-I-03 - TRAMO 2; A1860 RELLENO NO ESTRUCTURAL CON MATERIAL PROPIO - DIQUE A3-I-03 -TRAMO 1; A2730 CONFORMACIÓN DE DESVIO EN CAUCE DE RÍO - DIQUE A3-I-03 - TRAMO 3; A2720 RELLENO NO ESTRUCTURAL CON MATERIAL PROPIO - DIQUE A3-I-03 -TRAMO 2; A2750 CONFORMACIÓN DE DESVIO EN CAUCE DE RÍO - DIQUE A3-I-03 - TRAMO 4; A2740 RELLENO NO ESTRUCTURAL CON MATERIAL PROPIO - DIQUE A3-I-03 -TRAMO3; A2760 RELLENO NO ESTRUCTURAL CON MATERIAL PROPIO - DIQUE A3-I-03 -TRAMO 4; TRAMO 1; TRAMO 2; TRAMO 3; TRAMO 4; TRAMO 5; TRAMO 1; TRAMO 2; TRAMO 3; TRAMO 4; A2450 EXCAVACIÓN EN TERRENO NATURAL CON EQUIPO; A2460 EXCAVACIÓN DE UÑA CON EQUIPO; A2470 PERFILADO Y COMPACTACIÓN EN ZONA DE CORTE; A2500 GEOTEXTIL NO TEJIDO 400 G/M2, INC. COLOCACIÓN; A2510 COLOCACION Y ACOMODO DE ROCA EN UÑA DE DIQUE; A2520 COLOCACION Y ACOMODO DE ROCA EN TALUD DE DIQUE; A2530 PREPARACIÓN DE FUNDACIÓN DE CUERPO DE DIQUE; A2480 CONFORMACIÓN DE CUERPO DE DIQUE CON MATERIAL PROPIO; A2490 CONFORMACIÓN DE CORONA DE DIQUE CON MATERIAL PROPIO

Changed:

| ID | Task | Start | Finish | Duration | Total float | Predecessors | Other |
| --- | --- | --- | --- | --- | --- | --- | --- |
| 0 | **HITOS** | 2023-04-25 → 2023-10-15 (+173d) | 2023-11-03 → 2024-04-25 (+174d) |  |  |  |  |
| A1000 | KICK OFF MEETING | 2023-04-25 → 2023-10-15 (+173d) | 2023-04-25 → 2023-10-15 (+173d) |  |  |  | was named ADJUDICACION DEL SERVICIO |
| A1010 | INICIO DEL SERVICIO | 2023-05-09 → 2023-10-31 (+175d) | 2023-05-09 → 2023-10-31 (+175d) |  |  | A1000 FS+11d → A1000 FS+16d |  |
| A1015 | INICIO DE EXCAVACIÓN | 2023-05-15 → 2023-11-05 (+174d) | 2023-05-15 → 2023-11-05 (+174d) |  | 0d → 1d | A1010 FS+5d, A1070 SS+3d → A1060 SS+5d | was named INICIO DE EXCAVACION |
| A1016 | INICIO DE RELLENO DE DIQUE | 2023-06-06 → 2023-11-27 (+174d) | 2023-06-06 → 2023-11-27 (+174d) |  | 0d → 153d | A1015 SS+18d, A4240 → none | constraint none → start on or after 2023-11-27 |
| A1020 | FIN DEL SERVICIO | 2023-11-03 → 2024-04-25 (+174d) | 2023-11-03 → 2024-04-25 (+174d) |  |  | A1200, A4560, CONFORMACIÓN DE CORONA DE DIQUE CON MATERIAL PROPIO, A1760, A1780, A1070, RELLENO NO ESTRUCTURAL CON MATERIAL PROPIO - DIQUE A3-I-03 -TRAMO 4, RELLENO NO ESTRUCTURAL CON MATERIAL PROPIO - DIQUE A3-D-02 - TRAMO 5, A1050, A4520, A4020, A3850, A3790, A3780, A3740, A3730, A3670, A3650, A3640, A3630, A3580, A3560, A3550, A3530, A3470, A3450, A3400, A3260, A3160, A3140, A3130, A3080, A2930, A2880 → A1200, A1760, A1780, A1070, A1050, A4020, A3850, A3790, A3780, A3740, A3730, A3640, A3630, A3580, A3560, A3550, A3530, A3470, A3450, A3400, A3260, A3160, A3140, A3130, A3080, A2930, A2880, A1900, A4920, A5190 |  |
| 1 | **DEFENSAS RIBEREÑAS** | 2023-05-09 → 2023-10-31 (+175d) | 2023-11-04 → 2024-04-27 (+175d) |  |  |  |  |
| 1 | **OBRAS PRELIMINARES** | 2023-05-11 → 2023-11-02 (+175d) | 2023-10-31 → 2024-04-23 (+175d) |  |  |  |  |
| A1030 | CARTEL DE IDENTIFICACIÓN OBRA 4.80 x 3.60 m. | 2023-05-11 → 2023-11-02 (+175d) | 2023-05-13 → 2023-11-03 (+174d) |  | 1.75d → 3d | A1060 SS+2.5d → A1060 SS+2d |  |
| A1040 | INSTALACIONES PROVISIONALES PARA LA OBRA | 2023-05-16 → 2023-11-05 (+173d) | 2023-10-31 → 2024-04-21 (+173d) | 140d → 169d | 0d → 2d | A1100 SS+1.25d, A1030 → A1015, A1030 |  |
| A1050 | MANTENIMIENTO DE TRÁNSITO Y SEGURIDAD VIAL | 2023-05-31 → 2023-11-22 (+175d) | 2023-10-31 → 2024-04-23 (+175d) | 127d → 154d | 2.25d → 2d |  |  |
| 2 | **TRABAJOS PRELIMINARES** | 2023-05-09 → 2023-10-31 (+175d) | 2023-11-04 → 2024-04-27 (+175d) |  |  |  |  |
| A1060 | MOVILIZACION DE EQUIPOS | 2023-05-09 → 2023-10-31 (+175d) | 2023-06-08 → 2023-11-30 (+175d) | 26d → 31d | 0d → 1d |  |  |
| A1070 | TOPOGRAFÍA Y GEOREFERENCIACIÓN | 2023-05-11 → 2023-11-02 (+175d) | 2023-10-31 → 2024-04-23 (+175d) | 144d → 174d | 0d → 2d |  |  |
| A1080 | DESMOVILIZACION DE EQUIPOS | 2023-10-13 → 2024-04-05 (+175d) | 2023-11-04 → 2024-04-27 (+175d) | 18d → 23d |  | A1020 FF+1d → A1020 FF+2d |  |
| 3 | **MEJORAMIENTO DE VÍAS EXISTENTES** | 2023-05-15 → 2023-11-05 (+174d) | 2023-07-13 → 2024-01-04 (+175d) |  |  |  |  |
| 1 | **MOVIMIENTO DE TIERRAS** | 2023-05-15 → 2023-11-05 (+174d) | 2023-05-31 → 2023-11-21 (+174d) |  |  |  |  |
| A1090 | ROCE Y LIMPIEZA DE MALEZA | 2023-05-15 → 2023-11-05 (+174d) | 2023-05-31 → 2023-11-21 (+174d) | 14d → 17d | 0d → 2d | A1015 → A1015 SS, A1040 SS |  |
| A1100 | MEJORAMIENTO DE VIAS EXISTENTES | 2023-05-15 → 2023-11-05 (+174d) | 2023-05-31 → 2023-11-21 (+174d) | 14d → 17d | 0d → 2d |  |  |
| 2 | **REPOSICIÓN DE ESTRUCTURAS** | 2023-06-03 → 2023-11-25 (+175d) | 2023-07-07 → 2023-12-29 (+175d) |  |  |  |  |
| A1150 | DEMOLICIÓN DE ESTRUCTURAS EXISTENTES | 2023-06-03 → 2023-11-25 (+175d) | 2023-06-06 → 2023-11-26 (+173d) |  | 93.25d → 112d | A1070 SS+20d → A1070 SS+23d |  |
| A1160 | REPOSICIÓN DE PASE DE AGUA TUBO HDPE Ø=18" | 2023-06-06 → 2023-11-28 (+175d) | 2023-06-08 → 2023-11-29 (+174d) |  | 93.25d → 112d | A1150 → A1150 SS+3d |  |
| A1170 | REPOSICIÓN DE PASE DE AGUA TUBO HDPE Ø=36" | 2023-06-06 → 2023-11-28 (+175d) | 2023-06-08 → 2023-11-29 (+174d) |  | 93.25d → 112d |  |  |
| A1180 | SUMINISTRO Y MONTAJE DE PANELES DE C°A° 1.6mx1.0mx0.20m EN PASE DE AGUA | 2023-06-08 → 2023-11-30 (+175d) | 2023-07-07 → 2023-12-29 (+175d) | 24d → 30d | 93.25d → 112d | A1170 → A1170 SS+2d |  |
| A1190 | SUMINISTRO Y MONTAJE DE PANELES DE C°A° 2.20mx1.0mx0.20m EN PASE DE AGUA | 2023-06-08 → 2023-11-30 (+175d) | 2023-07-07 → 2023-12-29 (+175d) | 24d → 30d | 93.25d → 112d |  |  |
| 4 | **CABEZAL DE ENTRADA Y SALIDA** | 2023-07-07 → 2023-12-30 (+176d) | 2023-07-13 → 2024-01-04 (+175d) |  |  |  |  |
| A1210 | ENCOFRADO Y DESENCOFRADO RECTO | 2023-07-07 → 2023-12-30 (+176d) | 2023-07-11 → 2024-01-01 (+174d) |  | 93.25d → 112d |  |  |
| A1200 | CONCRETOS | 2023-07-11 → 2024-01-02 (+175d) | 2023-07-13 → 2024-01-04 (+175d) | 2d → 3d | 93.25d → 112d |  |  |
| 4 | **DESCOLMATACIÓN DE CAUCE Y OBRAS AUXILIARES** | 2023-05-17 → 2023-11-07 (+174d) | 2023-11-03 → 2024-04-11 (+160d) |  |  |  |  |
| 1 | **DESBROCE Y DESCOLMATACIÓN** | 2023-05-17 → 2023-11-07 (+174d) | 2023-08-11 → 2024-02-11 (+184d) |  |  |  |  |
| A1220 | DESBROCE Y LIMPIEZA EN ZONA NO BOSCOSA | 2023-05-17 → 2023-11-07 (+174d) | 2023-07-31 → 2024-01-21 (+174d) | 61d → 76d |  | A1070 SS+4d, A1015, A1040 SS+1.25d → A1015 FS+1d, A1010 FS+7d |  |
| A1230 | DESCOLMATACIÓN DE CAUCE NATURAL DEL RÍO LACRAMARCA - DIQUE A3-D-01 | 2023-05-17 → 2023-11-07 (+174d) | 2023-05-26 → 2023-11-16 (+174d) | 8d → 10d |  |  |  |
| A1880 | DESCOLMATACIÓN DE CAUCE NATURAL DEL RÍO LACRAMARCA - DIQUE A3-I-01 | 2023-05-17 → 2023-11-07 (+174d) | 2023-06-17 → 2023-12-08 (+174d) | 27d → 32d | 0d → 85d |  |  |
| A1870 | DESCOLMATACIÓN DE CAUCE NATURAL DEL RÍO LACRAMARCA - DIQUE A3-D-02 | 2023-05-26 → 2023-11-17 (+175d) | 2023-07-17 → 2024-01-08 (+175d) | 43d → 53d | 33d → 74d |  |  |
| A1890 | DESCOLMATACIÓN DE CAUCE NATURAL DEL RÍO LACRAMARCA - DIQUE A3-I-02 | 2023-06-17 → 2023-12-09 (+175d) | 2023-07-07 → 2023-12-28 (+174d) | 16d → 20d | 12.75d → 85d |  |  |
| A1900 | DESCOLMATACIÓN DE CAUCE NATURAL DEL RÍO LACRAMARCA - DIQUE A3-I-03 | 2023-07-07 → 2024-01-09 (+186d) | 2023-08-11 → 2024-02-11 (+184d) | 28d → 34d | 14.75d → 74d | A1890 → A1890, A1870 |  |
| 2 | **DESVIO DEL CAUCE** | 2023-05-18 → 2023-11-07 (+173d) | 2023-11-03 → 2024-04-11 (+160d) |  |  |  |  |
| 5 | **DIQUES DE TIERRA COMPACTADA CON ENROCADO** | 2023-05-23 → 2023-11-12 (+173d) | 2023-10-30 → 2024-04-25 (+178d) |  |  |  |  |
| 1 | **DIQUE DE TIERRA COMPACTADA A3-D-01** | 2023-05-23 → 2023-11-12 (+173d) | 2023-06-23 → 2024-03-30 (+281d) |  |  |  |  |
| A4210 | EXCAVACIÓN EN TERRENO NATURAL CON EQUIPO | 2023-05-23 → 2023-11-12 (+173d) | 2023-06-01 → 2023-11-15 (+167d) | 8d → 4d | 0d → 3d | CONFORMACIÓN DE DESVIO EN CAUCE DE RÍO - DIQUE A3-I-01 → A1230 SS+5d, A5200 SS |  |
| A4220 | EXCAVACIÓN DE UÑA CON EQUIPO | 2023-05-24 → 2023-11-12 (+172d) | 2023-06-01 → 2023-11-13 (+165d) | 7d → 2d | 76.5d → 4d | A4210 SS+1.25d → A4210 SS |  |
| A4230 | PERFILADO Y COMPACTACIÓN EN ZONA DE CORTE | 2023-05-24 → 2023-11-13 (+173d) | 2023-06-12 → 2023-11-20 (+161d) | 16d → 8d | 0d → 3d | A4210 SS+1.25d → A4210 SS+1d |  |
| A4240 | PREPARACIÓN DE FUNDACIÓN DE CUERPO DE DIQUE | 2023-05-24 → 2023-11-13 (+173d) | 2023-06-06 → 2023-11-13 (+160d) | 11d → 1d | 0d → 3d |  |  |
| A4250 | CONFORMACIÓN DE CUERPO DE DIQUE CON MATERIAL PROPIO | 2023-06-06 → 2023-11-15 (+162d) | 2023-06-10 → 2023-11-16 (+159d) | 4d → 2d | 0d → 3d | A1016 → A4220 SS+2d, A4240 SS+2d |  |
| A4260 | GEOTEXTIL NO TEJIDO 400 G/M2, INC. COLOCACIÓN | 2023-06-08 → 2023-11-17 (+162d) | 2023-06-14 → 2023-11-18 (+157d) | 5d → 2d | 0d → 3d | A4250 SS+1.25d → A4250 SS+2d |  |
| A4270 | COLOCACION Y ACOMODO DE ROCA EN UÑA DE DIQUE | 2023-06-09 → 2023-11-18 (+162d) | 2023-06-15 → 2023-11-19 (+157d) | 5d → 2d | 0d → 3d | A4260 SS+1.25d → A4260 SS+1d |  |
| A4280 | COLOCACION Y ACOMODO DE ROCA EN TALUD DE DIQUE | 2023-06-10 → 2023-11-20 (+163d) | 2023-06-21 → 2023-11-23 (+155d) | 9d → 4d | 0d → 3d | A4270 SS+1.25d → A4270 SS+2d |  |
| A4290 | CONFORMACIÓN DE CORONA DE DIQUE CON MATERIAL PROPIO | 2023-06-17 → 2023-11-25 (+161d) | 2023-06-23 → 2023-11-26 (+156d) | 5d → 2d | 83.75d → 3d | A4280 FF+2d → A4280 FF+3d |  |
| A4300 | EXCAVACIÓN EN TERRENO NATURAL CON EQUIPO | 2023-06-24 → 2024-03-07 (+257d) | 2023-07-04 → 2024-03-16 (+256d) | 7d → 10d | 12.75d → 3d | CONFORMACIÓN DE DESVIO EN CAUCE DE RÍO - DIQUE A3-I-02 → A4830 |  |
| A4310 | EXCAVACIÓN DE UÑA CON EQUIPO | 2023-06-26 → 2024-03-08 (+256d) | 2023-07-07 → 2024-03-18 (+255d) | 9d → 11d | 55.5d → 8d | A4300 SS+1.25d, A4220 → A4300 SS+1d |  |
| A4320 | PERFILADO Y COMPACTACIÓN EN ZONA DE CORTE | 2023-06-26 → 2024-03-08 (+256d) | 2023-07-08 → 2024-03-19 (+255d) | 10d → 12d | 12.75d → 3d | A4300 SS+1.25d → A4300 SS+1d |  |
| A4330 | PREPARACIÓN DE FUNDACIÓN DE CUERPO DE DIQUE | 2023-07-04 → 2024-03-13 (+253d) | 2023-07-08 → 2024-03-20 (+256d) | 4d → 8d | 79.75d → 3d | A4300 → A4320 SS+5d |  |
| A4340 | CONFORMACIÓN DE CUERPO DE DIQUE CON MATERIAL PROPIO | 2023-07-05 → 2024-03-18 (+257d) | 2023-07-10 → 2024-03-21 (+255d) |  | 79.75d → 3d | A4330 SS+1d → A4310 SS+5d, A4330 SS+5d |  |
| A4350 | GEOTEXTIL NO TEJIDO 400 G/M2, INC. COLOCACIÓN | 2023-06-28 → 2024-03-20 (+266d) | 2023-07-11 → 2024-03-23 (+256d) | 10d → 4d | 12.75d → 3d | A4320 SS+1.25d → A4340 SS+2d |  |
| A4360 | COLOCACION Y ACOMODO DE ROCA EN UÑA DE DIQUE | 2023-06-30 → 2024-03-21 (+265d) | 2023-07-15 → 2024-03-23 (+252d) | 13d → 3d | 12.75d → 3d | A4350 SS+1.25d → A4350 SS+1d |  |
| A4370 | COLOCACION Y ACOMODO DE ROCA EN TALUD DE DIQUE | 2023-07-01 → 2024-03-22 (+265d) | 2023-07-15 → 2024-03-27 (+256d) | 12d → 6d | 12.75d → 3d | A4360 SS+1.25d → A4360 SS+1d |  |
| A4380 | CONFORMACIÓN DE CORONA DE DIQUE CON MATERIAL PROPIO | 2023-07-12 → 2024-03-28 (+260d) | 2023-07-18 → 2024-03-30 (+256d) | 5d → 3d | 68.75d → 3d | A4370 FF+2d, A4290 → A4370 FF+3d |  |
| 2 | **DIQUE DE TIERRA COMPACTADA A3-D-02** | 2023-06-24 → 2023-11-27 (+156d) | 2023-10-13 → 2024-04-22 (+192d) |  |  |  |  |
| A4660 | EXCAVACIÓN EN TERRENO NATURAL CON EQUIPO | 2023-07-17 → 2023-11-27 (+133d) | 2023-07-25 → 2023-12-12 (+140d) | 7d → 16d | 12.75d → 3d | CONFORMACIÓN DE DESVIO EN CAUCE DE RÍO - DIQUE A3-I-03 - TRAMO 1 → A4290 |  |
| A4670 | EXCAVACIÓN DE UÑA CON EQUIPO | 2023-07-18 → 2023-11-28 (+133d) | 2023-07-31 → 2023-12-12 (+134d) | 9d → 15d | 46.5d → 9d | A4660 SS+1.25d, A4310 → A4660 SS+1d |  |
| A4680 | PERFILADO Y COMPACTACIÓN EN ZONA DE CORTE | 2023-07-18 → 2023-11-28 (+133d) | 2023-08-01 → 2023-12-20 (+141d) | 10d → 23d | 12.75d → 3d | A4660 SS+1.25d → A4660 SS+1d |  |
| A4690 | PREPARACIÓN DE FUNDACIÓN DE CUERPO DE DIQUE | 2023-07-25 → 2023-12-04 (+132d) | 2023-08-01 → 2023-12-21 (+142d) | 4d → 18d | 65.75d → 3d | A4660 → A4680 SS+6d |  |
| A4700 | CONFORMACIÓN DE CUERPO DE DIQUE CON MATERIAL PROPIO | 2023-07-26 → 2023-12-06 (+133d) | 2023-08-02 → 2023-12-22 (+142d) | 4d → 17d | 65.75d → 3d | A4690 SS+1d, A4340 → A4670 SS+2d, A4690 SS+2d |  |
| A4710 | GEOTEXTIL NO TEJIDO 400 G/M2, INC. COLOCACIÓN | 2023-07-20 → 2023-12-08 (+141d) | 2023-08-03 → 2023-12-23 (+142d) | 10d → 16d | 12.75d → 3d | A4680 SS+1.25d → A4700 SS+2d |  |
| A4720 | COLOCACION Y ACOMODO DE ROCA EN UÑA DE DIQUE | 2023-07-21 → 2023-12-09 (+141d) | 2023-08-08 → 2023-12-31 (+145d) | 13d → 23d | 12.75d → 3d | A4710 SS+1.25d → A4710 SS+1d |  |
| A4730 | COLOCACION Y ACOMODO DE ROCA EN TALUD DE DIQUE | 2023-07-22 → 2023-12-11 (+142d) | 2023-08-08 → 2024-01-01 (+146d) | 12d → 22d | 12.75d → 3d | A4720 SS+1.25d → A4720 SS+2d |  |
| A4740 | CONFORMACIÓN DE CORONA DE DIQUE CON MATERIAL PROPIO | 2023-08-04 → 2024-01-01 (+150d) | 2023-08-10 → 2024-01-04 (+147d) | 5d → 4d | 55.75d → 3d | A4730 FF+2d, A4380 → A4730 FF+3d |  |
| A4750 | EXCAVACIÓN EN TERRENO NATURAL CON EQUIPO | 2023-08-09 → 2024-01-05 (+149d) | 2023-08-17 → 2024-01-29 (+165d) | 7d → 25d | 12.75d → 3d | CONFORMACIÓN DE DESVIO EN CAUCE DE RÍO - DIQUE A3-I-03 - TRAMO 2 → A4740 |  |
| A4760 | EXCAVACIÓN DE UÑA CON EQUIPO | 2023-08-10 → 2024-01-08 (+151d) | 2023-08-21 → 2024-02-03 (+166d) | 9d → 27d | 37.5d → 25d | A4750 SS+1.25d, A4670 → A4750 SS+3d |  |
| A4770 | PERFILADO Y COMPACTACIÓN EN ZONA DE CORTE | 2023-08-10 → 2024-01-09 (+152d) | 2023-08-22 → 2024-02-07 (+169d) | 10d → 30d | 12.75d → 3d | A4750 SS+1.25d → A4750 SS+4d |  |

| ID | Task | Start | Finish | Duration | Total float | Predecessors |
| --- | --- | --- | --- | --- | --- | --- |
| A4780 | PREPARACIÓN DE FUNDACIÓN DE CUERPO DE DIQUE | 2023-08-17 → 2024-01-30 (+166d) | 2023-08-22 → 2024-02-08 (+170d) | 4d → 10d | 51.75d → 3d | A4750 → A4770 SS+21d |
| A4790 | CONFORMACIÓN DE CUERPO DE DIQUE CON MATERIAL PROPIO | 2023-08-18 → 2024-02-01 (+167d) | 2023-08-23 → 2024-02-10 (+171d) | 4d → 10d | 51.75d → 3d | A4780 SS+1d, A4700 → A4760 SS+2d, A4780 SS+2d |
| A4800 | GEOTEXTIL NO TEJIDO 400 G/M2, INC. COLOCACIÓN | 2023-08-12 → 2024-02-02 (+174d) | 2023-08-24 → 2024-02-14 (+174d) | 10d → 13d | 12.75d → 3d | A4770 SS+1.25d → A4790 SS+1d |
| A4810 | COLOCACION Y ACOMODO DE ROCA EN UÑA DE DIQUE | 2023-08-14 → 2024-02-03 (+173d) | 2023-08-29 → 2024-03-04 (+188d) | 13d → 31d | 12.75d → 3d | A4800 SS+1.25d → A4800 SS+1d |
| A4820 | COLOCACION Y ACOMODO DE ROCA EN TALUD DE DIQUE | 2023-08-15 → 2024-02-05 (+174d) | 2023-08-29 → 2024-03-03 (+187d) | 12d → 28d | 12.75d → 3d | A4810 SS+1.25d → A4810 SS+2d |
| A4830 | CONFORMACIÓN DE CORONA DE DIQUE CON MATERIAL PROPIO | 2023-08-25 → 2024-03-03 (+191d) | 2023-09-01 → 2024-03-06 (+187d) | 5d → 4d | 42.75d → 3d | A4820 FF+2d, A4740 → A4820 FF+3d |
| A4840 | EXCAVACIÓN EN TERRENO NATURAL CON EQUIPO | 2023-08-31 → 2024-03-31 (+213d) | 2023-09-08 → 2024-04-03 (+208d) | 7d → 4d | 12.75d → 3d | CONFORMACIÓN DE DESVIO EN CAUCE DE RÍO - DIQUE A3-I-03 - TRAMO 3 → A4380 |
| A4850 | EXCAVACIÓN DE UÑA CON EQUIPO | 2023-09-01 → 2024-04-03 (+215d) | 2023-09-12 → 2024-04-06 (+207d) | 9d → 4d | 28.5d → 6d | A4840 SS+1.25d, A4760 → A4840 SS+3d |
| A4860 | PERFILADO Y COMPACTACIÓN EN ZONA DE CORTE | 2023-09-01 → 2024-04-03 (+215d) | 2023-09-13 → 2024-04-08 (+208d) | 10d → 6d | 12.75d → 3d | A4840 SS+1.25d → A4840 SS+3d |
| A4870 | PREPARACIÓN DE FUNDACIÓN DE CUERPO DE DIQUE | 2023-09-08 → 2024-04-06 (+211d) | 2023-09-13 → 2024-04-10 (+210d) | 4d → 5d | 37.75d → 3d | A4840 → A4860 SS+3d |
| A4880 | CONFORMACIÓN DE CUERPO DE DIQUE CON MATERIAL PROPIO | 2023-09-09 → 2024-04-07 (+211d) | 2023-09-14 → 2024-04-11 (+210d) | 4d → 5d | 37.75d → 3d | A4870 SS+1d, A4790 → A4850 SS+1d, A4870 SS+1d |
| A4890 | GEOTEXTIL NO TEJIDO 400 G/M2, INC. COLOCACIÓN | 2023-09-04 → 2024-04-10 (+219d) | 2023-09-15 → 2024-04-14 (+212d) | 10d → 5d | 12.75d → 3d | A4860 SS+1.25d → A4880 SS+3d |
| A4900 | COLOCACION Y ACOMODO DE ROCA EN UÑA DE DIQUE | 2023-09-05 → 2024-04-12 (+220d) | 2023-09-20 → 2024-04-17 (+210d) | 13d → 6d | 12.75d → 3d | A4890 SS+1.25d → A4890 SS+2d |
| A4910 | COLOCACION Y ACOMODO DE ROCA EN TALUD DE DIQUE | 2023-09-06 → 2024-04-14 (+221d) | 2023-09-20 → 2024-04-19 (+212d) | 12d → 6d | 12.75d → 3d | A4900 SS+1.25d → A4900 SS+2d |
| A4920 | CONFORMACIÓN DE CORONA DE DIQUE CON MATERIAL PROPIO | 2023-09-16 → 2024-04-19 (+216d) | 2023-09-22 → 2024-04-22 (+213d) | 5d → 4d | 29.75d → 3d | A4910 FF+2d, A4830 → A4910 FF+3d |
| 3 | **DIQUE DE TIERRA COMPACTADA A3-I-01** | 2023-06-22 → 2023-11-13 (+144d) | 2023-07-13 → 2024-03-09 (+240d) |  |  |  |
| A1440 | EXCAVACIÓN EN TERRENO NATURAL CON EQUIPO | 2023-06-22 → 2023-11-13 (+144d) | 2023-07-04 → 2023-11-18 (+137d) | 9d → 6d |  | CONFORMACIÓN DE DESVIO EN CAUCE DE RÍO - DIQUE A3-D-01 → A1230 SS+6d |
| A1450 | EXCAVACIÓN DE UÑA CON EQUIPO | 2023-06-23 → 2023-11-16 (+146d) | 2023-07-04 → 2023-11-19 (+138d) | 8d → 4d | 49.5d → 0d | A1440 SS+1.25d → A1440 SS+3d |
| A1460 | PERFILADO Y COMPACTACIÓN EN ZONA DE CORTE | 2023-06-23 → 2023-11-16 (+146d) | 2023-07-05 → 2023-11-20 (+138d) | 9d → 5d |  | A1440 SS+1.25d → A1440 SS+1d, A1450 SS |
| A1520 | PREPARACIÓN DE FUNDACIÓN DE CUERPO DE DIQUE | 2023-06-23 → 2023-11-19 (+149d) | 2023-07-05 → 2023-11-21 (+139d) | 9d → 3d |  | A1460 SS → A1460 SS+3d |
| A1470 | CONFORMACIÓN DE CUERPO DE DIQUE CON MATERIAL PROPIO | 2023-06-24 → 2023-11-20 (+149d) | 2023-07-03 → 2023-11-24 (+144d) | 6d → 5d |  |  |
| A1490 | GEOTEXTIL NO TEJIDO 400 G/M2, INC. COLOCACIÓN | 2023-06-27 → 2023-11-22 (+148d) | 2023-07-04 → 2023-11-24 (+143d) | 5d → 3d |  | A1470 SS+1.25d → A1470 SS+2d |
| A1500 | COLOCACION Y ACOMODO DE ROCA EN UÑA DE DIQUE | 2023-06-28 → 2023-11-24 (+149d) | 2023-07-05 → 2023-11-26 (+144d) | 5d → 3d |  | A1490 SS+1.25d → A1490 SS+2d |
| A1510 | COLOCACION Y ACOMODO DE ROCA EN TALUD DE DIQUE | 2023-06-30 → 2023-11-26 (+149d) | 2023-07-11 → 2023-11-30 (+142d) | 9d → 5d |  | A1500 SS+1.25d → A1500 SS+2d |
| A1480 | CONFORMACIÓN DE CORONA DE DIQUE CON MATERIAL PROPIO | 2023-07-08 → 2023-11-30 (+145d) | 2023-07-13 → 2023-12-02 (+142d) | 4d → 3d | 26.25d → 0d |  |
| A4480 | EXCAVACIÓN EN TERRENO NATURAL CON EQUIPO | 2023-09-21 → 2024-02-26 (+158d) | 2023-09-29 → 2024-03-01 (+154d) | 7d → 5d | 12.75d → 0d | CONFORMACIÓN DE DESVIO EN CAUCE DE RÍO - DIQUE A3-I-03 - TRAMO 4 → A5100 |
| A4490 | EXCAVACIÓN DE UÑA CON EQUIPO | 2023-09-22 → 2024-02-27 (+158d) | 2023-10-03 → 2024-02-29 (+149d) | 9d → 3d | 19.5d → 0d | A4480 SS+1.25d, A4850 → A4480 SS+1d |
| A4500 | PERFILADO Y COMPACTACIÓN EN ZONA DE CORTE | 2023-09-22 → 2024-02-27 (+158d) | 2023-10-04 → 2024-03-01 (+149d) | 10d → 4d | 12.75d → 0d | A4480 SS+1.25d → A4480 SS+1d, A4490 SS |
| A4510 | PREPARACIÓN DE FUNDACIÓN DE CUERPO DE DIQUE | 2023-09-29 → 2024-02-27 (+151d) | 2023-10-04 → 2024-03-01 (+149d) |  | 23.75d → 0d | A4480 → A4500 SS |
| A4520 | CONFORMACIÓN DE CUERPO DE DIQUE CON MATERIAL PROPIO | 2023-09-30 → 2024-02-28 (+151d) | 2023-10-05 → 2024-03-02 (+149d) |  | 23.75d → 0d | A4510 SS+1d, A4880 → A4510 SS+1d |
| A4530 | GEOTEXTIL NO TEJIDO 400 G/M2, INC. COLOCACIÓN | 2023-09-25 → 2024-03-01 (+158d) | 2023-10-06 → 2024-03-03 (+149d) | 10d → 3d | 12.75d → 0d | A4500 SS+1.25d → A4520 SS+2d |
| A4540 | COLOCACION Y ACOMODO DE ROCA EN UÑA DE DIQUE | 2023-09-26 → 2024-03-03 (+159d) | 2023-10-11 → 2024-03-05 (+146d) | 13d → 3d | 12.75d → 0d | A4530 SS+1.25d → A4530 SS+2d |
| A4550 | COLOCACION Y ACOMODO DE ROCA EN TALUD DE DIQUE | 2023-09-27 → 2024-03-04 (+159d) | 2023-10-11 → 2024-03-08 (+149d) | 12d → 5d | 12.75d → 0d | A4540 SS+1.25d → A4540 SS+1d |
| A4560 | CONFORMACIÓN DE CORONA DE DIQUE CON MATERIAL PROPIO | 2023-10-07 → 2024-03-07 (+152d) | 2023-10-13 → 2024-03-09 (+148d) | 5d → 3d | 16.75d → 0d | A4550 FF+2d, A4920 → A4550 FF+1d |
| 4 | **DIQUE DE TIERRA COMPACTADA A3-I-02** | 2023-07-12 → 2024-03-10 (+242d) | 2023-08-05 → 2024-04-05 (+244d) |  |  |  |
| A4390 | EXCAVACIÓN EN TERRENO NATURAL CON EQUIPO | 2023-07-12 → 2024-03-10 (+242d) | 2023-07-26 → 2024-03-23 (+241d) | 12d → 14d |  | CONFORMACIÓN DE DESVIO EN CAUCE DE RÍO - DIQUE A3-D-02 - TRAMO 1 → A4560 |
| A4400 | EXCAVACIÓN DE UÑA CON EQUIPO | 2023-07-13 → 2024-03-11 (+242d) | 2023-07-26 → 2024-03-23 (+241d) | 11d → 13d | 41.5d → 1d | A4390 SS+1.25d, A1450 → A4390 SS+1d |
| A4410 | PERFILADO Y COMPACTACIÓN EN ZONA DE CORTE | 2023-07-15 → 2024-03-15 (+244d) | 2023-07-26 → 2024-03-24 (+242d) | 9d → 10d |  | A4390 SS+3d → A4390 SS+5d |
| A4470 | PREPARACIÓN DE FUNDACIÓN DE CUERPO DE DIQUE | 2023-07-21 → 2024-03-21 (+244d) | 2023-07-24 → 2024-03-25 (+245d) | 2d → 5d | 60.75d → 3d | A4390 SS+8d → A4410 FF+1d |
| A4420 | CONFORMACIÓN DE CUERPO DE DIQUE CON MATERIAL PROPIO | 2023-07-22 → 2024-03-24 (+246d) | 2023-07-25 → 2024-03-26 (+245d) | 2d → 3d | 60.75d → 1d | A4470 SS+1d → A4470 SS+1d, A4400 |
| A4440 | GEOTEXTIL NO TEJIDO 400 G/M2, INC. COLOCACIÓN | 2023-07-17 → 2024-03-25 (+252d) | 2023-07-27 → 2024-03-29 (+246d) | 9d → 5d |  | A4410 SS+1.25d → A4420 SS, A4410 |
| A4450 | COLOCACION Y ACOMODO DE ROCA EN UÑA DE DIQUE | 2023-07-19 → 2024-03-25 (+250d) | 2023-07-28 → 2024-03-30 (+246d) | 8d → 6d |  | A4440 SS+1.25d → A4440 SS |
| A4460 | COLOCACION Y ACOMODO DE ROCA EN TALUD DE DIQUE | 2023-07-20 → 2024-03-25 (+249d) | 2023-08-03 → 2024-04-04 (+245d) | 10d → 11d |  | A4450 SS+1.25d → A4450 SS |
| A4430 | CONFORMACIÓN DE CORONA DE DIQUE CON MATERIAL PROPIO | 2023-07-31 → 2024-03-31 (+244d) | 2023-08-05 → 2024-04-05 (+244d) | 5d → 6d | 13.5d → 0d | A4460 FF+2d, A1480 → A4460 FF+1d |
| 5 | **DIQUE DE TIERRA COMPACTADA A3-I-03** | 2023-08-04 → 2023-12-03 (+121d) | 2023-10-30 → 2024-04-25 (+178d) |  |  |  |
| A4930 | EXCAVACIÓN EN TERRENO NATURAL CON EQUIPO | 2023-08-04 → 2023-12-03 (+121d) | 2023-08-11 → 2023-12-27 (+138d) | 6d → 25d |  | CONFORMACIÓN DE DESVIO EN CAUCE DE RÍO - DIQUE A3-D-02 - TRAMO 2 → A1480 |
| A4950 | PERFILADO Y COMPACTACIÓN EN ZONA DE CORTE | 2023-08-05 → 2023-12-04 (+121d) | 2023-08-17 → 2024-01-02 (+138d) | 10d → 30d |  | A4930 SS+1.25d → A4930 SS+1d |
| A4940 | EXCAVACIÓN DE UÑA CON EQUIPO | 2023-08-05 → 2023-12-07 (+124d) | 2023-08-16 → 2023-12-29 (+135d) | 9d → 23d | 34.75d → 13d | A4930 SS+1.25d, A4400 → A4930 SS+4d |
| A4960 | PREPARACIÓN DE FUNDACIÓN DE CUERPO DE DIQUE | 2023-08-11 → 2023-12-20 (+131d) | 2023-08-16 → 2023-12-31 (+137d) | 4d → 12d | 47d → 0d | A4930 → A4950 SS+16d |
| A4970 | CONFORMACIÓN DE CUERPO DE DIQUE CON MATERIAL PROPIO | 2023-08-12 → 2023-12-22 (+132d) | 2023-08-17 → 2024-01-02 (+138d) | 4d → 12d | 47d → 0d | A4960 SS+1d, A4420 → A4940 SS+2d, A4960 SS+2d |
| A4980 | GEOTEXTIL NO TEJIDO 400 G/M2, INC. COLOCACIÓN | 2023-08-07 → 2023-12-24 (+139d) | 2023-08-18 → 2024-01-05 (+140d) | 10d → 13d |  | A4950 SS+1.25d → A4970 SS+2d |
| A4990 | COLOCACION Y ACOMODO DE ROCA EN UÑA DE DIQUE | 2023-08-09 → 2023-12-25 (+138d) | 2023-08-24 → 2024-01-23 (+152d) | 13d → 30d |  | A4980 SS+1.25d → A4980 SS+1d |
| A5000 | COLOCACION Y ACOMODO DE ROCA EN TALUD DE DIQUE | 2023-08-10 → 2023-12-27 (+139d) | 2023-08-24 → 2024-01-23 (+152d) | 12d → 28d |  | A4990 SS+1.25d → A4990 SS+2d |
| A5010 | CONFORMACIÓN DE CORONA DE DIQUE CON MATERIAL PROPIO | 2023-08-21 → 2024-01-12 (+144d) | 2023-08-26 → 2024-01-24 (+151d) | 5d → 13d | 42d → 0d | A5000 FF+2d, A4430 → A5000 FF+1d |
| A5020 | EXCAVACIÓN EN TERRENO NATURAL CON EQUIPO | 2023-08-25 → 2024-01-25 (+153d) | 2023-09-02 → 2024-02-03 (+154d) | 6d → 10d |  | CONFORMACIÓN DE DESVIO EN CAUCE DE RÍO - DIQUE A3-D-02 - TRAMO 3 → A5010 |
| A5030 | EXCAVACIÓN DE UÑA CON EQUIPO | 2023-08-26 → 2024-01-27 (+154d) | 2023-09-07 → 2024-02-04 (+150d) |  | 25.75d → 6d | A5020 SS+1.25d, A4940 → A5020 SS+2d |
| A5040 | PERFILADO Y COMPACTACIÓN EN ZONA DE CORTE | 2023-08-26 → 2024-01-28 (+155d) | 2023-09-08 → 2024-02-07 (+152d) | 10d → 11d |  | A5020 SS+1.25d → A5020 SS+3d |
| A5050 | PREPARACIÓN DE FUNDACIÓN DE CUERPO DE DIQUE | 2023-09-02 → 2024-02-02 (+153d) | 2023-09-07 → 2024-02-09 (+155d) | 4d → 8d | 33d → 0d | A5020 → A5040 SS+5d |
| A5060 | CONFORMACIÓN DE CUERPO DE DIQUE CON MATERIAL PROPIO | 2023-09-04 → 2024-02-07 (+156d) | 2023-09-08 → 2024-02-10 (+155d) |  | 33d → 0d | A5050 SS+1d, A4970 → A5030 SS+5d, A5050 SS+5d |
| A5070 | GEOTEXTIL NO TEJIDO 400 G/M2, INC. COLOCACIÓN | 2023-08-28 → 2024-02-09 (+165d) | 2023-09-09 → 2024-02-13 (+157d) | 10d → 5d |  | A5040 SS+1.25d → A5060 SS+2d |
| A5080 | COLOCACION Y ACOMODO DE ROCA EN UÑA DE DIQUE | 2023-08-31 → 2024-02-10 (+163d) | 2023-09-15 → 2024-02-21 (+159d) | 13d → 12d |  | A5070 SS+1.25d → A5070 SS+1d |
| A5090 | COLOCACION Y ACOMODO DE ROCA EN TALUD DE DIQUE | 2023-09-01 → 2024-02-12 (+164d) | 2023-09-15 → 2024-02-22 (+160d) | 12d → 11d |  | A5080 SS+1.25d → A5080 SS+2d |
| A5100 | CONFORMACIÓN DE CORONA DE DIQUE CON MATERIAL PROPIO | 2023-09-12 → 2024-02-21 (+162d) | 2023-09-18 → 2024-02-25 (+160d) |  | 29d → 0d | A5090 FF+2d, A5010 → A5090 FF+3d |
| A5110 | EXCAVACIÓN EN TERRENO NATURAL CON EQUIPO | 2023-09-16 → 2024-04-06 (+203d) | 2023-09-23 → 2024-04-11 (+201d) |  |  | CONFORMACIÓN DE DESVIO EN CAUCE DE RÍO - DIQUE A3-D-02 - TRAMO 4 → A4430 |
| A5120 | EXCAVACIÓN DE UÑA CON EQUIPO | 2023-09-18 → 2024-04-07 (+202d) | 2023-09-28 → 2024-04-11 (+196d) | 9d → 5d | 16.75d → 4d | A5110 SS+1.25d, A5030 → A5110 SS+1d |
| A5130 | PERFILADO Y COMPACTACIÓN EN ZONA DE CORTE | 2023-09-18 → 2024-04-07 (+202d) | 2023-09-29 → 2024-04-14 (+198d) | 10d → 8d |  | A5110 SS+1.25d → A5110 SS+1d |
| A5140 | PREPARACIÓN DE FUNDACIÓN DE CUERPO DE DIQUE | 2023-09-23 → 2024-04-11 (+201d) | 2023-09-28 → 2024-04-16 (+201d) | 4d → 6d | 19d → 0d | A5110 → A5130 SS+4d |
| A5150 | CONFORMACIÓN DE CUERPO DE DIQUE CON MATERIAL PROPIO | 2023-09-25 → 2024-04-14 (+202d) | 2023-09-29 → 2024-04-17 (+201d) |  | 19d → 0d | A5140 SS+1d, A5060 → A5120 SS+3d, A5140 SS+3d |
| A5160 | GEOTEXTIL NO TEJIDO 400 G/M2, INC. COLOCACIÓN | 2023-09-19 → 2024-04-16 (+210d) | 2023-09-30 → 2024-04-19 (+202d) | 10d → 4d |  | A5130 SS+1.25d → A5150 SS+2d |
| A5170 | COLOCACION Y ACOMODO DE ROCA EN UÑA DE DIQUE | 2023-09-21 → 2024-04-17 (+209d) | 2023-10-06 → 2024-04-24 (+201d) | 13d → 8d |  | A5160 SS+1.25d → A5160 SS+1d |

| ID | Task | Start | Finish | Duration | Total float | Predecessors |
| --- | --- | --- | --- | --- | --- | --- |
| A5180 | COLOCACION Y ACOMODO DE ROCA EN TALUD DE DIQUE | 2023-09-22 → 2024-04-19 (+210d) | 2023-10-06 → 2024-04-25 (+202d) | 12d → 7d |  | A5170 SS+1.25d → A5170 SS+2d |
| A5190 | CONFORMACIÓN DE CORONA DE DIQUE CON MATERIAL PROPIO | 2023-10-03 → 2024-04-23 (+203d) | 2023-10-09 → 2024-04-25 (+199d) | 5d → 3d | 16d → 0d | A5180 FF+2d, A5100 → A5180 SS+4d |
| 6 | **RAMPAS** | 2023-10-03 → 2024-03-09 (+158d) | 2023-10-24 → 2024-04-16 (+175d) |  |  |  |
| 1 | **A3-RA-D-01** | 2023-10-03 → 2024-03-09 (+158d) | 2023-10-07 → 2024-03-14 (+159d) |  |  |  |
| A1710 | EXCAVACIÓN EN TERRENO NATURAL CON EQUIPO | 2023-10-03 → 2024-03-09 (+158d) | 2023-10-05 → 2024-03-11 (+158d) | 2d → 3d | 19.5d → 40d | A4490 → A4550 |
| A1720 | CONFORMACIÓN DE CUERPO DE RAMPA CON MATERIAL PROPIO | 2023-10-05 → 2024-03-12 (+159d) | 2023-10-07 → 2024-03-14 (+159d) | 2d → 3d | 19.5d → 40d |  |
| A1730 | CONFORMACIÓN DE CORONACIÓN DE RAMPA | 2023-10-05 → 2024-03-12 (+159d) | 2023-10-07 → 2024-03-14 (+159d) | 2d → 3d | 19.5d → 40d |  |
| 2 | **A3-RA-I-01** | 2023-10-19 → 2024-04-12 (+176d) | 2023-10-24 → 2024-04-16 (+175d) |  |  |  |
| A1740 | EXCAVACIÓN EN TERRENO NATURAL CON EQUIPO | 2023-10-19 → 2024-04-12 (+176d) | 2023-10-21 → 2024-04-14 (+176d) | 2d → 3d | 7.75d → 9d | EXCAVACIÓN DE UÑA CON EQUIPO → A5120 |
| A1750 | CONFORMACIÓN DE CUERPO DE RAMPA CON MATERIAL PROPIO | 2023-10-21 → 2024-04-15 (+177d) | 2023-10-24 → 2024-04-16 (+175d) |  | 7.75d → 9d |  |
| A1760 | CONFORMACIÓN DE CORONACIÓN DE RAMPA | 2023-10-21 → 2024-04-15 (+177d) | 2023-10-24 → 2024-04-16 (+175d) |  | 7.75d → 9d |  |
| 2 | **OBRAS DE ARTE** | 2023-05-15 → 2023-11-06 (+175d) | 2023-10-31 → 2024-03-18 (+139d) |  |  |  |
| 1 | **CAPTACIÓN A3-CP-23-95** | 2023-05-27 → 2023-11-21 (+178d) | 2023-09-24 → 2024-03-18 (+176d) |  |  |  |
| 1 | **MOVIMIENTO DE TIERRAS** | 2023-05-27 → 2023-11-21 (+178d) | 2023-07-17 → 2024-01-07 (+174d) |  |  |  |
| A2770 | EXCAVACIÓN ESTRUCTURAL PARA OBRAS DE ARTE | 2023-05-27 → 2023-11-21 (+178d) | 2023-06-02 → 2023-11-26 (+177d) | 5d → 6d | 33.25d → 38d |  |
| A2780 | RELLENO ESTRUCTURAL PARA OBRAS DE ARTE, CON MATERIAL PROPIO | 2023-07-12 → 2024-01-03 (+175d) | 2023-07-17 → 2024-01-07 (+174d) | 4d → 5d | 76.75d → 90d |  |
| 2 | **OBRAS DE CONCRETO** | 2023-06-02 → 2023-11-27 (+178d) | 2023-06-27 → 2023-12-21 (+177d) |  |  |  |
| A2790 | CONCRETO f'c=100 kg/cm2 | 2023-06-02 → 2023-11-27 (+178d) | 2023-06-05 → 2023-11-29 (+177d) | 2d → 3d | 44.25d → 50d |  |
| A2810 | CONCRETO CICLÓPEO f'c=280 kg/cm2 + 30% P.G. | 2023-06-05 → 2023-11-30 (+178d) | 2023-06-07 → 2023-12-02 (+178d) | 2d → 3d | 44.25d → 50d |  |
| A2830 | ACERO DE REFUERZO fy=4200 kg/cm2 | 2023-06-07 → 2023-12-03 (+179d) | 2023-06-20 → 2023-12-15 (+178d) | 11d → 13d | 44.25d → 50d |  |
| A2820 | ENCOFRADO Y DESENCOFRADO RECTO | 2023-06-12 → 2023-12-07 (+178d) | 2023-06-21 → 2023-12-16 (+178d) | 8d → 10d | 45.75d → 53d |  |
| A2800 | CONCRETO f'c=280 kg/cm2 | 2023-06-15 → 2023-12-10 (+178d) | 2023-06-27 → 2023-12-21 (+177d) | 10d → 12d | 46.75d → 55d |  |
| 3 | **ESTRUCTURAS METALICAS** | 2023-07-12 → 2024-01-03 (+175d) | 2023-07-24 → 2024-01-17 (+177d) |  |  |  |
| A2840 | COMPUERTA METALICA PLANA DESLIZANTE DE 1.0x1.0m | 2023-07-12 → 2024-01-03 (+175d) | 2023-07-14 → 2024-01-05 (+175d) | 2d → 3d | 83.75d → 99d |  |
| A2850 | REJILLA DE 1.00x1.00m CON VARILLA DE 1/2" CADA 6,25cm | 2023-07-14 → 2024-01-06 (+176d) | 2023-07-17 → 2024-01-08 (+175d) | 2d → 3d | 83.75d → 99d |  |
| A2860 | BARANDA DE FIERRO GALVANIZADO 1 1/2" | 2023-07-17 → 2024-01-09 (+176d) | 2023-07-19 → 2024-01-11 (+176d) | 2d → 3d | 83.75d → 99d |  |
| A2870 | ESCALERA TIPO GATO | 2023-07-19 → 2024-01-12 (+177d) | 2023-07-21 → 2024-01-14 (+177d) | 2d → 3d | 83.75d → 99d |  |
| A2880 | TAPA METALICA CIRCULAR DN600 MM | 2023-07-21 → 2024-01-15 (+178d) | 2023-07-24 → 2024-01-17 (+177d) | 2d → 3d | 83.75d → 99d |  |
| 4 | **TUBERIAS** | 2023-06-02 → 2023-11-27 (+178d) | 2023-07-31 → 2024-01-23 (+176d) |  |  |  |
| A2890 | EXCAVACIÓN ESTRUCTURAL PARA OBRAS DE ARTE (Buzones) | 2023-06-02 → 2023-11-27 (+178d) | 2023-06-05 → 2023-11-29 (+177d) | 2d → 3d | 33.25d → 38d |  |
| A2900 | EXCAVACIÓN DE ZANJA | 2023-06-05 → 2023-11-30 (+178d) | 2023-06-30 → 2023-12-24 (+177d) | 21d → 25d | 33.25d → 38d |  |
| A2920 | CAMA DE ARENA | 2023-06-08 → 2023-12-03 (+178d) | 2023-07-04 → 2023-12-27 (+176d) | 21d → 25d | 79.75d → 93d |  |
| A2940 | CONCRETO f'c=100 kg/cm2 (Buzones) | 2023-06-08 → 2023-12-03 (+178d) | 2023-06-10 → 2023-12-05 (+178d) | 2d → 3d | 52.25d → 60d |  |
| A2990 | SUMINISTRO E INSTALACIÓN DE TUBERÍA GRP DN600 mm SN2500 | 2023-06-09 → 2023-12-04 (+178d) | 2023-07-05 → 2023-12-28 (+176d) | 21d → 25d | 79.75d → 93d |  |
| A2980 | ACERO DE REFUERZO fy=4200 kg/cm2 (Buzones) | 2023-06-20 → 2023-12-16 (+179d) | 2023-06-23 → 2023-12-19 (+179d) | 2.5d → 4d | 44.25d → 50d |  |
| A2960 | ENCOFRADO Y DESENCOFRADO RECTO | 2023-06-23 → 2023-12-20 (+180d) | 2023-06-28 → 2023-12-24 (+179d) | 4d → 5d | 44.25d → 50d |  |
| A2970 | ENCOFRADO Y DESENCOFRADO CURVO | 2023-06-23 → 2023-12-20 (+180d) | 2023-06-28 → 2023-12-24 (+179d) | 4d → 5d | 44.25d → 50d |  |
| A2950 | CONCRETO f'c=280 kg/cm2 (Buzones) | 2023-06-28 → 2023-12-25 (+180d) | 2023-07-01 → 2023-12-27 (+179d) | 2d → 3d | 46.25d → 52d |  |
| A2930 | RELLENO COMÚN PARA ZANJAS | 2023-07-05 → 2023-12-29 (+177d) | 2023-07-31 → 2024-01-23 (+176d) | 20d → 26d | 79.75d → 93d |  |
| A2910 | RELLENO ESTRUCTURAL PARA OBRAS DE ARTE CON MATERIAL PROPIO (Buzones) | 2023-07-17 → 2024-01-09 (+176d) | 2023-07-19 → 2024-01-11 (+176d) | 2d → 3d | 76.75d → 89d |  |
| 5 | **CANAL** | 2023-06-30 → 2023-12-25 (+178d) | 2023-09-06 → 2024-02-29 (+176d) |  |  |  |
| A3000 | EXCAVACIÓN ESTRUCTURAL PARA OBRAS DE ARTE | 2023-06-30 → 2023-12-25 (+178d) | 2023-07-06 → 2023-12-30 (+177d) | 5d → 6d | 33.25d → 38d |  |
| A3020 | COLOCACIÓN DE CONCRETO f'c=100 kg/cm2 | 2023-07-06 → 2023-12-31 (+178d) | 2023-07-09 → 2024-01-03 (+178d) | 2.5d → 4d | 33.25d → 38d |  |
| A3050 | ACERO DE REFUERZO fy=4200 kg/cm2 | 2023-07-10 → 2024-01-04 (+178d) | 2023-08-06 → 2024-01-31 (+178d) | 22d → 28d | 33.25d → 38d |  |
| A3040 | ENCOFRADO Y DESENCOFRADO RECTO | 2023-07-12 → 2024-01-06 (+178d) | 2023-09-03 → 2024-02-26 (+176d) | 43d → 52d | 33.25d → 38d |  |
| A3030 | COLOCACIÓN DE CONCRETO f'c=280 kg/cm2 | 2023-07-14 → 2024-01-08 (+178d) | 2023-09-06 → 2024-02-29 (+176d) | 43d → 53d | 33.25d → 38d |  |
| A3060 | JUNTA WATER STOP SIN BULBO 150 mm | 2023-07-14 → 2024-01-08 (+178d) | 2023-09-06 → 2024-02-29 (+176d) | 43d → 53d | 47.25d → 53d |  |
| A3010 | RELLENO ESTRUCTURAL PARA CANALES, CON MATERIAL PROPIO | 2023-07-19 → 2024-01-12 (+177d) | 2023-08-01 → 2024-01-24 (+176d) | 9d → 13d | 76.75d → 89d |  |
| 6 | **OBRAS DE DESCARGA** | 2023-07-06 → 2023-12-31 (+178d) | 2023-09-24 → 2024-03-18 (+176d) |  |  |  |
| A3070 | EXCAVACIÓN ESTRUCTURAL PARA OBRAS DE ARTE | 2023-07-06 → 2023-12-31 (+178d) | 2023-07-08 → 2024-01-02 (+178d) | 2d → 3d | 74.75d → 87d |  |
| A3090 | CONCRETO f'c=100 kg/cm2 | 2023-07-10 → 2024-01-04 (+178d) | 2023-07-12 → 2024-01-06 (+178d) | 2d → 3d | 74.25d → 86d |  |
| A3120 | ACERO DE REFUERZO fy=4200 kg/cm2 | 2023-08-07 → 2024-02-01 (+178d) | 2023-08-09 → 2024-02-03 (+178d) | 2d → 3d | 54.25d → 61d |  |
| A3110 | ENCOFRADO Y DESENCOFRADO RECTO | 2023-09-04 → 2024-02-27 (+176d) | 2023-09-06 → 2024-02-29 (+176d) | 2d → 3d | 33.25d → 38d |  |
| A3100 | CONCRETO f'c=280 kg/cm2 | 2023-09-06 → 2024-03-01 (+177d) | 2023-09-08 → 2024-03-03 (+177d) | 2d → 3d | 33.25d → 38d |  |
| A3130 | JUNTA WATER STOP SIN BULBO 150 mm | 2023-09-08 → 2024-03-04 (+178d) | 2023-09-10 → 2024-03-06 (+178d) | 2d → 3d | 45.25d → 50d |  |
| A3080 | RELLENO ESTRUCTURAL PARA OBRAS DE ARTE CON MATERIAL PROPIO | 2023-09-22 → 2024-03-16 (+176d) | 2023-09-24 → 2024-03-18 (+176d) | 2d → 3d | 33.25d → 38d |  |
| A3140 | COMPUERTA METALICA PLANA DESLIZANTE | 2023-09-22 → 2024-03-16 (+176d) | 2023-09-24 → 2024-03-18 (+176d) | 2d → 3d | 33.25d → 38d |  |
| 2 | **CAPTACIÓN A3-CP-21-05** | 2023-05-18 → 2023-11-09 (+175d) | 2023-08-15 → 2024-02-06 (+175d) |  |  |  |
| 1 | **MOVIMIENTO DE TIERRAS** | 2023-05-18 → 2023-11-09 (+175d) | 2023-07-08 → 2023-12-28 (+173d) |  |  |  |
| A3150 | EXCAVACIÓN ESTRUCTURAL PARA OBRAS DE ARTE | 2023-05-18 → 2023-11-09 (+175d) | 2023-05-20 → 2023-11-12 (+176d) | 2.5d → 4d | 33.25d → 38d | A1070 SS+6d → A1070 SS+7d |
| A3160 | RELLENO ESTRUCTURAL PARA OBRAS DE ARTE, CON MATERIAL PROPIO | 2023-07-04 → 2023-12-24 (+173d) | 2023-07-08 → 2023-12-28 (+173d) | 4d → 5d | 96.75d → 119d |  |
| 2 | **OBRAS DE CONCRETO** | 2023-05-20 → 2023-11-13 (+177d) | 2023-06-19 → 2023-12-11 (+175d) |  |  |  |
| A3170 | CONCRETO f'c=100 kg/cm2 | 2023-05-20 → 2023-11-13 (+177d) | 2023-05-23 → 2023-11-15 (+176d) | 2d → 3d | 66.75d → 79d |  |
| A3190 | CONCRETO CICLÓPEO f'c=280 kg/cm2 + 30% P.G. | 2023-05-23 → 2023-11-16 (+177d) | 2023-05-25 → 2023-11-18 (+177d) | 2d → 3d | 66.75d → 79d |  |
| A3210 | ACERO DE REFUERZO fy=4200 kg/cm2 | 2023-05-25 → 2023-11-19 (+178d) | 2023-06-14 → 2023-12-09 (+178d) | 17d → 21d | 66.75d → 79d |  |
| A3200 | ENCOFRADO Y DESENCOFRADO RECTO | 2023-06-01 → 2023-11-25 (+177d) | 2023-06-15 → 2023-12-09 (+177d) | 12d → 15d | 68.75d → 82d |  |
| A3180 | CONCRETO f'c=280 kg/cm2 | 2023-06-08 → 2023-12-01 (+176d) | 2023-06-19 → 2023-12-11 (+175d) | 9d → 11d | 89.75d → 109d |  |
| 3 | **ESTRUCTURAS METALICAS** | 2023-07-04 → 2023-12-24 (+173d) | 2023-07-15 → 2024-01-07 (+176d) |  |  |  |
| A3220 | COMPUERTA METALICA PLANA DESLIZANTE DE 1.0x1.0m | 2023-07-04 → 2023-12-24 (+173d) | 2023-07-06 → 2023-12-26 (+173d) | 2d → 3d | 90.75d → 109d |  |
| A3230 | REJILLA DE 1.00x1.00m CON VARILLA DE 1/2 CADA 6,25cm | 2023-07-06 → 2023-12-27 (+174d) | 2023-07-08 → 2023-12-29 (+174d) | 2d → 3d | 90.75d → 109d |  |

| ID | Task | Start | Finish | Duration | Total float | Predecessors |
| --- | --- | --- | --- | --- | --- | --- |
| A3240 | BARANDA DE FIERRO GALVANIZADO 1 1/2" | 2023-07-08 → 2023-12-30 (+175d) | 2023-07-11 → 2024-01-01 (+174d) | 2d → 3d | 90.75d → 109d |  |
| A3250 | ESCALERA TIPO GATO | 2023-07-11 → 2024-01-02 (+175d) | 2023-07-13 → 2024-01-04 (+175d) | 2d → 3d | 90.75d → 109d |  |
| A3260 | TAPA METALICA CIRCULAR DN600 MM | 2023-07-13 → 2024-01-05 (+176d) | 2023-07-15 → 2024-01-07 (+176d) | 2d → 3d | 90.75d → 109d |  |
| 4 | **TUBERIA** | 2023-05-20 → 2023-11-13 (+177d) | 2023-07-08 → 2024-01-02 (+178d) |  |  |  |
| A3270 | EXCAVACIÓN ESTRUCTURAL PARA OBRAS DE ARTE (Buzones) | 2023-05-20 → 2023-11-13 (+177d) | 2023-05-23 → 2023-11-15 (+176d) | 2d → 3d | 33.25d → 38d |  |
| A3280 | EXCAVACIÓN DE ZANJA | 2023-05-23 → 2023-11-16 (+177d) | 2023-05-25 → 2023-11-18 (+177d) | 2d → 3d | 122.75d → 143d |  |
| A3330 | CONCRETO f'c=100 kg/cm2 (Buzones) | 2023-05-23 → 2023-11-16 (+177d) | 2023-05-25 → 2023-11-18 (+177d) | 2d → 3d | 83.75d → 100d |  |
| A3300 | CAMA DE ARENA | 2023-05-25 → 2023-11-19 (+178d) | 2023-05-27 → 2023-11-21 (+178d) | 2d → 3d | 122.75d → 143d |  |
| A3380 | SUMINISTRO E INSTALACIÓN DE TUBERÍA GRP DN600 mm SN2500 | 2023-05-27 → 2023-11-22 (+179d) | 2023-05-30 → 2023-11-24 (+178d) | 2d → 3d | 122.75d → 143d |  |
| A3310 | RELLENO SELECCIONADO PARA ZANJAS CON MATERIAL PROPIO | 2023-05-30 → 2023-11-25 (+179d) | 2023-06-01 → 2023-11-27 (+179d) | 2d → 3d | 122.75d → 143d |  |
| A3320 | RELLENO COMÚN PARA ZANJAS | 2023-05-30 → 2023-11-25 (+179d) | 2023-06-01 → 2023-11-27 (+179d) | 2d → 3d | 122.75d → 143d |  |
| A3370 | ACERO DE REFUERZO fy=4200 kg/cm2 | 2023-06-14 → 2023-12-10 (+179d) | 2023-06-16 → 2023-12-12 (+179d) | 2d → 3d | 66.75d → 79d |  |
| A3350 | ENCOFRADO Y DESENCOFRADO RECTO | 2023-06-16 → 2023-12-13 (+180d) | 2023-06-19 → 2023-12-15 (+179d) | 2d → 3d | 67.75d → 79d |  |
| A3360 | ENCOFRADO Y DESENCOFRADO CURVO | 2023-06-16 → 2023-12-13 (+180d) | 2023-06-19 → 2023-12-15 (+179d) | 2d → 3d | 67.75d → 79d |  |
| A3340 | CONCRETO f'c=280 kg/cm2 (Buzones) | 2023-06-19 → 2023-12-16 (+180d) | 2023-06-21 → 2023-12-18 (+180d) | 2d → 3d | 89.75d → 105d |  |
| A3290 | RELLENO ESTRUCTURAL PARA OBRAS DE ARTE CON MATERIAL PROPIO | 2023-07-06 → 2023-12-31 (+178d) | 2023-07-08 → 2024-01-02 (+178d) | 2d → 3d | 91.75d → 107d |  |
| 5 | **CANALES** | 2023-05-23 → 2023-11-16 (+177d) | 2023-08-15 → 2024-02-06 (+175d) |  |  |  |
| A3390 | EXCAVACIÓN ESTRUCTURAL PARA OBRAS DE ARTE | 2023-05-23 → 2023-11-16 (+177d) | 2023-05-27 → 2023-11-20 (+177d) | 4d → 5d | 33.25d → 38d | A3270, A3270 FF → A3270 |
| A3410 | COLOCACIÓN DE CONCRETO f'c=100 kg/cm2 | 2023-05-27 → 2023-11-21 (+178d) | 2023-05-30 → 2023-11-23 (+177d) | 2d → 3d | 81.75d → 98d |  |
| A3440 | ACERO DE REFUERZO fy=4200 kg/cm2 | 2023-06-16 → 2023-12-13 (+180d) | 2023-06-28 → 2023-12-24 (+179d) | 10d → 12d | 66.75d → 79d |  |
| A3430 | ENCOFRADO Y DESENCOFRADO | 2023-06-20 → 2023-12-16 (+179d) | 2023-07-19 → 2024-01-13 (+178d) | 24d → 29d | 66.75d → 79d |  |
| A3420 | COLOCACIÓN DE CONCRETO f'c=280 kg/cm2 | 2023-07-19 → 2024-01-14 (+179d) | 2023-07-24 → 2024-01-18 (+178d) | 4d → 5d | 66.75d → 79d |  |
| A3450 | JUNTA WATER STOP SIN BULBO 150 mm | 2023-07-19 → 2024-01-14 (+179d) | 2023-07-21 → 2024-01-16 (+179d) | 2d → 3d | 85.75d → 100d |  |
| A3400 | RELLENO ESTRUCTURAL PARA CANALES, CON MATERIAL PROPIO | 2023-08-09 → 2024-01-31 (+175d) | 2023-08-15 → 2024-02-06 (+175d) | 5d → 7d | 66.75d → 79d |  |
| 3 | **RETORNO A3-OA-RE-D-21-55** | 2023-05-15 → 2023-11-06 (+175d) | 2023-07-07 → 2023-12-29 (+175d) |  |  |  |
| 1 | **MOVIMIENTO DE TIERRAS** | 2023-05-15 → 2023-11-06 (+175d) | 2023-07-05 → 2023-12-25 (+173d) |  |  |  |
| A3460 | EXCAVACIÓN ESTRUCTURAL PARA OBRAS DE ARTE | 2023-05-15 → 2023-11-06 (+175d) | 2023-05-17 → 2023-11-08 (+175d) | 2d → 3d | 97.75d → 118d | A1070 SS+3d → A1070 SS+4d |
| A3470 | RELLENO ESTRUCTURAL PARA OBRAS DE ARTE, CON MATERIAL PROPIO | 2023-07-03 → 2023-12-23 (+173d) | 2023-07-05 → 2023-12-25 (+173d) | 2d → 3d | 100.25d → 122d |  |
| 2 | **OBRAS DE CONCRETO** | 2023-05-17 → 2023-11-09 (+176d) | 2023-06-17 → 2023-12-10 (+176d) |  |  |  |
| A3480 | CONCRETO f'c=100 kg/cm2 | 2023-05-17 → 2023-11-09 (+176d) | 2023-05-19 → 2023-11-11 (+176d) | 2d → 3d | 97.75d → 118d |  |
| A3500 | CONCRETO CICLÓPEO f'c=280 kg/cm2 + 30% P.G. | 2023-05-19 → 2023-11-12 (+177d) | 2023-05-24 → 2023-11-16 (+176d) | 4d → 5d | 97.75d → 118d |  |
| A3520 | ACERO DE REFUERZO fy=4200 kg/cm2 | 2023-05-19 → 2023-11-12 (+177d) | 2023-06-11 → 2023-12-05 (+177d) | 20d → 24d | 97.75d → 118d |  |
| A3510 | ENCOFRADO Y DESENCOFRADO | 2023-05-26 → 2023-11-18 (+176d) | 2023-06-13 → 2023-12-05 (+175d) | 15d → 18d | 97.75d → 118d |  |
| A3490 | CONCRETO f'c=280 kg/cm2 | 2023-06-13 → 2023-12-06 (+176d) | 2023-06-17 → 2023-12-10 (+176d) | 4d → 5d | 97.75d → 118d |  |
| A3530 | JUNTA WATER STOP SIN BULBO 150 mm | 2023-06-13 → 2023-12-06 (+176d) | 2023-06-17 → 2023-12-10 (+176d) | 4d → 5d | 114.25d → 137d |  |
| 3 | **ESTRUCTURAS METALICAS** | 2023-07-03 → 2023-12-23 (+173d) | 2023-07-07 → 2023-12-29 (+175d) |  |  |  |
| A3540 | COMPUERTA METALICA PLANA DESLIZANTE DE 1.0x1.6 m | 2023-07-03 → 2023-12-23 (+173d) | 2023-07-05 → 2023-12-26 (+174d) | 2.5d → 4d | 97.75d → 118d |  |
| A3550 | BARANDA DE FIERRO GALVANIZADO 1 1/2" | 2023-07-05 → 2023-12-27 (+175d) | 2023-07-07 → 2023-12-29 (+175d) | 2d → 3d | 97.75d → 118d |  |
| 4 | **REPOSICIÓN DE CANALES** | 2023-06-01 → 2023-11-22 (+174d) | 2023-10-31 → 2024-03-14 (+135d) |  |  |  |
| 1 | **REPOSICIÓN DE CANAL 1** | 2023-07-26 → 2023-12-13 (+140d) | 2023-10-31 → 2024-03-14 (+135d) |  |  |  |
| 1 | **MOVIMIENTO DE TIERRAS** | 2023-07-26 → 2023-12-13 (+140d) | 2023-10-31 → 2024-01-24 (+85d) |  |  |  |
| A3560 | DEMOLICIÓN DE ESTRUCTURAS EXISTENTES | 2023-07-26 → 2023-12-13 (+140d) | 2023-08-12 → 2023-12-29 (+139d) | 13d → 17d | 68.75d → 42d | A4390 → A4660 |
| A3580 | RELLENO ESTRUCTURAL PARA OBRAS DE ARTE CON MATERIAL PROPIO | 2023-09-23 → 2023-12-17 (+85d) | 2023-10-31 → 2024-01-24 (+85d) | 32d → 39d | 2d → 92d | A3620 SS+16d → A4660 FS+4d |
| A3570 | EXCAVACIÓN EN TERRENO NATURAL CON EQUIPO | 2023-08-03 → 2023-12-19 (+138d) | 2023-09-07 → 2024-01-23 (+138d) | 29d → 36d | 2d → 42d | A4460 → A3560 SS+6d |
| 2 | **OBRAS DE CONCRETO** | 2023-08-10 → 2023-12-26 (+138d) | 2023-10-28 → 2024-03-14 (+138d) |  |  |  |
| A3610 | CONCRETO f'c=100 kg/cm2 | 2023-08-10 → 2023-12-26 (+138d) | 2023-09-14 → 2024-01-30 (+138d) | 29d → 36d | 2d → 42d | A3570 SS+6d → A3570 SS+7d |
| A3600 | ACERO DE REFUERZO fy=4200 kg/cm2 | 2023-08-14 → 2023-12-29 (+137d) | 2023-10-21 → 2024-03-07 (+138d) | 58d → 70d | 2d → 42d |  |
| A3590 | ENCOFRADO Y DESENCOFRADO RECTO | 2023-08-21 → 2024-01-05 (+137d) | 2023-10-21 → 2024-03-07 (+138d) | 52d → 63d | 2d → 42d | A3600 SS+6d → A3600 SS+7d |
| A3620 | CONCRETO f'c=280 kg/cm2 | 2023-09-05 → 2024-01-19 (+136d) | 2023-10-26 → 2024-03-12 (+138d) | 44d → 54d | 2d → 42d | A3590 SS+12d → A3590 SS+14d |
| A3630 | JUNTA WATER STOP 6" | 2023-09-05 → 2024-01-19 (+136d) | 2023-10-26 → 2024-03-12 (+138d) | 44d → 54d | 6d → 44d |  |
| A3640 | MAMPOSTERIA DE PIEDRA, e=20cm, ACABADO CARA VISTA | 2023-10-26 → 2024-03-13 (+139d) | 2023-10-28 → 2024-03-14 (+138d) |  | 4d → 42d |  |
| 2 | **REPOSICIÓN DE CANAL 3** | 2023-06-01 → 2023-11-22 (+174d) | 2023-07-27 → 2024-01-16 (+173d) |  |  |  |
| 1 | **MOVIMIENTO DE TIERRAS** | 2023-06-01 → 2023-11-22 (+174d) | 2023-07-27 → 2023-12-20 (+146d) |  |  |  |
| A3650 | DEMOLICIÓN DE ESTRUCTURAS EXISTENTES | 2023-06-01 → 2023-11-22 (+174d) | 2023-06-10 → 2023-12-01 (+174d) | 8d → 10d | 119.75d → 100d | A4210 → A4210 FS+6d |
| A3660 | EXCAVACIÓN EN TERRENO NATURAL CON EQUIPO | 2023-06-21 → 2023-12-14 (+176d) | 2023-06-24 → 2023-12-17 (+176d) | 2.5d → 4d | 80.75d → 100d | A4280 → A3650 FS+12d |
| A3670 | RELLENO ESTRUCTURAL PARA OBRAS DE ARTE CON MATERIAL PROPIO | 2023-07-25 → 2023-12-18 (+146d) | 2023-07-27 → 2023-12-20 (+146d) | 2d → 3d | 80.75d → 100d | A3720 FS+6d → A3660 |
| 2 | **OBRAS DE CONCRETO** | 2023-06-24 → 2023-12-21 (+180d) | 2023-07-20 → 2024-01-16 (+180d) |  |  |  |
| A3710 | CONCRETO f'c=100 kg/cm2 | 2023-06-24 → 2023-12-21 (+180d) | 2023-06-27 → 2023-12-24 (+180d) | 2.5d → 4d | 80.75d → 100d | A3660 → A3670 |
| A3700 | MALLA ELECTROSOLDADA DE DN6mm EN CUADRICULA 15x15 cm | 2023-06-27 → 2023-12-25 (+181d) | 2023-07-12 → 2024-01-08 (+180d) | 12d → 15d | 80.75d → 100d |  |
| A3680 | ENCOFRADO Y DESENCOFRADO PARA REVESTIMIENTO DE CANALES (CERCHAS) | 2023-07-01 → 2023-12-28 (+180d) | 2023-07-13 → 2024-01-08 (+179d) | 10d → 12d | 80.75d → 100d |  |
| A3690 | ENCOFRADO Y DESENCOFRADO RECTO | 2023-07-01 → 2023-12-28 (+180d) | 2023-07-13 → 2024-01-08 (+179d) | 10d → 12d | 80.75d → 100d |  |
| A3730 | SELLO DE JUNTA CONSTRUCCIÓN CON MATERIAL ELASTOMÉRICO | 2023-07-01 → 2023-12-28 (+180d) | 2023-07-11 → 2024-01-06 (+179d) | 8d → 10d | 94.75d → 110d |  |
| A3720 | CONCRETO f'c=280 kg/cm2 | 2023-07-13 → 2024-01-09 (+180d) | 2023-07-18 → 2024-01-13 (+179d) | 4d → 5d | 80.75d → 100d |  |
| A3740 | MAMPOSTERIA DE PIEDRA, e=20cm, ACABADO CARA VISTA | 2023-07-18 → 2024-01-14 (+180d) | 2023-07-20 → 2024-01-16 (+180d) | 2d → 3d | 86.75d → 100d |  |
| 5 | **REPOSICIÓN SIFON INOPERATIVO** | 2023-06-17 → 2023-12-08 (+174d) | 2023-07-26 → 2024-01-16 (+174d) |  |  |  |
| A3750 | DEMOLICIÓN DE ESTRUCTURAS EXISTENTES | 2023-06-17 → 2023-12-08 (+174d) | 2023-06-20 → 2023-12-10 (+173d) | 2d → 3d | 81.75d → 100d | A1230, A1880 → A1230, A1880 FF+2d |
| A3760 | EXCAVACIÓN ESTRUCTURAL PARA OBRAS DE ARTE | 2023-06-20 → 2023-12-11 (+174d) | 2023-06-30 → 2023-12-20 (+173d) | 8d → 10d | 81.75d → 100d |  |
| A3770 | COLOCACIÓN CAMA DE ARENA | 2023-06-30 → 2023-12-21 (+174d) | 2023-07-03 → 2023-12-23 (+173d) | 2d → 3d | 89.75d → 109d |  |
| A3810 | CONCRETO f'c=100 kg/cm2 | 2023-06-30 → 2023-12-21 (+174d) | 2023-07-03 → 2023-12-23 (+173d) | 2d → 3d | 81.75d → 100d |  |
| A3800 | TUBERÍAS DE 14" HDPE SDR21 DN 355mm | 2023-07-03 → 2023-12-24 (+174d) | 2023-07-08 → 2023-12-29 (+174d) | 5d → 6d | 89.75d → 109d |  |

| ID | Task | Start | Finish | Duration | Total float | Predecessors |
| --- | --- | --- | --- | --- | --- | --- |
| A3840 | ACERO DE REFUERZO fy=4200 kg/cm2 | 2023-07-03 → 2023-12-24 (+174d) | 2023-07-05 → 2023-12-26 (+174d) | 2d → 3d | 81.75d → 100d |  |
| A3850 | CODOS HDPE DE 14" DN 355mm | 2023-07-03 → 2023-12-24 (+174d) | 2023-07-08 → 2023-12-29 (+174d) | 5d → 6d | 96.75d → 118d |  |
| A3830 | ENCOFRADO Y DESENCOFRADO RECTO | 2023-07-05 → 2023-12-27 (+175d) | 2023-07-07 → 2023-12-29 (+175d) | 2d → 3d | 81.75d → 100d |  |
| A3790 | RELLENO COMÚN | 2023-07-08 → 2023-12-30 (+175d) | 2023-07-17 → 2024-01-07 (+174d) | 7d → 9d | 89.75d → 109d |  |
| A3820 | CONCRETO f'c=280 kg/cm2 | 2023-07-07 → 2023-12-30 (+176d) | 2023-07-10 → 2024-01-01 (+175d) | 2d → 3d | 81.75d → 100d |  |
| A3780 | RELLENO ESTRUCTURAL PARA OBRAS DE ARTE CON MATERIAL PROPIO | 2023-07-24 → 2024-01-14 (+174d) | 2023-07-26 → 2024-01-16 (+174d) | 2d → 3d | 81.75d → 100d |  |
| 3 | **ARQUITECTURA Y PAISAJISMO** | 2023-08-05 → 2024-01-05 (+153d) | 2023-10-17 → 2024-03-22 (+157d) |  |  |  |
| 1 | **OBRAS PRELIMINARES** | 2023-08-05 → 2024-01-05 (+153d) | 2023-10-17 → 2024-03-22 (+157d) |  |  |  |
| A3860 | MOVILIZACIÓN DE EQUIPOS Y HERRAMIENTAS (ARQUITECTURA Y PAISAJISMO) | 2023-08-05 → 2024-01-05 (+153d) | 2023-08-08 → 2024-01-06 (+151d) |  | 13.5d → 34d | A4430 → A4740 |
| A3870 | TRAZO Y REPLANTEO PRELIMINAR | 2023-08-08 → 2024-01-07 (+152d) | 2023-08-10 → 2024-01-08 (+151d) | 2.5d → 2d | 13.5d → 34d |  |
| A4020 | DEMOVILIZACIÓN DE EQUIPOS Y HERRAMIENTAS (ARQUITECTURA Y PAISAJISMO) | 2023-10-14 → 2024-03-21 (+159d) | 2023-10-17 → 2024-03-22 (+157d) |  | 13.5d → 34d | A4010, A3900 → A4010 FS+4d, A3900 |
| 2 | **MOVIMIENTO DE TIERRAS** | 2023-08-10 → 2024-01-09 (+152d) | 2023-08-26 → 2024-01-25 (+152d) |  |  |  |
| A3880 | EXCAVACIÓN MANUAL PARA INSTALACIÓN DE BORDILLOS Y CIMENTACIONES | 2023-08-10 → 2024-01-09 (+152d) | 2023-08-12 → 2024-01-10 (+151d) |  | 13.5d → 34d |  |
| A3900 | ELIMINACION DE MATERIAL EXCEDENTE (DME´S) | 2023-08-10 → 2024-01-09 (+152d) | 2023-08-26 → 2024-01-25 (+152d) | 14d → 17d | 54.5d → 89d |  |
| A3890 | EXCAVACIÓN PARA MEJORAMIENTO DE SUELO CON TIERRA VEGETAL | 2023-08-12 → 2024-01-11 (+152d) | 2023-08-26 → 2024-01-25 (+152d) | 12d → 15d | 13.5d → 34d |  |
| 3 | **PAVIMENTOS, RECUBRIMIENTOS Y BORDILLOS** | 2023-08-26 → 2024-01-26 (+153d) | 2023-09-07 → 2024-02-05 (+151d) |  |  |  |
| A3910 | PISO DE GRAVILLA | 2023-08-26 → 2024-01-26 (+153d) | 2023-08-29 → 2024-01-27 (+151d) |  | 13.5d → 34d |  |
| A3920 | RECUBRIMIENTO DE PIEDRA DEL LUGAR e=0.05cm | 2023-08-29 → 2024-01-28 (+152d) | 2023-09-02 → 2024-01-31 (+151d) | 2.5d → 4d | 13.5d → 34d |  |
| A3930 | BORDILLOS DE PIEDRA DEL LUGAR | 2023-09-02 → 2024-02-01 (+152d) | 2023-09-07 → 2024-02-05 (+151d) | 4d → 5d | 13.5d → 34d |  |
| 4 | **MOBILIARIOS, BARANDAS Y ESCALERAS** | 2023-09-07 → 2024-02-06 (+152d) | 2023-10-12 → 2024-03-14 (+154d) |  |  |  |
| A3940 | ESCALERA DE CONCRETO SOBRE ENROCADO, CIMENTACION Y ANCLAJE | 2023-09-07 → 2024-02-06 (+152d) | 2023-09-16 → 2024-02-15 (+152d) | 8d → 10d | 13.5d → 34d |  |
| A3950 | BARANDA DE MADERA EUCALIPTO CON SOGA, INCLUYE CIMENTACIÓN | 2023-09-16 → 2024-02-16 (+153d) | 2023-09-21 → 2024-02-19 (+151d) |  | 13.5d → 34d |  |
| A3960 | TACHOS DE BASURA, INCLUYE CIMENTACIÓN | 2023-09-21 → 2024-02-20 (+152d) | 2023-09-23 → 2024-02-22 (+152d) | 2d → 3d | 13.5d → 34d |  |
| A3970 | BANCAS DE CONCRETO, INCLUYE CIMENTACIÓN | 2023-09-23 → 2024-02-23 (+153d) | 2023-10-03 → 2024-03-03 (+152d) | 8d → 10d | 13.5d → 34d |  |
| A3980 | POSTES DE ILUMINACIÓN, INCLUYE LUMINARIA Y CIMENTACIÓN | 2023-10-03 → 2024-03-04 (+153d) | 2023-10-07 → 2024-03-08 (+153d) | 4d → 5d | 13.5d → 34d |  |
| A3990 | SEÑALETICA INFORMATIVA | 2023-10-07 → 2024-03-09 (+154d) | 2023-10-10 → 2024-03-11 (+153d) | 2d → 3d | 13.5d → 34d |  |
| A4000 | BOLARDOS DE PIEDRA | 2023-10-10 → 2024-03-12 (+154d) | 2023-10-12 → 2024-03-14 (+154d) | 2.5d → 3d | 13.5d → 34d |  |
| 5 | **INSTALACIÓN DE ALCORQUES** | 2023-10-12 → 2024-03-15 (+155d) | 2023-10-14 → 2024-03-16 (+154d) |  |  |  |
| A4010 | ALCORQUES DE PIEDRA DE CANTO RODADO PARA ARBOLES | 2023-10-12 → 2024-03-15 (+155d) | 2023-10-14 → 2024-03-16 (+154d) |  | 13.5d → 34d |  |
| 4 | **PROGRAMA DE CIERRE DE OBRA** | 2023-05-17 → 2023-11-07 (+174d) | 2023-10-31 → 2024-04-22 (+174d) |  |  |  |
| A1770 | ACONDICIONAMIENTO DE DEPOSITOS DE MATERIALES EXCEDENTES (DME) | 2023-05-17 → 2023-11-07 (+174d) | 2023-10-24 → 2024-04-14 (+173d) | 133d → 160d | 1.75d → 3d |  |
| A1780 | RESTAURACIÓN DE ÁREAS DE INSTALACIONES PROVISIONALES | 2023-10-24 → 2024-04-15 (+174d) | 2023-10-31 → 2024-04-22 (+174d) | 6d → 8d | 1.75d → 3d | CONFORMACIÓN DE CUERPO DE DIQUE CON MATERIAL PROPIO, A1770 → A1770 |

## Version 3 (data date 2024-10-16, saved 2024-10-18, file 4.1.1 PER2305-1 rev01.xer)

Last finish 2024-04-27 → 2025-04-29 (+367d).

Added:

| ID | Task | Duration | Start | Finish | Predecessors | Resources |
| --- | --- | --- | --- | --- | --- | --- |
| A5250 | DESBROCE Y LIMPIEZA INICIAL EN ZONA NO BOSCOSA | 4d | 2024-11-01 | 2024-11-04 | A1060 | EXCAVADORA CAT 336 [16 h]; TRACTOR SOBRE ORUGAS CAT D6D [32 h] |
| A5260 | DESCOLMATACIÓN DE CAUCE NATURAL DEL RÍO LACRAMARCA - DIQUE A3-D-02 - INICIAL | 3d | 2024-11-05 | 2024-11-07 | A5250 | Tractor D8 [19.2 h] |
| 1 | **CONSTRUCCION DIQUE A3-D-01** |  | 2024-11-08 | 2024-12-07 |  |  |
| 1 | **CONSTRUCCION DIQUE A3-D-02 TRAMO 1** |  | 2024-11-26 | 2025-01-10 |  |  |
| 4 | **CONSTRUCCION DIQUE A3-D-02 TRAMO 2** |  | 2025-01-09 | 2025-02-13 |  |  |
| A5480 | CONFORMACIÓN DE CUERPO Y CORONA DE DIQUE CON MATERIAL PROPIO | 12d | 2025-01-19 | 2025-01-30 | A5460 SS+8d | Conformacion de cuerpo y corona de dique con mat. propio [2997 m3]; TRACTOR SOBRE ORUGAS CAT D6D [96 h]; Rodillo Liso Vibratorio Autopropulsado 10-12 tn [96 h] |
| 3 | **CONSTRUCCION DIQUE A3-D-02 TRAMO 3** |  | 2025-02-12 | 2025-03-20 |  |  |
| A5390 | CONFORMACIÓN DE CUERPO Y CORONA DE DIQUE CON MATERIAL PROPIO | 5d | 2025-02-22 | 2025-02-26 | A5370 SS+8d | Conformacion de cuerpo y corona de dique con mat. propio [2997 m3] |
| 2 | **CONSTRUCCION DIQUE A3-D-02 TRAMO 4** |  | 2025-03-19 | 2025-04-24 |  |  |
| A5300 | CONFORMACIÓN DE CUERPO Y CORONA DE DIQUE CON MATERIAL PROPIO | 5d | 2025-03-29 | 2025-04-02 | A5280 SS+8d | Conformacion de cuerpo y corona de dique con mat. propio [2997 m3]; TRACTOR SOBRE ORUGAS CAT D6D [40 h]; Rodillo Liso Vibratorio Autopropulsado 10-12 tn [40 h] |
| 1 | **CONSTRUCCION DIQUE A3-I-01** |  | 2024-11-08 | 2024-12-16 |  |  |
| 2 | **CONSTRUCCION DIQUE A3-I-02** |  | 2024-12-17 | 2025-01-16 |  |  |
| 1 | **CONSTRUCCION DIQUE A3-I-03 TRAMO 1** |  | 2025-01-15 | 2025-02-16 |  |  |
| 3 | **CONSTRUCCION DIQUE A3-I-03 TRAMO 2** |  | 2025-02-16 | 2025-03-19 |  |  |
| A5660 | CONFORMACIÓN DE CUERPO Y CORONA DE DIQUE CON MATERIAL PROPIO | 5d | 2025-02-18 | 2025-02-22 | A5640 SS+1d, A4960 | Conformacion de cuerpo y corona de dique con mat. propio [3253 m3]; TRACTOR SOBRE ORUGAS CAT D6D [40 h]; Rodillo Liso Vibratorio Autopropulsado 10-12 tn [40 h] |
| 2 | **CONSTRUCCION DIQUE A3-I-03 TRAMO 3** |  | 2025-03-20 | 2025-04-20 |  |  |
| A5570 | CONFORMACIÓN DE CUERPO Y CORONA DE DIQUE CON MATERIAL PROPIO | 5d | 2025-03-21 | 2025-03-25 | A5550 SS+1d | Conformacion de cuerpo y corona de dique con mat. propio [3253 m3]; TRACTOR SOBRE ORUGAS CAT D6D [40 h]; Rodillo Liso Vibratorio Autopropulsado 10-12 tn [40 h] |
| A5220 | SECADO DE CONCRETO f'c=280 kg/cm2 | 18d | 2024-12-20 | 2025-01-06 | A2800 | Encofrado Recto [144 m3] |
| A5750 | SECADO DE CONCRETO f'c=280 kg/cm2 | 12d | 2024-12-20 | 2024-12-31 | A2800 | Encofrado Recto [96 m3] |
| A5230 | SECADO DE CONCRETO f'c=280 kg/cm2 | 12d | 2024-12-14 | 2024-12-25 | A3180 | Encofrado Recto [96 m3] |
| A5240 | SECADO DE CONCRETO f'c=280 kg/cm2 (Buzones) | 12d | 2024-12-25 | 2025-01-05 | A3340 | Encofrado Recto [96 m3] |
| A5730 | SECADO DE CONCRETO f'c=280 kg/cm2 | 14d | 2025-03-31 | 2025-04-13 | A3620 | Encofrado Recto [112 m3] |
| A5740 | DESENCOFRADO RECTO | 10d | 2025-04-14 | 2025-04-23 | A5730 | Camion grua 20 ton [64 h] |

Removed: SIN AFECTACIÓN A3-D-01; CON AFECTACIÓN A3-D-01; SIN AFECTACIÓN A3-D-02; CON AFECTACIÓN A3-D-02; A4790 CONFORMACIÓN DE CUERPO DE DIQUE CON MATERIAL PROPIO; A4830 CONFORMACIÓN DE CORONA DE DIQUE CON MATERIAL PROPIO; POR LIBERAR A3-D-02; A4880 CONFORMACIÓN DE CUERPO DE DIQUE CON MATERIAL PROPIO; A4920 CONFORMACIÓN DE CORONA DE DIQUE CON MATERIAL PROPIO; SIN AFECTACIÓN A3-I-01; CON AFECTACIÓN A3-I-01; A4510 PREPARACIÓN DE FUNDACIÓN DE CUERPO DE DIQUE; A4520 CONFORMACIÓN DE CUERPO DE DIQUE CON MATERIAL PROPIO; A4560 CONFORMACIÓN DE CORONA DE DIQUE CON MATERIAL PROPIO; Sector por Liberar - Km 20+980 - km 21+300; SIN AFECTACIÓN A3-I-03; CON AFECTACIÓN A3-I-03; A5050 PREPARACIÓN DE FUNDACIÓN DE CUERPO DE DIQUE; A5060 CONFORMACIÓN DE CUERPO DE DIQUE CON MATERIAL PROPIO; A5100 CONFORMACIÓN DE CORONA DE DIQUE CON MATERIAL PROPIO; POR LIBERAR A3-I-03; A5110 EXCAVACIÓN EN TERRENO NATURAL CON EQUIPO; A5120 EXCAVACIÓN DE UÑA CON EQUIPO; A5130 PERFILADO Y COMPACTACIÓN EN ZONA DE CORTE; A5140 PREPARACIÓN DE FUNDACIÓN DE CUERPO DE DIQUE; A5150 CONFORMACIÓN DE CUERPO DE DIQUE CON MATERIAL PROPIO; A5160 GEOTEXTIL NO TEJIDO 400 G/M2, INC. COLOCACIÓN; A5170 COLOCACION Y ACOMODO DE ROCA EN UÑA DE DIQUE; A5180 COLOCACION Y ACOMODO DE ROCA EN TALUD DE DIQUE; A5190 CONFORMACIÓN DE CORONA DE DIQUE CON MATERIAL PROPIO

Changed:

| ID | Task | Start | Finish | Duration | Total float | Predecessors | Other |
| --- | --- | --- | --- | --- | --- | --- | --- |
| 0 | **HITOS** | 2023-10-15 → 2024-10-16 (+367d) | 2024-04-25 → 2025-04-29 (+369d) |  |  |  |  |
| A1000 | KICK OFF MEETING | 2023-10-15 → 2024-10-16 (+367d) | 2023-10-15 → 2024-10-16 (+367d) |  |  |  |  |
| A1010 | INICIO DE PLAZO CONTRACTUAL - ACCESO AL SITIO | 2023-10-31 → 2024-11-01 (+367d) | 2023-10-31 → 2024-11-01 (+367d) |  | 0d → 1d |  | was named INICIO DEL SERVICIO |
| A1015 | INICIO DE EXCAVACIÓN | 2023-11-05 → 2024-11-06 (+367d) | 2023-11-05 → 2024-11-06 (+367d) |  |  | A1060 SS+5d → A1060 SS+5d, A1010 SS+5d |  |
| A1016 | INICIO DE RELLENO DE DIQUE | 2023-11-27 → 2024-11-28 (+367d) | 2023-11-27 → 2024-11-28 (+367d) |  | 153d → 5d | none → A1015 SS+22d | constraint start on or after 2023-11-27 → none |
| A1020 | FIN DE PLAZO CONTRACTUAL - CULMINACION DE OBRAS | 2024-04-25 → 2025-04-29 (+369d) | 2024-04-25 → 2025-04-29 (+369d) |  |  | A1200, A1760, A1780, A1070, A1050, A4020, A3850, A3790, A3780, A3740, A3730, A3640, A3630, A3580, A3560, A3550, A3530, A3470, A3450, A3400, A3260, A3160, A3140, A3130, A3080, A2930, A2880, A1900, CONFORMACIÓN DE CORONA DE DIQUE CON MATERIAL PROPIO, CONFORMACIÓN DE CORONA DE DIQUE CON MATERIAL PROPIO → A1780, A1070, A1050, A4020, A3850, A3790, A3780, A3740, A3730, A3470, A3450, A3140, A2930, A1900, A5010 FF, A5010 SF, A1890 FF, A1016 SF, A4430 FF, A5210 FF, A4960 FF, A4990 FF, A5610 FF, A5620 FF, A5740 FF, A4740 FF, A1080 FF | was named FIN DEL SERVICIO |
| 1 | **DEFENSAS RIBEREÑAS** | 2023-10-31 → 2024-10-16 (+351d) | 2024-04-27 → 2025-04-29 (+367d) |  |  |  |  |
| 2 | **TRABAJOS PRELIMINARES** | 2023-10-31 → 2024-10-16 (+351d) | 2024-04-27 → 2025-04-29 (+367d) |  |  |  |  |
| A1060 | MOVILIZACION DE EQUIPOS | 2023-10-31 → 2024-10-16 (+351d) | 2023-11-30 → 2024-10-31 (+336d) | 31d → 16d | 1d → 0d | A1010 → A1000 SS |  |
| A1070 | TOPOGRAFÍA Y GEOREFERENCIACIÓN | 2023-11-02 → 2024-11-01 (+365d) | 2024-04-23 → 2025-04-24 (+366d) | 174d → 175d | 2d → 5d | A1060 SS+2d → A1060 SS+2d, A1010 SS |  |
| A1080 | DESMOVILIZACION DE EQUIPOS | 2024-04-05 → 2025-04-25 (+385d) | 2024-04-27 → 2025-04-29 (+367d) | 23d → 5d |  | A1020 FF+2d → A5340, A1730 |  |
| 1 | **OBRAS PRELIMINARES** | 2023-11-02 → 2024-11-01 (+365d) | 2024-04-23 → 2025-04-28 (+370d) |  |  |  |  |
| A1030 | CARTEL DE IDENTIFICACIÓN OBRA 4.80 x 3.60 m. | 2023-11-02 → 2024-11-01 (+365d) | 2023-11-03 → 2024-11-02 (+365d) |  | 3d → 4d | A1060 SS+2d → A1060 SS+2d, A1010 SS | resources none → CAMION GRUA 20 TON [16 h] |
| A1040 | INSTALACIONES PROVISIONALES PARA LA OBRA | 2023-11-05 → 2024-11-06 (+367d) | 2024-04-21 → 2025-04-23 (+367d) |  | 2d → 1d |  | resources none → Grupo electrogeno [1352 h] |
| A1050 | MANTENIMIENTO DE TRÁNSITO Y SEGURIDAD VIAL | 2023-11-22 → 2024-11-26 (+370d) | 2024-04-23 → 2025-04-28 (+370d) |  | 2d → 1d |  | resources none → Motoniveladora 140K [616 h]; Camion Cisterna [1232 h]; Rodillo Liso Vibratorio Autopropulsado 10-12 tn [308 h] |
| 3 | **MEJORAMIENTO DE VÍAS EXISTENTES** | 2023-11-05 → 2024-11-06 (+367d) | 2024-01-04 → 2025-01-06 (+368d) |  |  |  |  |
| 1 | **MOVIMIENTO DE TIERRAS** | 2023-11-05 → 2024-11-06 (+367d) | 2023-11-21 → 2024-11-25 (+370d) |  |  |  |  |
| A1090 | ROCE Y LIMPIEZA DE MALEZA | 2023-11-05 → 2024-11-06 (+367d) | 2023-11-21 → 2024-11-25 (+370d) | 17d → 20d | 2d → 1d |  | resources none → TRACTOR SOBRE ORUGAS CAT D6D [160 h] |
| A1100 | MEJORAMIENTO DE VIAS EXISTENTES | 2023-11-05 → 2024-11-06 (+367d) | 2023-11-21 → 2024-11-25 (+370d) | 17d → 20d | 2d → 1d |  | resources none → EXCAVADORA CAT 336 [80 h]; TRACTOR SOBRE ORUGAS CAT D6D [40 h]; Motoniveladora 140K [160 h]; Camion Cisterna [160 h]; Rodillo Liso Vibratorio Autopropulsado 10-12 tn [160 h] |
| 2 | **REPOSICIÓN DE ESTRUCTURAS** | 2023-11-25 → 2024-11-26 (+367d) | 2023-12-29 → 2024-12-31 (+368d) |  |  |  |  |
| A1150 | DEMOLICIÓN DE ESTRUCTURAS EXISTENTES | 2023-11-25 → 2024-11-26 (+367d) | 2023-11-26 → 2024-11-27 (+367d) |  | 112d → 35d | A1070 SS+23d → A1070 SS, A1100 | resources none → EXCAVADORA CAT 336 [16 h]; MARTILLO HIDRAULICO P/EXCAVADORA [16 h] |
| A1160 | REPOSICIÓN DE PASE DE AGUA TUBO HDPE Ø=18" | 2023-11-28 → 2024-11-28 (+366d) | 2023-11-29 → 2024-11-29 (+366d) |  | 112d → 35d | A1150 SS+3d → A1150 | resources none → CAMION GRUA 20 TON [16 h] |
| A1170 | REPOSICIÓN DE PASE DE AGUA TUBO HDPE Ø=36" | 2023-11-28 → 2024-11-30 (+368d) | 2023-11-29 → 2024-12-01 (+368d) |  | 112d → 35d | A1160 SS → A1160 | resources none → CAMION GRUA 20 TON [16 h] |
| A1180 | SUMINISTRO Y MONTAJE DE PANELES DE C°A° 1.6mx1.0mx0.20m EN PASE DE AGUA | 2023-11-30 → 2024-12-02 (+368d) | 2023-12-29 → 2024-12-31 (+368d) |  | 112d → 35d | A1170 SS+2d → A1170 | resources none → CAMION GRUA 20 TON [240 h] |
| A1190 | SUMINISTRO Y MONTAJE DE PANELES DE C°A° 2.20mx1.0mx0.20m EN PASE DE AGUA | 2023-11-30 → 2024-12-02 (+368d) | 2023-12-29 → 2024-12-31 (+368d) |  | 112d → 35d |  | resources none → CAMION GRUA 20 TON [240 h] |
| 4 | **CABEZAL DE ENTRADA Y SALIDA** | 2023-12-30 → 2025-01-01 (+368d) | 2024-01-04 → 2025-01-06 (+368d) |  |  |  |  |
| A1210 | ENCOFRADO Y DESENCOFRADO RECTO | 2023-12-30 → 2025-01-01 (+368d) | 2024-01-01 → 2025-01-03 (+368d) |  | 112d → 35d |  | resources none → CAMION GRUA 20 TON [24 h]; Encofrado Recto [22 m3] |
| A1200 | CONCRETOS | 2024-01-02 → 2025-01-04 (+368d) | 2024-01-04 → 2025-01-06 (+368d) |  | 112d → 35d |  | resources none → mezcladora de concreto [24 h] |
| 4 | **DESCOLMATACIÓN DE CAUCE Y OBRAS AUXILIARES** | 2023-11-07 → 2024-11-01 (+360d) | 2024-04-11 → 2025-04-13 (+367d) |  |  |  |  |
| 1 | **DESBROCE Y DESCOLMATACIÓN** | 2023-11-07 → 2024-11-01 (+360d) | 2024-02-11 → 2025-02-05 (+360d) |  |  |  |  |
| A1220 | DESBROCE Y LIMPIEZA EN ZONA NO BOSCOSA | 2023-11-07 → 2024-11-06 (+365d) | 2024-01-21 → 2025-01-20 (+365d) |  | 0d → 2d | A1015 FS+1d, A1010 FS+7d → A1015, A1010, A5250 | resources none → EXCAVADORA CAT 336 [608 h] |
| A1230 | DESCOLMATACIÓN DE CAUCE NATURAL DEL RÍO LACRAMARCA - DIQUE A3-D-01 | 2023-11-07 → 2024-11-08 (+367d) | 2023-11-16 → 2024-11-17 (+367d) |  | 0d → 2d | A1220 SS → A1220 SS+2d | resources none → Tractor D8 [64 h] |
| A1880 | DESCOLMATACIÓN DE CAUCE NATURAL DEL RÍO LACRAMARCA - DIQUE A3-I-01 | 2023-11-07 → 2024-11-12 (+371d) | 2023-12-08 → 2024-12-13 (+371d) |  | 85d → 48d | A1230 SS → A1220 SS+6d | resources none → Tractor D8 [204.8 h] |
| A1870 | DESCOLMATACIÓN DE CAUCE NATURAL DEL RÍO LACRAMARCA - DIQUE A3-D-02 | 2023-11-17 → 2024-11-18 (+367d) | 2024-01-08 → 2025-01-09 (+367d) |  | 74d → 12d |  | resources none → Tractor D8 [339.2 h] |
| A1890 | DESCOLMATACIÓN DE CAUCE NATURAL DEL RÍO LACRAMARCA - DIQUE A3-I-02 | 2023-12-09 → 2024-12-14 (+371d) | 2023-12-28 → 2025-01-02 (+371d) |  | 85d → 83d |  | resources none → Tractor D8 [128 h] |
| A1900 | DESCOLMATACIÓN DE CAUCE NATURAL DEL RÍO LACRAMARCA - DIQUE A3-I-03 | 2024-01-09 → 2025-01-03 (+360d) | 2024-02-11 → 2025-02-05 (+360d) |  | 74d → 83d | A1890, A1870 → A1890 | resources none → Tractor D8 [217.6 h] |
| 2 | **DESVIO DEL CAUCE** | 2023-11-07 → 2024-11-08 (+367d) | 2024-04-11 → 2025-04-13 (+367d) |  |  |  |  |
| A5200 | CONFORMACIÓN DE DESVIO EN CAUCE DE RÍO | 2023-11-07 → 2024-11-08 (+367d) | 2024-01-13 → 2025-01-14 (+367d) |  | 8d → 6d | A1015 FS+2d → A1015 FS+2d, A5260 | resources none → TRACTOR SOBRE ORUGAS CAT D6D [544 h]; EXCAVADORA CAT 336 [17 h] |
| A5210 | RELLENO NO ESTRUCTURAL CON MATERIAL PROPIO | 2024-01-14 → 2025-01-15 (+367d) | 2024-04-11 → 2025-04-13 (+367d) |  |  |  | resources none → TRACTOR SOBRE ORUGAS CAT D6D [712 h] |
| 5 | **DIQUES DE TIERRA COMPACTADA CON ENROCADO** | 2023-11-12 → 2024-11-08 (+362d) | 2024-04-25 → 2025-04-24 (+364d) |  |  |  |  |
| 1 | **DIQUE DE TIERRA COMPACTADA A3-D-01** | 2023-11-12 → 2024-11-08 (+362d) | 2024-03-30 → 2024-12-07 (+252d) |  |  |  |  |
| A4210 | EXCAVACIÓN EN TERRENO NATURAL CON EQUIPO | 2023-11-12 → 2024-11-08 (+362d) | 2023-11-15 → 2024-11-16 (+367d) | 4d → 9d | 3d → 0d | A1230 SS+5d, A5200 SS → A5250, A5260 | resources none → EXCAVADORA CAT 336 [72 h]; TRACTOR SOBRE ORUGAS CAT D6D [72 h]; Excavacion en terreno natural con equipo [6167 m3] |
| A4230 | PERFILADO Y COMPACTACIÓN EN ZONA DE CORTE | 2023-11-13 → 2024-11-09 (+362d) | 2023-11-20 → 2024-11-18 (+364d) | 8d → 10d |  |  | resources none → EXCAVADORA CAT 336 [40 h] |
| A4240 | CONFORMACIÓN DE CUERPO DE DIQUE CON MATERIAL PROPIO | 2023-11-15 → 2024-11-09 (+360d) | 2023-11-16 → 2024-11-13 (+363d) | 2d → 5d |  | A4220 SS+2d, A5530 SS+2d → A4230 SS | resources none → TRACTOR SOBRE ORUGAS CAT D6D [40 h]; Conformacion de cuerpo y corona de dique con mat. propio [1319 m3]; Rodillo Liso Vibratorio Autopropulsado 10-12 tn [40 h] |
| A4220 | EXCAVACIÓN DE UÑA CON EQUIPO | 2023-11-12 → 2024-11-12 (+366d) | 2023-11-13 → 2024-11-17 (+370d) | 2d → 6d | 4d → 2d | A4210 SS → A1230 SS+4d, A5200 SS | resources none → Motobomba 8" [38.4 h]; excavacion de uña con equipo [2325 m3]; EXCAVADORA CAT 336 [48 h] |
| A4250 | CONFORMACIÓN DE CORONA DE DIQUE CON MATERIAL PROPIO | 2024-03-28 → 2024-11-17 (+234d) | 2024-03-30 → 2024-11-21 (+236d) | 3d → 5d | 3d → 0d | A5520 FF+3d → A4210, A4240 | resources none → TRACTOR SOBRE ORUGAS CAT D6D [40 h]; Rodillo Liso Vibratorio Autopropulsado 10-12 tn [40 h] |
| A4260 | GEOTEXTIL NO TEJIDO 400 G/M2, INC. COLOCACIÓN | 2023-11-17 → 2024-11-19 (+368d) | 2023-11-18 → 2024-11-24 (+372d) | 2d → 6d | 3d → 0d | A4240 SS+2d → A4250 SS+2d | resources none → Camion grua 20 ton [38.4 h]; Geotextil no tejido 400 gr/m2 [5381] |
| A4270 | COLOCACION Y ACOMODO DE ROCA EN UÑA DE DIQUE | 2023-11-18 → 2024-11-20 (+368d) | 2023-11-19 → 2024-11-25 (+372d) | 2d → 6d | 3d → 0d | A4260 SS+1d → A4260 SS+1d, A4220 | resources none → TRACTOR SOBRE ORUGAS CAT D6D [12 h]; Colocacion y acomodo de roca en uña [2325 m3]; EXCAVADORA CAT 336 [96 h] |
| A4280 | COLOCACION Y ACOMODO DE ROCA EN TALUD DE DIQUE | 2023-11-20 → 2024-11-22 (+368d) | 2023-11-23 → 2024-12-05 (+378d) | 4d → 14d | 3d → 0d | A4270 SS+2d → A4270 SS+2d, A4210 | resources none → TRACTOR SOBRE ORUGAS CAT D6D [28 h]; Colocacion y acomodo de roca en talud [3493 m3]; EXCAVADORA CAT 336 [448 h] |
| A4290 | CONFORMACIÓN DE CORONA DE DIQUE CON MATERIAL PROPIO | 2023-11-25 → 2024-12-06 (+377d) | 2023-11-26 → 2024-12-07 (+377d) |  | 3d → 0d | A4280 FF+3d → A4280 | resources none → Motoniveladora 140K [16 h]; Rodillo Liso Vibratorio Autopropulsado 10-12 tn [16 h] |
| 2 | **DIQUE DE TIERRA COMPACTADA A3-D-02** | 2023-11-27 → 2024-11-26 (+365d) | 2024-04-22 → 2025-04-24 (+367d) |  |  |  |  |
| A4660 | EXCAVACIÓN EN TERRENO NATURAL CON EQUIPO | 2023-11-27 → 2024-11-26 (+365d) | 2023-12-12 → 2024-12-06 (+360d) | 16d → 11d | 3d → 4d | A4290 → A5200 SS, A1870 SS, A1060, A4270 | resources none → Excavacion en terreno natural con equipo [13321 m3]; EXCAVADORA CAT 336 [176 h]; TRACTOR SOBRE ORUGAS CAT D6D [44 h] |
| A4680 | PERFILADO Y COMPACTACIÓN EN ZONA DE CORTE | 2023-11-28 → 2024-11-27 (+365d) | 2023-12-20 → 2024-12-10 (+356d) | 23d → 14d | 3d → 13d |  |  |
| A4690 | CONFORMACIÓN DE CUERPO DE DIQUE CON MATERIAL PROPIO | 2024-03-18 → 2024-12-03 (+260d) | 2024-03-21 → 2024-12-09 (+263d) | 4d → 7d | 3d → 13d | A5460 SS+5d, A5440 SS+5d → A4680 SS+6d | resources none → Conformacion de cuerpo y corona de dique con mat. propio [2997 m3]; TRACTOR SOBRE ORUGAS CAT D6D [56 h]; Motoniveladora 140K [56 h]; Rodillo Liso Vibratorio Autopropulsado 10-12 tn [56 h] |
| A4700 | CONFORMACIÓN DE CORONADE DIQUE CON MATERIAL PROPIO | 2023-12-06 → 2024-12-07 (+367d) | 2023-12-22 → 2024-12-11 (+355d) | 17d → 5d | 3d → 8d | A4670 SS+2d, A5350 SS+2d → A4660 | was named CONFORMACIÓN DE CUERPO DE DIQUE CON MATERIAL PROPIO; resources none → TRACTOR SOBRE ORUGAS CAT D6D [40 h]; Rodillo Liso Vibratorio Autopropulsado 10-12 tn [40 h] |
| A4670 | EXCAVACIÓN DE UÑA CON EQUIPO | 2023-11-28 → 2024-12-08 (+376d) | 2023-12-12 → 2024-12-17 (+371d) | 15d → 10d | 9d → 0d | A4660 SS+1d → A1060, A1015 SS, A5260, A4280, A4290 | resources none → excavacion de uña con equipo [4179 m3]; EXCAVADORA CAT 336 [80 h]; Motobomba 8" [64 h] |
| A4710 | GEOTEXTIL NO TEJIDO 400 G/M2, INC. COLOCACIÓN | 2023-12-08 → 2024-12-09 (+367d) | 2023-12-23 → 2024-12-14 (+357d) | 16d → 6d | 3d → 8d |  | resources none → Geotextil no tejido 400 gr/m2 [6091]; CAMION GRUA 20 TON [48 h] |
| A4720 | COLOCACION Y ACOMODO DE ROCA EN UÑA DE DIQUE | 2023-12-09 → 2024-12-18 (+375d) | 2023-12-31 → 2025-01-08 (+374d) | 23d → 22d | 3d → 0d | A4710 SS+1d → A4670 | resources none → Colocacion y acomodo de roca en uña [4179 m3]; EXCAVADORA CAT 336 [176 h]; TRACTOR SOBRE ORUGAS CAT D6D [88 h] |
| A4730 | COLOCACION Y ACOMODO DE ROCA EN TALUD DE DIQUE | 2023-12-11 → 2024-12-23 (+378d) | 2024-01-01 → 2025-01-10 (+375d) | 22d → 19d | 3d → 0d | A4720 SS+2d → A4720 SS+5d, A4690, A4710 | resources none → Colocacion y acomodo de roca en talud [5005 m3]; EXCAVADORA CAT 336 [608 h]; TRACTOR SOBRE ORUGAS CAT D6D [76 h] |
| A4740 | CONFORMACIÓN DE CORONA DE DIQUE CON MATERIAL PROPIO | 2024-01-01 → 2025-01-09 (+374d) | 2024-01-04 → 2025-01-10 (+372d) | 4d → 2d | 3d → 109d | A4730 FF+3d → A4730 FF |  |
| A5450 | EXCAVACIÓN EN TERRENO NATURAL CON EQUIPO | 2024-03-07 → 2025-01-09 (+308d) | 2024-03-16 → 2025-01-19 (+309d) | 10d → 11d | 3d → 4d | CONFORMACIÓN DE CORONA DE DIQUE CON MATERIAL PROPIO → A4720 | resources none → Excavacion en terreno natural con equipo [13321 m3]; EXCAVADORA CAT 336 [176 h]; TRACTOR SOBRE ORUGAS CAT D6D [44 h] |
| A5470 | PERFILADO Y COMPACTACIÓN EN ZONA DE CORTE | 2024-03-08 → 2025-01-09 (+307d) | 2024-03-19 → 2025-01-22 (+309d) | 12d → 14d | 3d → 4d | A5450 SS+1d → A5450 SS | resources none → EXCAVADORA CAT 336 [112 h] |
| A5460 | EXCAVACIÓN DE UÑA CON EQUIPO | 2024-03-08 → 2025-01-11 (+309d) | 2024-03-18 → 2025-01-20 (+308d) | 11d → 10d | 8d → 0d | A5450 SS+1d → A4730 | resources none → excavacion de uña con equipo [4179 m3]; EXCAVADORA CAT 336 [80 h]; Motobomba 8" [64 h] |
| A5530 | PREPARACIÓN DE FUNDACIÓN DE CUERPO DE DIQUE | 2023-11-13 → 2025-01-15 (+429d) | 2023-11-13 → 2025-01-21 (+435d) | 1d → 7d | 3d → 4d | A4230 SS → A5470 SS+6d | resources none → Motoniveladora 140K [56 h]; Rodillo Liso Vibratorio Autopropulsado 10-12 tn [56 h] |
| A5500 | GEOTEXTIL NO TEJIDO 400 G/M2, INC. COLOCACIÓN | 2024-03-20 → 2025-01-21 (+307d) | 2024-03-23 → 2025-01-26 (+309d) | 4d → 6d | 3d → 0d | A4690 SS+2d → A5480 SS+2d | resources none → Geotextil no tejido 400 gr/m2 [6091]; CAMION GRUA 20 TON [48 h] |
| A5510 | COLOCACION Y ACOMODO DE ROCA EN UÑA DE DIQUE | 2024-03-21 → 2025-01-21 (+306d) | 2024-03-23 → 2025-02-11 (+325d) | 3d → 22d | 3d → 0d | A5500 SS+1d → A5500 SS, A5460 | resources none → Colocacion y acomodo de roca en uña [4179 m3]; EXCAVADORA CAT 336 [176 h]; TRACTOR SOBRE ORUGAS CAT D6D [44 h] |
| A5520 | COLOCACION Y ACOMODO DE ROCA EN TALUD DE DIQUE | 2024-03-22 → 2025-01-26 (+310d) | 2024-03-27 → 2025-02-13 (+323d) | 6d → 19d | 3d → 0d | A5510 SS+1d → A5510 SS+5d, A5530 | resources none → Colocacion y acomodo de roca en talud [5005 m3]; EXCAVADORA CAT 336 [608 h]; TRACTOR SOBRE ORUGAS CAT D6D [38 h] |
| A5360 | EXCAVACIÓN EN TERRENO NATURAL CON EQUIPO | 2024-01-05 → 2025-02-12 (+404d) | 2024-01-29 → 2025-02-22 (+390d) | 25d → 11d | 3d → 9d | A4740 → A5510 | resources none → Excavacion en terreno natural con equipo [13321 m3]; EXCAVADORA CAT 336 [1408 h] |
| A5380 | PERFILADO Y COMPACTACIÓN EN ZONA DE CORTE | 2024-01-09 → 2025-02-13 (+401d) | 2024-02-07 → 2025-02-26 (+385d) | 30d → 14d | 3d → 9d | A5360 SS+4d → A5360 SS+1d | resources none → EXCAVADORA CAT 336 [56 h] |
| A5370 | EXCAVACIÓN DE UÑA CON EQUIPO | 2024-01-08 → 2025-02-14 (+403d) | 2024-02-03 → 2025-02-23 (+386d) | 27d → 10d | 25d → 0d | A5360 SS+3d → A5520 | resources none → excavacion de uña con equipo [4179 m3]; EXCAVADORA CAT 336 [80 h] |

| ID | Task | Start | Finish | Duration | Total float | Predecessors | Other |
| --- | --- | --- | --- | --- | --- | --- | --- |
| A5440 | PREPARACIÓN DE FUNDACIÓN DE CUERPO DE DIQUE | 2024-03-13 → 2025-02-19 (+343d) | 2024-03-20 → 2025-02-20 (+337d) | 8d → 2d | 3d → 9d | A5470 SS+5d → A5380 SS+6d |  |
| A5410 | GEOTEXTIL NO TEJIDO 400 G/M2, INC. COLOCACIÓN | 2024-02-02 → 2025-02-24 (+388d) | 2024-02-14 → 2025-03-01 (+381d) | 13d → 6d | 3d → 0d | CONFORMACIÓN DE CUERPO DE DIQUE CON MATERIAL PROPIO SS+1d → A5390 SS+2d | resources none → Geotextil no tejido 400 gr/m2 [6091] |
| A5420 | COLOCACION Y ACOMODO DE ROCA EN UÑA DE DIQUE | 2024-02-03 → 2025-02-25 (+388d) | 2024-03-04 → 2025-03-18 (+379d) | 31d → 22d | 3d → 0d | A5410 SS+1d → A5410 SS+1d, A5370 | resources none → Colocacion y acomodo de roca en uña [4179 m3]; EXCAVADORA CAT 336 [176 h] |
| A5430 | COLOCACION Y ACOMODO DE ROCA EN TALUD DE DIQUE | 2024-02-05 → 2025-03-02 (+391d) | 2024-03-03 → 2025-03-20 (+382d) | 28d → 19d | 3d → 0d | A5420 SS+2d → A5420 SS+5d, A5440 | resources none → Colocacion y acomodo de roca en talud [5005 m3]; EXCAVADORA CAT 336 [608 h] |
| A5270 | EXCAVACIÓN EN TERRENO NATURAL CON EQUIPO | 2024-03-31 → 2025-03-19 (+353d) | 2024-04-03 → 2025-03-29 (+360d) | 4d → 11d | 3d → 9d | A4250 → A5420 | resources none → Excavacion en terreno natural con equipo [13321 m3]; TRACTOR SOBRE ORUGAS CAT D6D [44 h] |
| A5290 | PERFILADO Y COMPACTACIÓN EN ZONA DE CORTE | 2024-04-03 → 2025-03-20 (+351d) | 2024-04-08 → 2025-04-02 (+359d) | 6d → 14d | 3d → 9d | A5270 SS+3d → A5270 SS+1d | resources none → Motobomba 8" [89.6 h] |
| A5280 | EXCAVACIÓN DE UÑA CON EQUIPO | 2024-04-03 → 2025-03-21 (+352d) | 2024-04-06 → 2025-03-30 (+358d) | 4d → 10d | 6d → 0d | A5270 SS+3d → A5430 | resources none → excavacion de uña con equipo [4179 m3] |
| A5350 | PREPARACIÓN DE FUNDACIÓN DE CUERPO DE DIQUE | 2023-12-04 → 2025-03-26 (+478d) | 2023-12-21 → 2025-03-27 (+462d) | 18d → 2d | 3d → 9d | A4680 SS+6d → A5290 SS+6d | resources none → Motoniveladora 140K [16 h]; Rodillo Liso Vibratorio Autopropulsado 10-12 tn [16 h] |
| A5320 | GEOTEXTIL NO TEJIDO 400 G/M2, INC. COLOCACIÓN | 2024-04-10 → 2025-03-31 (+355d) | 2024-04-14 → 2025-04-05 (+356d) | 5d → 6d | 3d → 0d | CONFORMACIÓN DE CUERPO DE DIQUE CON MATERIAL PROPIO SS+3d → A5300 SS+2d | resources none → Geotextil no tejido 400 gr/m2 [6091]; Camion grua 20 ton [38.4 h] |
| A5330 | COLOCACION Y ACOMODO DE ROCA EN UÑA DE DIQUE | 2024-04-12 → 2025-04-01 (+354d) | 2024-04-17 → 2025-04-22 (+370d) | 6d → 22d | 3d → 0d | A5320 SS+2d → A5320 SS+1d, A5280 | resources none → Colocacion y acomodo de roca en uña [4179 m3]; TRACTOR SOBRE ORUGAS CAT D6D [44 h] |
| A5340 | COLOCACION Y ACOMODO DE ROCA EN TALUD DE DIQUE | 2024-04-14 → 2025-04-06 (+357d) | 2024-04-19 → 2025-04-24 (+370d) | 6d → 19d | 3d → 0d | A5330 SS+2d → A5330 SS+5d, A5350 | resources none → Colocacion y acomodo de roca en talud [5005 m3]; TRACTOR SOBRE ORUGAS CAT D6D [38 h] |
| 3 | **DIQUE DE TIERRA COMPACTADA A3-I-01** | 2023-11-13 → 2024-11-08 (+361d) | 2024-03-09 → 2024-12-16 (+282d) |  |  |  |  |
| A1440 | EXCAVACIÓN EN TERRENO NATURAL CON EQUIPO | 2023-11-13 → 2024-11-08 (+361d) | 2023-11-18 → 2024-11-18 (+366d) | 6d → 11d | 0d → 7d | A1230 SS+6d → A1230 SS, A1015 SS | resources none → Excavacion en terreno natural con equipo [13764 m3]; EXCAVADORA CAT 336 [176 h]; TRACTOR SOBRE ORUGAS CAT D6D [44 h] |
| A1450 | EXCAVACIÓN DE UÑA CON EQUIPO | 2023-11-16 → 2024-11-22 (+372d) | 2023-11-19 → 2024-11-26 (+373d) | 4d → 5d | 0d → 7d | A1440 SS+3d → A1440 FS+3d | resources none → excavacion de uña con equipo [2275 m3]; EXCAVADORA CAT 336 [40 h]; Motobomba 8" [32 h] |
| A1460 | PERFILADO Y COMPACTACIÓN EN ZONA DE CORTE | 2023-11-16 → 2024-11-22 (+372d) | 2023-11-20 → 2024-11-29 (+375d) | 5d → 8d | 0d → 7d |  | resources none → EXCAVADORA CAT 336 [256 h] |
| A1520 | PREPARACIÓN DE FUNDACIÓN DE CUERPO DE DIQUE | 2023-11-19 → 2024-11-25 (+372d) | 2023-11-21 → 2024-11-26 (+371d) | 3d → 2d | 0d → 7d |  | resources none → Motoniveladora 140K [16 h]; Rodillo Liso Vibratorio Autopropulsado 10-12 tn [16 h] |
| A1470 | CONFORMACIÓN DE CUERPO Y CORONA DE DIQUE CON MATERIAL PROPIO | 2023-11-20 → 2024-11-28 (+374d) | 2023-11-24 → 2024-12-05 (+377d) | 5d → 8d | 0d → 5d | A1520 SS+1d → A1520 SS+1d, A1016 SS | was named CONFORMACIÓN DE CUERPO DE DIQUE CON MATERIAL PROPIO; resources none → Conformacion de cuerpo y corona de dique con mat. propio [3772 m3]; TRACTOR SOBRE ORUGAS CAT D6D [64 h]; Rodillo Liso Vibratorio Autopropulsado 10-12 tn [64 h] |
| A1490 | GEOTEXTIL NO TEJIDO 400 G/M2, INC. COLOCACIÓN | 2023-11-22 → 2024-11-30 (+374d) | 2023-11-24 → 2024-12-04 (+376d) | 3d → 5d | 0d → 5d |  | resources none → Geotextil no tejido 400 gr/m2 [5276]; Camion grua 20 ton [32 h] |
| A1500 | COLOCACION Y ACOMODO DE ROCA EN UÑA DE DIQUE | 2023-11-24 → 2024-12-01 (+373d) | 2023-11-26 → 2024-12-06 (+376d) | 3d → 6d | 0d → 5d | A1490 SS+2d → A1490 SS+1d, A1450 | resources none → Colocacion y acomodo de roca en uña [2275 m3]; EXCAVADORA CAT 336 [48 h]; TRACTOR SOBRE ORUGAS CAT D6D [24 h] |
| A1510 | COLOCACION Y ACOMODO DE ROCA EN TALUD DE DIQUE | 2023-11-26 → 2024-12-03 (+373d) | 2023-11-30 → 2024-12-14 (+380d) | 5d → 12d | 0d → 5d | A1500 SS+2d → A1500 SS+2d, A1440 | resources none → Colocacion y acomodo de roca en talud [3426 m3]; EXCAVADORA CAT 336 [384 h]; TRACTOR SOBRE ORUGAS CAT D6D [48 h] |
| A1480 | CONFORMACIÓN DE CORONA DE DIQUE CON MATERIAL PROPIO | 2023-11-30 → 2024-12-12 (+378d) | 2023-12-02 → 2024-12-16 (+380d) | 3d → 5d | 0d → 5d |  |  |
| 4 | **DIQUE DE TIERRA COMPACTADA A3-I-02** | 2024-03-10 → 2024-12-17 (+282d) | 2024-04-05 → 2025-01-16 (+286d) |  |  |  |  |
| A4390 | EXCAVACIÓN EN TERRENO NATURAL CON EQUIPO | 2024-03-10 → 2024-12-17 (+282d) | 2024-03-23 → 2024-12-31 (+283d) | 14d → 15d | 0d → 5d | CONFORMACIÓN DE CORONA DE DIQUE CON MATERIAL PROPIO → A1520, A1510, A1480 | resources none → Excavacion en terreno natural con equipo [18781 m3]; EXCAVADORA CAT 336 [240 h]; TRACTOR SOBRE ORUGAS CAT D6D [120 h] |
| A4400 | EXCAVACIÓN DE UÑA CON EQUIPO | 2024-03-11 → 2024-12-18 (+282d) | 2024-03-23 → 2024-12-24 (+276d) | 13d → 7d | 1d → 12d |  | resources none → excavacion de uña con equipo [3101 m3]; EXCAVADORA CAT 336 [56 h]; Motobomba 8" [44.8 h] |
| A4410 | PERFILADO Y COMPACTACIÓN EN ZONA DE CORTE | 2024-03-15 → 2024-12-20 (+280d) | 2024-03-24 → 2024-12-30 (+281d) | 10d → 11d | 0d → 5d | A4390 SS+5d → A4390 SS+3d |  |
| A4470 | PREPARACIÓN DE FUNDACIÓN DE CUERPO DE DIQUE | 2024-03-21 → 2024-12-31 (+285d) | 2024-03-25 → 2024-12-31 (+281d) | 5d → 1d | 3d → 5d |  | resources none → Motoniveladora 140K [8 h]; Rodillo Liso Vibratorio Autopropulsado 10-12 tn [8 h] |
| A4420 | CONFORMACIÓN DE CUERPO Y CORONA DE DIQUE CON MATERIAL PROPIO | 2024-03-24 → 2025-01-01 (+283d) | 2024-03-26 → 2025-01-02 (+282d) | 3d → 2d | 1d → 5d |  | was named CONFORMACIÓN DE CUERPO DE DIQUE CON MATERIAL PROPIO; resources none → Conformacion de cuerpo y corona de dique con mat. propio [1739 m3]; TRACTOR SOBRE ORUGAS CAT D6D [16 h]; Rodillo Liso Vibratorio Autopropulsado 10-12 tn [16 h] |
| A4440 | GEOTEXTIL NO TEJIDO 400 G/M2, INC. COLOCACIÓN | 2024-03-25 → 2025-01-01 (+282d) | 2024-03-29 → 2025-01-05 (+282d) |  | 0d → 9d |  | resources none → Geotextil no tejido 400 gr/m2 [4752]; CAMION GRUA 20 TON [40 h] |
| A4450 | COLOCACION Y ACOMODO DE ROCA EN UÑA DE DIQUE | 2024-03-25 → 2025-01-01 (+282d) | 2024-03-30 → 2025-01-16 (+292d) | 6d → 16d | 0d → 9d |  | resources none → Colocacion y acomodo de roca en uña [3101 m3]; EXCAVADORA CAT 336 [128 h]; TRACTOR SOBRE ORUGAS CAT D6D [32 h] |
| A4460 | COLOCACION Y ACOMODO DE ROCA EN TALUD DE DIQUE | 2024-03-25 → 2025-01-01 (+282d) | 2024-04-04 → 2025-01-14 (+285d) | 11d → 14d | 0d → 9d |  | resources none → Colocacion y acomodo de roca en talud [3837 m3]; EXCAVADORA CAT 336 [448 h]; TRACTOR SOBRE ORUGAS CAT D6D [56 h] |
| A4430 | CONFORMACIÓN DE CORONA DE DIQUE CON MATERIAL PROPIO | 2024-03-31 → 2025-01-10 (+285d) | 2024-04-05 → 2025-01-15 (+285d) |  | 0d → 26d |  |  |
| 5 | **DIQUE DE TIERRA COMPACTADA A3-I-03** | 2023-12-03 → 2025-01-15 (+409d) | 2024-04-25 → 2025-04-20 (+360d) |  |  |  |  |
| A4930 | EXCAVACIÓN EN TERRENO NATURAL CON EQUIPO | 2023-12-03 → 2025-01-15 (+409d) | 2023-12-27 → 2025-01-23 (+393d) | 25d → 9d | 0d → 9d | A1480 → A4460 | resources none → Excavacion en terreno natural con equipo [11506 m3]; EXCAVADORA CAT 336 [144 h]; TRACTOR SOBRE ORUGAS CAT D6D [72 h] |
| A4950 | PERFILADO Y COMPACTACIÓN EN ZONA DE CORTE | 2023-12-04 → 2025-01-16 (+409d) | 2024-01-02 → 2025-01-31 (+395d) | 30d → 16d | 0d → 26d | A4930 SS+1d → A4930 SS+1d, A4430 | resources none → Motobomba 8" [102.4 h] |
| A4940 | EXCAVACIÓN DE UÑA CON EQUIPO | 2023-12-07 → 2025-01-17 (+407d) | 2023-12-29 → 2025-01-26 (+394d) | 23d → 10d | 13d → 10d | A4930 SS+4d → A4450 | resources none → excavacion de uña con equipo [4593 m3]; EXCAVADORA CAT 336 [80 h] |
| A4970 | CONFORMACIÓN DE CUERPO Y CORONA DE DIQUE CON MATERIAL PROPIO | 2023-12-22 → 2025-01-19 (+394d) | 2024-01-02 → 2025-01-26 (+390d) | 12d → 8d | 0d → 12d | A4940 SS+2d, A4960 SS+2d → A4940 SS+2d | was named CONFORMACIÓN DE CUERPO DE DIQUE CON MATERIAL PROPIO; resources none → Conformacion de cuerpo y corona de dique con mat. propio [3253 m3]; TRACTOR SOBRE ORUGAS CAT D6D [64 h]; Rodillo Liso Vibratorio Autopropulsado 10-12 tn [64 h] |
| A4980 | GEOTEXTIL NO TEJIDO 400 G/M2, INC. COLOCACIÓN | 2023-12-24 → 2025-01-21 (+394d) | 2024-01-05 → 2025-01-27 (+388d) | 13d → 7d | 0d → 12d |  | resources none → Geotextil no tejido 400 gr/m2 [6607]; CAMION GRUA 20 TON [56 h] |
| A4990 | COLOCACION Y ACOMODO DE ROCA EN UÑA DE DIQUE | 2023-12-25 → 2025-01-24 (+396d) | 2024-01-23 → 2025-02-15 (+389d) | 30d → 23d | 0d → 9d | A4980 SS+1d → A4980 SS, A4930 | resources none → Colocacion y acomodo de roca en uña [4593 m3]; EXCAVADORA CAT 336 [184 h]; TRACTOR SOBRE ORUGAS CAT D6D [46 h] |
| A5000 | COLOCACION Y ACOMODO DE ROCA EN TALUD DE DIQUE | 2023-12-27 → 2025-01-27 (+397d) | 2024-01-23 → 2025-02-16 (+390d) | 28d → 21d | 0d → 10d | A4990 SS+2d → A4990 SS+1d, A4940 | resources none → Colocacion y acomodo de roca en talud [5548 m3]; EXCAVADORA CAT 336 [672 h]; TRACTOR SOBRE ORUGAS CAT D6D [84 h] |
| A4960 | PREPARACIÓN DE FUNDACIÓN DE CUERPO DE DIQUE | 2023-12-20 → 2025-02-01 (+409d) | 2023-12-31 → 2025-02-05 (+402d) | 12d → 5d | 0d → 26d |  | resources none → Motoniveladora 140K [40 h]; Rodillo Liso Vibratorio Autopropulsado 10-12 tn [40 h] |
| A5010 | CONFORMACIÓN DE CORONA DE DIQUE CON MATERIAL PROPIO | 2024-01-12 → 2025-02-15 (+400d) | 2024-01-24 → 2025-02-16 (+389d) | 13d → 2d | 0d → 72d | A5000 FF+1d → A5000 FF |  |
| A5630 | EXCAVACIÓN EN TERRENO NATURAL CON EQUIPO | 2024-02-26 → 2025-02-16 (+356d) | 2024-03-01 → 2025-02-24 (+360d) | 5d → 9d | 0d → 9d | CONFORMACIÓN DE CORONA DE DIQUE CON MATERIAL PROPIO → A4990 | resources none → Excavacion en terreno natural con equipo [11506 m3]; EXCAVADORA CAT 336 [144 h]; TRACTOR SOBRE ORUGAS CAT D6D [72 h] |
| A5650 | PERFILADO Y COMPACTACIÓN EN ZONA DE CORTE | 2024-02-27 → 2025-02-16 (+355d) | 2024-03-01 → 2025-03-03 (+367d) | 4d → 16d | 0d → 35d | A5630 SS+1d, A5640 SS → A5630 SS |  |
| A5640 | EXCAVACIÓN DE UÑA CON EQUIPO | 2024-02-27 → 2025-02-17 (+356d) | 2024-02-29 → 2025-02-26 (+363d) | 3d → 10d | 0d → 10d | A5630 SS+1d → A5000 | resources none → excavacion de uña con equipo [4593 m3]; EXCAVADORA CAT 336 [80 h]; Motobomba 8" [80 h] |
| A5680 | GEOTEXTIL NO TEJIDO 400 G/M2, INC. COLOCACIÓN | 2024-03-01 → 2025-02-20 (+356d) | 2024-03-03 → 2025-02-26 (+360d) | 3d → 7d | 0d → 14d | CONFORMACIÓN DE CUERPO DE DIQUE CON MATERIAL PROPIO SS+2d → A5660 SS+2d | resources none → Geotextil no tejido 400 gr/m2 [6607]; CAMION GRUA 20 TON [56 h] |
| A5710 | PREPARACIÓN DE FUNDACIÓN DE CUERPO DE DIQUE | 2024-01-30 → 2025-02-21 (+388d) | 2024-02-08 → 2025-02-22 (+380d) | 10d → 2d | 3d → 35d | A5380 SS+21d → A5650 SS+5d | resources none → Motoniveladora 140K [12.8 h]; Rodillo Liso Vibratorio Autopropulsado 10-12 tn [16 h] |
| A5690 | COLOCACION Y ACOMODO DE ROCA EN UÑA DE DIQUE | 2024-03-03 → 2025-02-25 (+359d) | 2024-03-05 → 2025-03-19 (+379d) | 3d → 23d | 0d → 9d | A5680 SS+2d → A5680 SS, A5630 | resources none → Colocacion y acomodo de roca en uña [4593 m3]; EXCAVADORA CAT 336 [184 h]; TRACTOR SOBRE ORUGAS CAT D6D [92 h] |
| A5700 | COLOCACION Y ACOMODO DE ROCA EN TALUD DE DIQUE | 2024-03-04 → 2025-02-27 (+360d) | 2024-03-08 → 2025-03-19 (+376d) | 5d → 21d | 0d → 10d | A5690 SS+1d → A5690 SS+1d, A5640 | resources none → Colocacion y acomodo de roca en talud [5548 m3]; EXCAVADORA CAT 336 [672 h]; TRACTOR SOBRE ORUGAS CAT D6D [168 h] |
| A5540 | EXCAVACIÓN EN TERRENO NATURAL CON EQUIPO | 2024-01-25 → 2025-03-20 (+420d) | 2024-02-03 → 2025-03-28 (+419d) | 10d → 9d | 0d → 9d | A5010 → A5690 | resources none → Excavacion en terreno natural con equipo [11506 m3]; EXCAVADORA CAT 336 [144 h]; TRACTOR SOBRE ORUGAS CAT D6D [36 h] |
| A5550 | EXCAVACIÓN DE UÑA CON EQUIPO | 2024-01-27 → 2025-03-20 (+418d) | 2024-02-04 → 2025-03-29 (+419d) | 9d → 10d | 6d → 10d | A5540 SS+2d → A5540 SS, A5700, A5710 | resources none → excavacion de uña con equipo [4593 m3]; EXCAVADORA CAT 336 [80 h]; Motobomba 8" [80 h] |
| A5560 | PERFILADO Y COMPACTACIÓN EN ZONA DE CORTE | 2024-01-28 → 2025-03-20 (+417d) | 2024-02-07 → 2025-04-04 (+422d) | 11d → 16d | 0d → 23d | A5540 SS+3d → A5540 SS |  |
| A5590 | GEOTEXTIL NO TEJIDO 400 G/M2, INC. COLOCACIÓN | 2024-02-09 → 2025-03-23 (+408d) | 2024-02-13 → 2025-03-29 (+410d) | 5d → 7d | 0d → 15d | CONFORMACIÓN DE CUERPO DE DIQUE CON MATERIAL PROPIO SS+2d → A5570 SS+2d | resources none → Geotextil no tejido 400 gr/m2 [6607]; Camion grua 20 ton [56 h] |
| A5600 | COLOCACION Y ACOMODO DE ROCA EN UÑA DE DIQUE | 2024-02-10 → 2025-03-29 (+413d) | 2024-02-21 → 2025-04-20 (+424d) | 12d → 23d | 0d → 9d | A5590 SS+1d → A5590 SS, A5540 | resources none → Colocacion y acomodo de roca en uña [4593 m3]; EXCAVADORA CAT 336 [184 h]; TRACTOR SOBRE ORUGAS CAT D6D [46 h] |
| A5610 | COLOCACION Y ACOMODO DE ROCA EN TALUD DE DIQUE | 2024-02-12 → 2025-03-30 (+412d) | 2024-02-22 → 2025-04-19 (+422d) | 11d → 21d | 0d → 10d | A5600 SS+2d → A5600 SS+1d, A5550 | resources none → Colocacion y acomodo de roca en talud [5548 m3]; EXCAVADORA CAT 336 [672 h]; TRACTOR SOBRE ORUGAS CAT D6D [84 h] |
| A5620 | PREPARACIÓN DE FUNDACIÓN DE CUERPO DE DIQUE | 2024-04-06 → 2025-04-05 (+364d) | 2024-04-10 → 2025-04-06 (+361d) | 5d → 2d | 3d → 23d | A5290 SS+3d → A5560 SS+16d | resources none → Motoniveladora 140K [16 h]; Rodillo Liso Vibratorio Autopropulsado 10-12 tn [16 h] |
| 6 | **RAMPAS** | 2024-03-09 → 2025-01-27 (+324d) | 2024-04-16 → 2025-04-12 (+361d) |  |  |  |  |
| 2 | **A3-RA-I-01** | 2024-04-12 → 2025-01-27 (+290d) | 2024-04-16 → 2025-02-13 (+303d) |  |  |  |  |
| A1740 | EXCAVACIÓN EN TERRENO NATURAL CON EQUIPO | 2024-04-12 → 2025-01-27 (+290d) | 2024-04-14 → 2025-02-04 (+296d) | 3d → 9d | 9d → 55d | EXCAVACIÓN DE UÑA CON EQUIPO → A4940, A4930 | resources none → Excavacion [72] |
| A1750 | CONFORMACIÓN DE CUERPO DE RAMPA CON MATERIAL PROPIO | 2024-04-15 → 2025-02-05 (+296d) | 2024-04-16 → 2025-02-13 (+303d) | 2d → 9d | 9d → 55d |  | resources none → TRACTOR SOBRE ORUGAS CAT D6D [72 h]; Rodillo Liso Vibratorio Autopropulsado 10-12 tn [72 h] |
| A1760 | CONFORMACIÓN DE CORONACIÓN DE RAMPA | 2024-04-15 → 2025-02-05 (+296d) | 2024-04-16 → 2025-02-13 (+303d) | 2d → 9d | 9d → 55d | A1750 SS, A1730 → A1750 SS | resources none → Motoniveladora 140K [57.6 h]; Rodillo Liso Vibratorio Autopropulsado 10-12 tn [72 h] |
| 1 | **A3-RA-D-01** | 2024-03-09 → 2025-03-31 (+387d) | 2024-03-14 → 2025-04-12 (+394d) |  |  |  |  |
| A1710 | EXCAVACIÓN EN TERRENO NATURAL CON EQUIPO | 2024-03-09 → 2025-03-31 (+387d) | 2024-03-11 → 2025-04-06 (+391d) | 3d → 7d | 40d → 12d | A5700 → A5280 | resources none → EXCAVADORA CAT 336 [56 h] |
| A1720 | CONFORMACIÓN DE CUERPO DE RAMPA CON MATERIAL PROPIO | 2024-03-12 → 2025-04-07 (+391d) | 2024-03-14 → 2025-04-12 (+394d) | 3d → 6d | 40d → 12d |  | resources none → TRACTOR SOBRE ORUGAS CAT D6D [48 h]; Rodillo Liso Vibratorio Autopropulsado 10-12 tn [48 h] |
| A1730 | CONFORMACIÓN DE CORONACIÓN DE RAMPA | 2024-03-12 → 2025-04-07 (+391d) | 2024-03-14 → 2025-04-12 (+394d) | 3d → 6d | 40d → 12d |  | resources none → Motoniveladora 140K [48 h]; Rodillo Liso Vibratorio Autopropulsado 10-12 tn [48 h] |
| 2 | **OBRAS DE ARTE** | 2023-11-06 → 2024-11-08 (+368d) | 2024-03-18 → 2025-04-25 (+403d) |  |  |  |  |
| 1 | **CAPTACIÓN A3-CP-23-95** | 2023-11-21 → 2024-11-26 (+371d) | 2024-03-18 → 2025-04-12 (+390d) |  |  |  |  |
| 1 | **MOVIMIENTO DE TIERRAS** | 2023-11-21 → 2024-11-26 (+371d) | 2024-01-07 → 2025-01-12 (+371d) |  |  |  |  |
| A2770 | EXCAVACIÓN ESTRUCTURAL PARA OBRAS DE ARTE | 2023-11-21 → 2024-11-26 (+371d) | 2023-11-26 → 2024-12-01 (+371d) |  | 38d → 4d | A3390 → A4660 SS | resources none → RETROEXCAVADORA SOBRE LLANTAS 94 HP, 1.25 Y3 [48 h] |
| A2780 | RELLENO ESTRUCTURAL PARA OBRAS DE ARTE, CON MATERIAL PROPIO | 2024-01-03 → 2025-01-07 (+370d) | 2024-01-07 → 2025-01-12 (+371d) | 5d → 6d | 90d → 29d | A2800 FS+12d → A2800, A5220 | resources none → RETROEXCAVADORA SOBRE LLANTAS 94 HP, 1.25 Y3 [12 h]; RODILLO LISO VIBRATORIO MANUAL 10.8 HP 0.8 -1.1 Ton [48 h] |
| 2 | **OBRAS DE CONCRETO** | 2023-11-27 → 2024-12-02 (+371d) | 2023-12-21 → 2025-01-06 (+382d) |  |  |  |  |

| ID | Task | Start | Finish | Duration | Total float | Predecessors | Other |
| --- | --- | --- | --- | --- | --- | --- | --- |
| A2790 | CONCRETO f'c=100 kg/cm2 | 2023-11-27 → 2024-12-02 (+371d) | 2023-11-29 → 2024-12-04 (+371d) |  | 50d → 14d |  | resources none → Colocacion de concreto f'c=100 kg/cm2 [13 m3] |
| A2810 | CONCRETO CICLÓPEO f'c=280 kg/cm2 + 30% P.G. | 2023-11-30 → 2024-12-05 (+371d) | 2023-12-02 → 2024-12-07 (+371d) |  | 50d → 14d |  | resources none → Colocacion de concreto ciclopeo [4 m3] |
| A2800 | CONCRETO f'c=280 kg/cm2 | 2023-12-10 → 2024-12-08 (+364d) | 2023-12-21 → 2024-12-19 (+364d) |  | 55d → 19d | A2820 SS+3d → A2820 SS | resources none → Colocacion de concreto f'c=280 kg/cm2 [115 m3] |
| A2820 | ENCOFRADO Y DESENCOFRADO RECTO | 2023-12-07 → 2024-12-08 (+367d) | 2023-12-16 → 2024-12-20 (+370d) | 10d → 13d | 53d → 18d | A2830 FF+1d → A2830 FF | resources none → Encofrado Recto [94 m3] |
| A2830 | ACERO DE REFUERZO fy=4200 kg/cm2 | 2023-12-03 → 2024-12-08 (+371d) | 2023-12-15 → 2024-12-20 (+371d) |  | 50d → 14d |  | resources none → armado de acero fy=4200 kg/cm2 [6894 kg] |
| 3 | **ESTRUCTURAS METALICAS** | 2024-01-03 → 2025-01-01 (+364d) | 2024-01-17 → 2025-01-15 (+364d) |  |  |  |  |
| A2840 | COMPUERTA METALICA PLANA DESLIZANTE DE 1.0x1.0m | 2024-01-03 → 2025-01-01 (+364d) | 2024-01-05 → 2025-01-03 (+364d) |  | 99d → 19d | A2800 FS+12d → A5750 | resources none → CAMION GRUA 20 TON [24 h] |
| A2850 | REJILLA DE 1.00x1.00m CON VARILLA DE 1/2" CADA 6,25cm | 2024-01-06 → 2025-01-04 (+364d) | 2024-01-08 → 2025-01-06 (+364d) |  | 99d → 19d |  | resources none → CAMION GRUA 20 TON [24 h] |
| A2860 | BARANDA DE FIERRO GALVANIZADO 1 1/2" | 2024-01-09 → 2025-01-07 (+364d) | 2024-01-11 → 2025-01-09 (+364d) |  | 99d → 19d |  | resources none → CAMION GRUA 20 TON [24 h] |
| A2870 | ESCALERA TIPO GATO | 2024-01-12 → 2025-01-10 (+364d) | 2024-01-14 → 2025-01-12 (+364d) |  | 99d → 19d |  | resources none → CAMION GRUA 20 TON [24 h] |
| A2880 | TAPA METALICA CIRCULAR DN600 MM | 2024-01-15 → 2025-01-13 (+364d) | 2024-01-17 → 2025-01-15 (+364d) |  | 99d → 19d |  | resources none → CAMION GRUA 20 TON [24 h] |
| 4 | **TUBERIAS** | 2023-11-27 → 2024-12-02 (+371d) | 2024-01-23 → 2025-01-24 (+367d) |  |  |  |  |
| A2890 | EXCAVACIÓN ESTRUCTURAL PARA OBRAS DE ARTE (Buzones) | 2023-11-27 → 2024-12-02 (+371d) | 2023-11-29 → 2024-12-04 (+371d) |  | 38d → 4d |  |  |
| A2900 | EXCAVACIÓN DE ZANJA | 2023-11-30 → 2024-12-05 (+371d) | 2023-12-24 → 2024-12-29 (+371d) |  | 38d → 4d |  | resources none → RETROEXCAVADORA SOBRE LLANTAS 94 HP, 1.25 Y3 [200 h] |
| A2920 | CAMA DE ARENA | 2023-12-03 → 2024-12-05 (+368d) | 2023-12-27 → 2024-12-29 (+368d) |  | 93d → 25d | A2900 SS+3d → A2900 SS |  |
| A2940 | CONCRETO f'c=100 kg/cm2 (Buzones) | 2023-12-03 → 2024-12-05 (+368d) | 2023-12-05 → 2024-12-07 (+368d) |  | 60d → 27d | A2900 SS+3d, A2790 → A2900 SS, A2790 | resources none → Colocacion de concreto f'c=100 kg/cm2 [2 m3] |
| A2990 | SUMINISTRO E INSTALACIÓN DE TUBERÍA GRP DN600 mm SN2500 | 2023-12-04 → 2024-12-05 (+367d) | 2023-12-28 → 2024-12-29 (+367d) |  | 93d → 25d | A2920 SS+1d → A2920 SS | resources none → Camion grua 20 ton [160 h] |
| A2980 | ACERO DE REFUERZO fy=4200 kg/cm2 (Buzones) | 2023-12-16 → 2024-12-21 (+371d) | 2023-12-19 → 2024-12-24 (+371d) |  | 50d → 14d |  | resources none → armado de acero fy=4200 kg/cm2 [569 kg] |
| A2960 | ENCOFRADO Y DESENCOFRADO RECTO | 2023-12-20 → 2024-12-25 (+371d) | 2023-12-24 → 2024-12-29 (+371d) |  | 50d → 14d |  | resources none → Encofrado Recto [13 m3] |
| A2970 | ENCOFRADO Y DESENCOFRADO CURVO | 2023-12-20 → 2024-12-25 (+371d) | 2023-12-24 → 2024-12-29 (+371d) |  | 50d → 14d |  | resources none → Encofrado Curvo [25 m3] |
| A2930 | RELLENO COMÚN PARA ZANJAS | 2023-12-29 → 2024-12-30 (+367d) | 2024-01-23 → 2025-01-24 (+367d) |  | 93d → 25d |  | resources none → RETROEXCAVADORA SOBRE LLANTAS 94 HP, 1.25 Y3 [208 h] |
| A2950 | CONCRETO f'c=280 kg/cm2 (Buzones) | 2023-12-25 → 2024-12-30 (+371d) | 2023-12-27 → 2025-01-01 (+371d) |  | 52d → 23d |  | resources none → Colocacion de concreto f'c=280 kg/cm2 [11 m3] |
| A2910 | RELLENO ESTRUCTURAL PARA OBRAS DE ARTE CON MATERIAL PROPIO (Buzones) | 2024-01-09 → 2025-01-14 (+371d) | 2024-01-11 → 2025-01-21 (+376d) | 3d → 8d | 89d → 28d | A2950 FS+12d, A2780 → A2950 FS+12d, A2780, A1200, A3160 |  |
| 5 | **CANAL** | 2023-12-25 → 2024-12-30 (+371d) | 2024-02-29 → 2025-03-18 (+383d) |  |  |  |  |
| A3000 | EXCAVACIÓN ESTRUCTURAL PARA OBRAS DE ARTE | 2023-12-25 → 2024-12-30 (+371d) | 2023-12-30 → 2025-01-04 (+371d) |  | 38d → 4d |  |  |
| A3020 | COLOCACIÓN DE CONCRETO f'c=100 kg/cm2 | 2023-12-31 → 2025-01-05 (+371d) | 2024-01-03 → 2025-01-08 (+371d) |  | 38d → 4d |  | resources none → Colocacion de concreto f'c=100 kg/cm2 [38 m3] |
| A3040 | ENCOFRADO Y DESENCOFRADO RECTO | 2024-01-06 → 2025-01-09 (+369d) | 2024-02-26 → 2025-03-01 (+369d) |  | 38d → 4d | A2970, A3050 SS+2d → A2970, A3050 SS | resources none → Encofrado Recto [2032 m3] |
| A3050 | ACERO DE REFUERZO fy=4200 kg/cm2 | 2024-01-04 → 2025-01-09 (+371d) | 2024-01-31 → 2025-02-05 (+371d) |  | 38d → 4d |  | resources none → armado de acero fy=4200 kg/cm2 [14268 kg] |
| A3030 | COLOCACIÓN DE CONCRETO f'c=280 kg/cm2 | 2024-01-08 → 2025-01-11 (+369d) | 2024-02-29 → 2025-03-04 (+369d) |  | 38d → 11d |  | resources none → Colocacion de concreto f'c=280 kg/cm2 [164 m3] |
| A3060 | JUNTA WATER STOP SIN BULBO 150 mm | 2024-01-08 → 2025-01-11 (+369d) | 2024-02-29 → 2025-03-18 (+383d) | 53d → 67d | 53d → 20d |  | resources none → CAMION GRUA 20 TON [536 h] |
| A3010 | RELLENO ESTRUCTURAL PARA CANALES, CON MATERIAL PROPIO | 2024-01-12 → 2025-01-25 (+379d) | 2024-01-24 → 2025-03-08 (+409d) | 13d → 43d | 89d → 25d | A2910 → A2910, A2930 | resources none → Rodillo liso vibratorio 0.80 - 1.10 ton [344 h]; RETROEXCAVADORA SOBRE LLANTAS 94 HP, 1.25 Y3 [86 h] |
| 6 | **OBRAS DE DESCARGA** | 2023-12-31 → 2025-01-05 (+371d) | 2024-03-18 → 2025-04-12 (+390d) |  |  |  |  |
| A3070 | EXCAVACIÓN ESTRUCTURAL PARA OBRAS DE ARTE | 2023-12-31 → 2025-01-05 (+371d) | 2024-01-02 → 2025-01-14 (+378d) | 3d → 10d | 87d → 30d |  | resources none → RETROEXCAVADORA SOBRE LLANTAS 94 HP, 1.25 Y3 [80 h] |
| A3090 | CONCRETO f'c=100 kg/cm2 | 2024-01-04 → 2025-01-15 (+377d) | 2024-01-06 → 2025-01-24 (+384d) | 3d → 10d | 86d → 30d |  | resources none → Colocacion de concreto f'c=100 kg/cm2 [2 m3] |
| A3120 | ACERO DE REFUERZO fy=4200 kg/cm2 | 2024-02-01 → 2025-02-06 (+371d) | 2024-02-03 → 2025-02-15 (+378d) | 3d → 10d | 61d → 18d |  | resources none → armado de acero fy=4200 kg/cm2 [78 kg] |
| A3110 | ENCOFRADO Y DESENCOFRADO RECTO | 2024-02-27 → 2025-03-02 (+369d) | 2024-02-29 → 2025-03-11 (+376d) | 3d → 10d | 38d → 4d |  | resources none → Encofrado Recto [24 m3] |
| A3100 | CONCRETO f'c=280 kg/cm2 | 2024-03-01 → 2025-03-12 (+376d) | 2024-03-03 → 2025-03-21 (+383d) | 3d → 10d | 38d → 4d |  | resources none → Colocacion de concreto f'c=280 kg/cm2 [3 m3] |
| A3130 | JUNTA WATER STOP SIN BULBO 150 mm | 2024-03-04 → 2025-03-22 (+383d) | 2024-03-06 → 2025-04-02 (+392d) | 3d → 12d | 50d → 17d |  | resources none → CAMION GRUA 20 TON [96 h] |
| A3080 | RELLENO ESTRUCTURAL PARA OBRAS DE ARTE CON MATERIAL PROPIO | 2024-03-16 → 2025-03-30 (+379d) | 2024-03-18 → 2025-04-08 (+386d) | 3d → 10d | 38d → 4d | A3100 FS+12d, A3010 → A3100 FS+8d, A3010 | resources none → RETROEXCAVADORA SOBRE LLANTAS 94 HP, 1.25 Y3 [20 h]; RODILLO LISO VIBRATORIO MANUAL 10.8 HP 0.8 -1.1 Ton [80 h] |
| A3140 | COMPUERTA METALICA PLANA DESLIZANTE | 2024-03-16 → 2025-04-03 (+383d) | 2024-03-18 → 2025-04-12 (+390d) | 3d → 10d | 38d → 17d | A3100 FS+12d → A3100 FS+12d, A3130 | resources none → CAMION GRUA 20 TON [80 h] |
| 2 | **CAPTACIÓN A3-CP-21-05** | 2023-11-09 → 2024-11-08 (+365d) | 2024-02-06 → 2025-03-15 (+403d) |  |  |  |  |
| 1 | **MOVIMIENTO DE TIERRAS** | 2023-11-09 → 2024-11-08 (+365d) | 2023-12-28 → 2025-01-05 (+374d) |  |  |  |  |
| A3150 | EXCAVACIÓN ESTRUCTURAL PARA OBRAS DE ARTE | 2023-11-09 → 2024-11-08 (+365d) | 2023-11-12 → 2024-11-11 (+365d) |  | 38d → 10d | A1070 SS+7d → A1070 SS+7d, A1015 SS, A1440 SS | resources none → RETROEXCAVADORA SOBRE LLANTAS 94 HP, 1.25 Y3 [32 h] |
| A3160 | RELLENO ESTRUCTURAL PARA OBRAS DE ARTE, CON MATERIAL PROPIO | 2023-12-24 → 2024-12-14 (+356d) | 2023-12-28 → 2025-01-05 (+374d) | 5d → 23d | 119d → 36d | A3180 FS+12d → A3180 | resources none → RETROEXCAVADORA SOBRE LLANTAS 94 HP, 1.25 Y3 [46 h]; RODILLO LISO VIBRATORIO MANUAL 10.8 HP 0.8 -1.1 Ton [184 h] |
| 2 | **OBRAS DE CONCRETO** | 2023-11-13 → 2024-11-12 (+365d) | 2023-12-11 → 2024-12-25 (+380d) |  |  |  |  |
| A3170 | CONCRETO f'c=100 kg/cm2 | 2023-11-13 → 2024-11-12 (+365d) | 2023-11-15 → 2024-11-14 (+365d) |  | 79d → 10d |  | resources none → Colocacion de concreto f'c=100 kg/cm2 [11 m3] |
| A3190 | CONCRETO CICLÓPEO f'c=280 kg/cm2 + 30% P.G. | 2023-11-16 → 2024-11-15 (+365d) | 2023-11-18 → 2024-11-17 (+365d) |  | 79d → 10d |  | resources none → Colocacion de concreto ciclopeo [3 m3] |
| A3180 | CONCRETO f'c=280 kg/cm2 | 2023-12-01 → 2024-11-18 (+353d) | 2023-12-11 → 2024-12-13 (+368d) | 11d → 26d | 109d → 10d | A3200 SS+6d → A3200 SS | resources none → Colocacion de concreto f'c=280 kg/cm2 [109 m3] |
| A3200 | ENCOFRADO Y DESENCOFRADO RECTO | 2023-11-25 → 2024-11-18 (+359d) | 2023-12-09 → 2024-12-09 (+366d) | 15d → 22d | 82d → 10d | A3210 SS+6d → A3210 SS | resources none → Encofrado Recto [288 m3] |
| A3210 | ACERO DE REFUERZO fy=4200 kg/cm2 | 2023-11-19 → 2024-11-18 (+365d) | 2023-12-09 → 2024-12-08 (+365d) |  | 79d → 10d |  | resources none → armado de acero fy=4200 kg/cm2 [7198 kg] |
| 3 | **ESTRUCTURAS METALICAS** | 2023-12-24 → 2024-12-26 (+368d) | 2024-01-07 → 2025-02-13 (+403d) |  |  |  |  |
| A3220 | COMPUERTA METALICA PLANA DESLIZANTE DE 1.0x1.0m | 2023-12-24 → 2024-12-26 (+368d) | 2023-12-26 → 2025-01-04 (+375d) | 3d → 10d | 109d → 10d | A3180 FS+12d → A3180, A5230 | resources none → CAMION GRUA 20 TON [80 h] |
| A3230 | REJILLA DE 1.00x1.00m CON VARILLA DE 1/2 CADA 6,25cm | 2023-12-27 → 2025-01-05 (+375d) | 2023-12-29 → 2025-01-14 (+382d) | 3d → 10d | 109d → 10d |  | resources none → CAMION GRUA 20 TON [80 h] |
| A3240 | BARANDA DE FIERRO GALVANIZADO 1 1/2" | 2023-12-30 → 2025-01-15 (+382d) | 2024-01-01 → 2025-01-24 (+389d) | 3d → 10d | 109d → 10d |  | resources none → CAMION GRUA 20 TON [80 h] |
| A3250 | ESCALERA TIPO GATO | 2024-01-02 → 2025-01-25 (+389d) | 2024-01-04 → 2025-02-03 (+396d) | 3d → 10d | 109d → 10d |  | resources none → CAMION GRUA 20 TON [80 h] |
| A3260 | TAPA METALICA CIRCULAR DN600 MM | 2024-01-05 → 2025-02-04 (+396d) | 2024-01-07 → 2025-02-13 (+403d) | 3d → 10d | 109d → 10d |  | resources none → CAMION GRUA 20 TON [80 h] |
| 4 | **TUBERIA** | 2023-11-13 → 2024-11-12 (+365d) | 2024-01-02 → 2025-01-12 (+376d) |  |  |  |  |
| A3270 | EXCAVACIÓN ESTRUCTURAL PARA OBRAS DE ARTE (Buzones) | 2023-11-13 → 2024-11-12 (+365d) | 2023-11-15 → 2024-11-17 (+368d) | 3d → 6d | 38d → 33d |  | resources none → EXCAVADORA CAT 336 [48 h] |
| A3280 | EXCAVACIÓN DE ZANJA | 2023-11-16 → 2024-11-18 (+368d) | 2023-11-18 → 2024-11-23 (+371d) | 3d → 6d | 143d → 113d |  | resources none → RETROEXCAVADORA SOBRE LLANTAS 94 HP, 1.25 Y3 [48 h] |
| A3330 | CONCRETO f'c=100 kg/cm2 (Buzones) | 2023-11-16 → 2024-11-18 (+368d) | 2023-11-18 → 2024-11-23 (+371d) | 3d → 6d | 100d → 33d |  | resources none → Colocacion de concreto f'c=100 kg/cm2 [1 m3] |
| A3300 | CAMA DE ARENA | 2023-11-19 → 2024-11-24 (+371d) | 2023-11-21 → 2024-11-29 (+374d) | 3d → 6d | 143d → 113d |  | resources none → CAMION GRUA 20 TON [48 h] |
| A3380 | SUMINISTRO E INSTALACIÓN DE TUBERÍA GRP DN600 mm SN2500 | 2023-11-22 → 2024-11-30 (+374d) | 2023-11-24 → 2024-12-04 (+376d) | 3d → 5d | 143d → 113d |  | resources none → CAMION GRUA 20 TON [40 h] |
| A3310 | RELLENO SELECCIONADO PARA ZANJAS CON MATERIAL PROPIO | 2023-11-25 → 2024-12-05 (+376d) | 2023-11-27 → 2024-12-10 (+379d) | 3d → 6d | 143d → 113d |  | resources none → RETROEXCAVADORA SOBRE LLANTAS 94 HP, 1.25 Y3 [12 h]; RODILLO LISO VIBRATORIO MANUAL 10.8 HP 0.8 -1.1 Ton [48 h] |
| A3320 | RELLENO COMÚN PARA ZANJAS | 2023-11-25 → 2024-12-05 (+376d) | 2023-11-27 → 2024-12-10 (+379d) | 3d → 6d | 143d → 113d |  | resources none → RODILLO LISO VIBRATORIO MANUAL 10.8 HP 0.8 -1.1 Ton [48 h] |
| A3370 | ACERO DE REFUERZO fy=4200 kg/cm2 | 2023-12-10 → 2024-12-09 (+365d) | 2023-12-12 → 2024-12-13 (+367d) | 3d → 5d | 79d → 32d |  | resources none → armado de acero fy=4200 kg/cm2 [218 kg] |
| A3350 | ENCOFRADO Y DESENCOFRADO RECTO | 2023-12-13 → 2024-12-14 (+367d) | 2023-12-15 → 2024-12-18 (+369d) | 3d → 5d | 79d → 32d |  | resources none → Encofrado Recto [5 m3] |
| A3360 | ENCOFRADO Y DESENCOFRADO CURVO | 2023-12-13 → 2024-12-14 (+367d) | 2023-12-15 → 2024-12-18 (+369d) | 3d → 5d | 79d → 32d |  | resources none → Encofrado Curvo [17 m3] |
| A3340 | CONCRETO f'c=280 kg/cm2 (Buzones) | 2023-12-16 → 2024-12-19 (+369d) | 2023-12-18 → 2024-12-24 (+372d) | 3d → 6d | 105d → 63d |  | resources none → Colocacion de concreto f'c=280 kg/cm2 [7 m3] |
| A3290 | RELLENO ESTRUCTURAL PARA OBRAS DE ARTE CON MATERIAL PROPIO | 2023-12-31 → 2025-01-06 (+372d) | 2024-01-02 → 2025-01-12 (+376d) | 3d → 7d | 107d → 80d | A3340 FS+12d → A3340, A5240 | resources none → RODILLO LISO VIBRATORIO MANUAL 10.8 HP 0.8 -1.1 Ton [56 h]; RETROEXCAVADORA SOBRE LLANTAS 94 HP, 1.25 Y3 [14 h] |
| 5 | **CANALES** | 2023-11-16 → 2024-11-18 (+368d) | 2024-02-06 → 2025-03-15 (+403d) |  |  |  |  |

| ID | Task | Start | Finish | Duration | Total float | Predecessors | Other |
| --- | --- | --- | --- | --- | --- | --- | --- |
| A3390 | EXCAVACIÓN ESTRUCTURAL PARA OBRAS DE ARTE | 2023-11-16 → 2024-11-18 (+368d) | 2023-11-20 → 2024-11-22 (+368d) |  | 38d → 34d |  | resources none → RETROEXCAVADORA SOBRE LLANTAS 94 HP, 1.25 Y3 [40 h] |
| A3410 | COLOCACIÓN DE CONCRETO f'c=100 kg/cm2 | 2023-11-21 → 2024-11-24 (+369d) | 2023-11-23 → 2024-12-17 (+390d) | 3d → 24d | 98d → 33d |  | resources none → Colocacion de concreto f'c=100 kg/cm2 [9 m3] |
| A3440 | ACERO DE REFUERZO fy=4200 kg/cm2 | 2023-12-13 → 2024-12-18 (+371d) | 2023-12-24 → 2024-12-29 (+371d) |  | 79d → 33d |  | resources none → armado de acero fy=4200 kg/cm2 [4419 kg] |
| A3430 | ENCOFRADO Y DESENCOFRADO | 2023-12-16 → 2024-12-19 (+369d) | 2024-01-13 → 2025-01-24 (+377d) | 29d → 37d | 79d → 32d | A3440 SS+3d, A3360 → A3440 SS, A3360 | resources none → Encofrado Recto [570 m3] |
| A3420 | COLOCACIÓN DE CONCRETO f'c=280 kg/cm2 | 2024-01-14 → 2025-01-25 (+377d) | 2024-01-18 → 2025-02-17 (+396d) | 5d → 24d | 79d → 32d |  | resources none → Colocacion de concreto f'c=280 kg/cm2 [44 m3] |
| A3450 | JUNTA WATER STOP SIN BULBO 150 mm | 2024-01-14 → 2025-01-25 (+377d) | 2024-01-16 → 2025-01-29 (+379d) | 3d → 5d | 100d → 90d |  | resources none → CAMION GRUA 20 TON [40 h] |
| A3400 | RELLENO ESTRUCTURAL PARA CANALES, CON MATERIAL PROPIO | 2024-01-31 → 2025-03-02 (+396d) | 2024-02-06 → 2025-03-15 (+403d) | 7d → 14d | 79d → 32d |  | resources none → RETROEXCAVADORA SOBRE LLANTAS 94 HP, 1.25 Y3 [28 h]; RODILLO LISO VIBRATORIO MANUAL 10.8 HP 0.8 -1.1 Ton [112 h] |
| 3 | **RETORNO A3-OA-RE-D-21-55** | 2023-11-06 → 2024-11-17 (+377d) | 2023-12-29 → 2025-02-03 (+402d) |  |  |  |  |
| 1 | **MOVIMIENTO DE TIERRAS** | 2023-11-06 → 2024-11-17 (+377d) | 2023-12-25 → 2025-01-30 (+402d) |  |  |  |  |
| A3460 | EXCAVACIÓN ESTRUCTURAL PARA OBRAS DE ARTE | 2023-11-06 → 2024-11-17 (+377d) | 2023-11-08 → 2024-11-19 (+377d) |  | 118d → 7d | A1070 SS+4d → A1070 SS+4d, A1015 SS, A4210 | resources none → RETROEXCAVADORA SOBRE LLANTAS 94 HP, 1.25 Y3 [24 h] |
| A3470 | RELLENO ESTRUCTURAL PARA OBRAS DE ARTE, CON MATERIAL PROPIO | 2023-12-23 → 2025-01-28 (+402d) | 2023-12-25 → 2025-01-30 (+402d) |  | 122d → 11d |  | resources none → RETROEXCAVADORA SOBRE LLANTAS 94 HP, 1.25 Y3 [6 h]; RODILLO LISO VIBRATORIO MANUAL 10.8 HP 0.8 -1.1 Ton [24 h] |
| 2 | **OBRAS DE CONCRETO** | 2023-11-09 → 2024-11-20 (+377d) | 2023-12-10 → 2025-01-15 (+402d) |  |  |  |  |
| A3480 | CONCRETO f'c=100 kg/cm2 | 2023-11-09 → 2024-11-20 (+377d) | 2023-11-11 → 2024-12-06 (+391d) | 3d → 17d | 118d → 7d |  | resources none → Colocacion de concreto f'c=100 kg/cm2 [6 m3] |
| A3500 | CONCRETO CICLÓPEO f'c=280 kg/cm2 + 30% P.G. | 2023-11-12 → 2024-12-07 (+391d) | 2023-11-16 → 2024-12-21 (+401d) | 5d → 15d | 118d → 7d |  | resources none → Colocacion de concreto ciclopeo [28 m3] |
| A3510 | ENCOFRADO Y DESENCOFRADO | 2023-11-18 → 2024-12-07 (+385d) | 2023-12-05 → 2024-12-31 (+392d) | 18d → 25d | 118d → 7d | A3520 SS+6d → A3520 SS | resources none → Encofrado Recto [115 m3] |
| A3520 | ACERO DE REFUERZO fy=4200 kg/cm2 | 2023-11-12 → 2024-12-07 (+391d) | 2023-12-05 → 2024-12-30 (+391d) |  | 118d → 7d |  | resources none → armado de acero fy=4200 kg/cm2 [8655 kg] |
| A3490 | CONCRETO f'c=280 kg/cm2 | 2023-12-06 → 2025-01-01 (+392d) | 2023-12-10 → 2025-01-15 (+402d) | 5d → 15d | 118d → 7d |  | resources none → Colocacion de concreto f'c=280 kg/cm2 [43 m3] |
| A3530 | JUNTA WATER STOP SIN BULBO 150 mm | 2023-12-06 → 2025-01-01 (+392d) | 2023-12-10 → 2025-01-15 (+402d) | 5d → 15d | 137d → 26d |  | resources none → CAMION GRUA 20 TON [120 h] |
| 3 | **ESTRUCTURAS METALICAS** | 2023-12-23 → 2025-01-28 (+402d) | 2023-12-29 → 2025-02-03 (+402d) |  |  |  |  |
| A3540 | COMPUERTA METALICA PLANA DESLIZANTE DE 1.0x1.6 m | 2023-12-23 → 2025-01-28 (+402d) | 2023-12-26 → 2025-01-31 (+402d) |  | 118d → 7d | A3490 FS+12d → A3490 FS+12d, A2880 | resources none → CAMION GRUA 20 TON [32 h] |
| A3550 | BARANDA DE FIERRO GALVANIZADO 1 1/2" | 2023-12-27 → 2025-02-01 (+402d) | 2023-12-29 → 2025-02-03 (+402d) |  | 118d → 7d |  | resources none → CAMION GRUA 20 TON [24 h] |
| 4 | **REPOSICIÓN DE CANALES** | 2023-11-22 → 2024-11-19 (+363d) | 2024-03-14 → 2025-04-25 (+407d) |  |  |  |  |
| 1 | **REPOSICIÓN DE CANAL 1** | 2023-12-13 → 2025-01-01 (+385d) | 2024-03-14 → 2025-04-23 (+405d) |  |  |  |  |
| 1 | **MOVIMIENTO DE TIERRAS** | 2023-12-13 → 2025-01-01 (+385d) | 2024-01-24 → 2025-02-11 (+384d) |  |  |  |  |
| A3560 | DEMOLICIÓN DE ESTRUCTURAS EXISTENTES | 2023-12-13 → 2025-01-01 (+385d) | 2023-12-29 → 2025-01-17 (+385d) |  | 42d → 35d | A4660 → A4390 | resources none → EXCAVADORA CAT 336 [136 h] |
| A3570 | EXCAVACIÓN EN TERRENO NATURAL CON EQUIPO | 2023-12-19 → 2025-01-07 (+385d) | 2024-01-23 → 2025-02-11 (+385d) |  | 42d → 35d | A3560 SS+6d → A3560 SS+6d, A3760 | resources none → RETROEXCAVADORA SOBRE LLANTAS 94 HP, 1.25 Y3 [288 h] |
| A3580 | RELLENO ESTRUCTURAL PARA OBRAS DE ARTE CON MATERIAL PROPIO | 2023-12-17 → 2025-01-10 (+390d) | 2024-01-24 → 2025-02-04 (+377d) | 39d → 26d | 92d → 6d | A4660 FS+4d → A4660 SS+45d | resources none → RETROEXCAVADORA SOBRE LLANTAS 94 HP, 1.25 Y3 [52 h]; RODILLO LISO VIBRATORIO MANUAL 10.8 HP 0.8 -1.1 Ton [208 h] |
| 2 | **OBRAS DE CONCRETO** | 2023-12-26 → 2025-01-31 (+402d) | 2024-03-14 → 2025-04-23 (+405d) |  |  |  |  |
| A3600 | ACERO DE REFUERZO fy=4200 kg/cm2 | 2023-12-29 → 2025-01-31 (+399d) | 2024-03-07 → 2025-03-22 (+380d) | 70d → 51d | 42d → 11d | A3610 SS+3d → A3610 SS | resources none → Camion grua 20 ton [326.4 h] |
| A3610 | CONCRETO f'c=100 kg/cm2 | 2023-12-26 → 2025-01-31 (+402d) | 2024-01-30 → 2025-03-07 (+402d) |  | 42d → 11d | A3570 SS+7d → A3570 SS, A3470 | resources none → Colocacion de concreto f'c=100 kg/cm2 [122 m3] |
| A3590 | ENCOFRADO RECTO | 2024-01-05 → 2025-02-04 (+396d) | 2024-03-07 → 2025-04-05 (+394d) | 63d → 61d | 42d → 7d | A3600 SS+7d → A3600 SS, A3530, A3550 | was named ENCOFRADO Y DESENCOFRADO RECTO; resources none → Encofrado Recto [3708 m3] |
| A3620 | CONCRETO f'c=280 kg/cm2 | 2024-01-19 → 2025-02-05 (+383d) | 2024-03-12 → 2025-03-30 (+383d) |  | 42d → 6d | A3590 SS+14d → A3590 SS, A3580 | resources none → Colocacion de concreto f'c=280 kg/cm2 [528 m3] |
| A3630 | JUNTA WATER STOP 6" | 2024-01-19 → 2025-02-14 (+392d) | 2024-03-12 → 2025-03-30 (+383d) | 54d → 45d | 44d → 10d | A3620 SS → A3620 SS, A3260 | resources none → Camion grua 20 ton [288 h] |
| A3640 | MAMPOSTERIA DE PIEDRA, e=20cm, ACABADO CARA VISTA | 2024-03-13 → 2025-04-03 (+386d) | 2024-03-14 → 2025-04-08 (+390d) | 2d → 6d | 42d → 18d | A3620 → A3620, A3130 | resources none → Camion grua 20 ton [38.4 h] |
| 2 | **REPOSICIÓN DE CANAL 3** | 2023-11-22 → 2024-11-19 (+363d) | 2024-01-16 → 2025-04-25 (+465d) |  |  |  |  |
| 1 | **MOVIMIENTO DE TIERRAS** | 2023-11-22 → 2024-11-19 (+363d) | 2023-12-20 → 2025-04-01 (+468d) |  |  |  |  |
| A3650 | DEMOLICIÓN DE ESTRUCTURAS EXISTENTES | 2023-11-22 → 2024-11-19 (+363d) | 2023-12-01 → 2024-11-30 (+365d) | 10d → 12d | 100d → 105d | A4210 FS+6d → A1440 | resources none → EXCAVADORA CAT 336 [96 h] |
| A3660 | EXCAVACIÓN EN TERRENO NATURAL CON EQUIPO | 2023-12-14 → 2024-12-01 (+353d) | 2023-12-17 → 2024-12-18 (+367d) | 4d → 18d | 100d → 105d | A3650 FS+12d → A3650 | resources none → RETROEXCAVADORA SOBRE LLANTAS 94 HP, 1.25 Y3 [144 h] |
| A3670 | RELLENO ESTRUCTURAL PARA OBRAS DE ARTE CON MATERIAL PROPIO | 2023-12-18 → 2025-03-30 (+468d) | 2023-12-20 → 2025-04-01 (+468d) |  | 100d → 4d | A3660 → A3660, A3080 SS, A3400 SS | resources none → RETROEXCAVADORA SOBRE LLANTAS 94 HP, 1.25 Y3 [6 h]; RODILLO LISO VIBRATORIO MANUAL 10.8 HP 0.8 -1.1 Ton [24 h] |
| 2 | **OBRAS DE CONCRETO** | 2023-12-21 → 2025-04-02 (+468d) | 2024-01-16 → 2025-04-25 (+465d) |  |  |  |  |
| A3710 | CONCRETO f'c=100 kg/cm2 | 2023-12-21 → 2025-04-02 (+468d) | 2023-12-24 → 2025-04-05 (+468d) |  | 100d → 4d | A3670 → A3670, A3580 | resources none → Colocacion de concreto f'c=100 kg/cm2 [33 m3] |
| A3680 | ENCOFRADO Y DESENCOFRADO PARA REVESTIMIENTO DE CANALES (CERCHAS) | 2023-12-28 → 2025-04-06 (+465d) | 2024-01-08 → 2025-04-17 (+465d) |  | 100d → 4d | A3700 SS+3d → A3700 SS, A3630, A1760 | resources none → Encofrado Recto [21 m3] |
| A3690 | ENCOFRADO Y DESENCOFRADO RECTO | 2023-12-28 → 2025-04-06 (+465d) | 2024-01-08 → 2025-04-17 (+465d) |  | 100d → 4d |  | resources none → Encofrado Recto [630 m3] |
| A3700 | MALLA ELECTROSOLDADA DE DN6mm EN CUADRICULA 15x15 cm | 2023-12-25 → 2025-04-06 (+468d) | 2024-01-08 → 2025-04-18 (+466d) | 15d → 13d | 100d → 4d |  | resources none → Camion grua 20 ton [83.2 h] |
| A3730 | SELLO DE JUNTA CONSTRUCCIÓN CON MATERIAL ELASTOMÉRICO | 2023-12-28 → 2025-04-06 (+465d) | 2024-01-06 → 2025-04-13 (+463d) | 10d → 8d | 110d → 16d |  | resources none → Camion grua 20 ton [51.2 h] |
| A3720 | CONCRETO f'c=280 kg/cm2 | 2024-01-09 → 2025-04-18 (+465d) | 2024-01-13 → 2025-04-22 (+465d) |  | 100d → 4d |  | resources none → Colocacion de concreto f'c=280 kg/cm2 [50 m3] |
| A3740 | MAMPOSTERIA DE PIEDRA, e=20cm, ACABADO CARA VISTA | 2024-01-14 → 2025-04-23 (+465d) | 2024-01-16 → 2025-04-25 (+465d) |  | 100d → 4d | A3720 → A3720, A3640 | resources none → Camion grua 20 ton [19.2 h] |
| 5 | **REPOSICIÓN SIFON INOPERATIVO** | 2023-12-08 → 2024-12-10 (+368d) | 2024-01-16 → 2025-02-25 (+406d) |  |  |  |  |
| A3750 | DEMOLICIÓN DE ESTRUCTURAS EXISTENTES | 2023-12-08 → 2024-12-10 (+368d) | 2023-12-10 → 2024-12-13 (+369d) | 3d → 4d | 100d → 48d | A1230, A1880 FF+2d → A1230, A1880 FF | resources none → EXCAVADORA CAT 336 [32 h] |
| A3760 | EXCAVACIÓN ESTRUCTURAL PARA OBRAS DE ARTE | 2023-12-11 → 2024-12-14 (+369d) | 2023-12-20 → 2024-12-24 (+370d) | 10d → 11d | 100d → 48d |  | resources none → RETROEXCAVADORA SOBRE LLANTAS 94 HP, 1.25 Y3 [88 h] |
| A3770 | COLOCACIÓN CAMA DE ARENA | 2023-12-21 → 2024-12-25 (+370d) | 2023-12-23 → 2024-12-29 (+372d) | 3d → 5d | 109d → 104d |  | resources none → Camion grua 20 ton [32 h] |
| A3810 | CONCRETO f'c=100 kg/cm2 | 2023-12-21 → 2024-12-25 (+370d) | 2023-12-23 → 2025-01-09 (+383d) | 3d → 16d | 100d → 63d |  | resources none → Colocacion de concreto f'c=100 kg/cm2 [2 m3] |
| A3800 | TUBERÍAS DE 14" HDPE SDR21 DN 355mm | 2023-12-24 → 2024-12-30 (+372d) | 2023-12-29 → 2025-01-05 (+373d) | 6d → 7d | 109d → 104d |  | resources none → Camion grua 20 ton [44.8 h] |
| A3850 | CODOS HDPE DE 14" DN 355mm | 2023-12-24 → 2024-12-30 (+372d) | 2023-12-29 → 2025-01-05 (+373d) | 6d → 7d | 118d → 114d |  | resources none → Camion grua 20 ton [44.8 h] |
| A3790 | RELLENO COMÚN | 2023-12-30 → 2025-01-06 (+373d) | 2024-01-07 → 2025-01-15 (+374d) | 9d → 10d | 109d → 104d |  | resources none → Camion grua 20 ton [64 h] |
| A3840 | ACERO DE REFUERZO fy=4200 kg/cm2 | 2023-12-24 → 2025-01-10 (+383d) | 2023-12-26 → 2025-01-22 (+393d) | 3d → 13d | 100d → 63d |  | resources none → armado de acero fy=4200 kg/cm2 [90 kg] |
| A3830 | ENCOFRADO Y DESENCOFRADO RECTO | 2023-12-27 → 2025-01-23 (+393d) | 2023-12-29 → 2025-02-04 (+403d) | 3d → 13d | 100d → 63d |  | resources none → Encofrado Recto [10 m3] |
| A3820 | CONCRETO f'c=280 kg/cm2 | 2023-12-30 → 2025-02-05 (+403d) | 2024-01-01 → 2025-02-20 (+416d) | 3d → 16d | 100d → 63d |  | resources none → Colocacion de concreto f'c=280 kg/cm2 [2 m3] |
| A3780 | RELLENO ESTRUCTURAL PARA OBRAS DE ARTE CON MATERIAL PROPIO | 2024-01-14 → 2025-02-21 (+404d) | 2024-01-16 → 2025-02-25 (+406d) | 3d → 5d | 100d → 63d | A3820 FS+12d → A3820 | resources none → RETROEXCAVADORA SOBRE LLANTAS 94 HP, 1.25 Y3 [10 h]; RODILLO LISO VIBRATORIO MANUAL 10.8 HP 0.8 -1.1 Ton [40 h] |
| 3 | **ARQUITECTURA Y PAISAJISMO** | 2024-01-05 → 2025-01-23 (+384d) | 2024-03-22 → 2025-04-24 (+398d) |  |  |  |  |
| 1 | **OBRAS PRELIMINARES** | 2024-01-05 → 2025-01-23 (+384d) | 2024-03-22 → 2025-04-24 (+398d) |  |  |  |  |
| A3860 | MOVILIZACIÓN DE EQUIPOS Y HERRAMIENTAS (ARQUITECTURA Y PAISAJISMO) | 2024-01-05 → 2025-01-23 (+384d) | 2024-01-06 → 2025-01-30 (+390d) | 2d → 8d | 34d → 5d | A4740 → A4420 FS+20d |  |
| A3870 | TRAZO Y REPLANTEO PRELIMINAR | 2024-01-07 → 2025-01-31 (+390d) | 2024-01-08 → 2025-02-07 (+396d) | 2d → 8d | 34d → 5d |  |  |
| A4020 | DEMOVILIZACIÓN DE EQUIPOS Y HERRAMIENTAS (ARQUITECTURA Y PAISAJISMO) | 2024-03-21 → 2025-04-17 (+392d) | 2024-03-22 → 2025-04-24 (+398d) | 2d → 8d | 34d → 5d | A4010 FS+4d, A3900 → A4010, A3900 |  |
| 2 | **MOVIMIENTO DE TIERRAS** | 2024-01-09 → 2025-02-08 (+396d) | 2024-01-25 → 2025-02-27 (+399d) |  |  |  |  |
| A3880 | EXCAVACIÓN MANUAL PARA INSTALACIÓN DE BORDILLOS Y CIMENTACIONES | 2024-01-09 → 2025-02-08 (+396d) | 2024-01-10 → 2025-02-09 (+396d) |  | 34d → 5d |  |  |
| A3900 | ELIMINACION DE MATERIAL EXCEDENTE (DME´S) | 2024-01-09 → 2025-02-08 (+396d) | 2024-01-25 → 2025-02-27 (+399d) | 17d → 20d | 89d → 53d |  |  |
| A3890 | EXCAVACIÓN PARA MEJORAMIENTO DE SUELO CON TIERRA VEGETAL | 2024-01-11 → 2025-02-10 (+396d) | 2024-01-25 → 2025-02-24 (+396d) |  | 34d → 5d |  |  |
| 3 | **PAVIMENTOS, RECUBRIMIENTOS Y BORDILLOS** | 2024-01-26 → 2025-02-25 (+396d) | 2024-02-05 → 2025-03-07 (+396d) |  |  |  |  |
| A3910 | PISO DE GRAVILLA | 2024-01-26 → 2025-02-25 (+396d) | 2024-01-27 → 2025-02-26 (+396d) |  | 34d → 5d |  | resources none → Camion grua 20 ton [12.8 h] |

| ID | Task | Start | Finish | Total float | Other |
| --- | --- | --- | --- | --- | --- |
| A3920 | RECUBRIMIENTO DE PIEDRA DEL LUGAR e=0.05cm | 2024-01-28 → 2025-02-27 (+396d) | 2024-01-31 → 2025-03-02 (+396d) | 34d → 5d | resources none → Camion grua 20 ton [25.6 h] |
| A3930 | BORDILLOS DE PIEDRA DEL LUGAR | 2024-02-01 → 2025-03-03 (+396d) | 2024-02-05 → 2025-03-07 (+396d) | 34d → 5d | resources none → Camion grua 20 ton [32 h] |
| 4 | **MOBILIARIOS, BARANDAS Y ESCALERAS** | 2024-02-06 → 2025-03-08 (+396d) | 2024-03-14 → 2025-04-14 (+396d) |  |  |
| A3940 | ESCALERA DE CONCRETO SOBRE ENROCADO, CIMENTACION Y ANCLAJE | 2024-02-06 → 2025-03-08 (+396d) | 2024-02-15 → 2025-03-17 (+396d) | 34d → 5d | resources none → Camion grua 20 ton [64 h] |
| A3950 | BARANDA DE MADERA EUCALIPTO CON SOGA, INCLUYE CIMENTACIÓN | 2024-02-16 → 2025-03-18 (+396d) | 2024-02-19 → 2025-03-21 (+396d) | 34d → 5d | resources none → Camion grua 20 ton [25.6 h] |
| A3960 | TACHOS DE BASURA, INCLUYE CIMENTACIÓN | 2024-02-20 → 2025-03-22 (+396d) | 2024-02-22 → 2025-03-24 (+396d) | 34d → 5d | resources none → Camion grua 20 ton [19.2 h] |
| A3970 | BANCAS DE CONCRETO, INCLUYE CIMENTACIÓN | 2024-02-23 → 2025-03-25 (+396d) | 2024-03-03 → 2025-04-03 (+396d) | 34d → 5d | resources none → Camion grua 20 ton [64 h] |
| A3980 | POSTES DE ILUMINACIÓN, INCLUYE LUMINARIA Y CIMENTACIÓN | 2024-03-04 → 2025-04-04 (+396d) | 2024-03-08 → 2025-04-08 (+396d) | 34d → 5d | resources none → Camion grua 20 ton [32 h] |
| A3990 | SEÑALETICA INFORMATIVA | 2024-03-09 → 2025-04-09 (+396d) | 2024-03-11 → 2025-04-11 (+396d) | 34d → 5d | resources none → Camion grua 20 ton [19.2 h] |
| A4000 | BOLARDOS DE PIEDRA | 2024-03-12 → 2025-04-12 (+396d) | 2024-03-14 → 2025-04-14 (+396d) | 34d → 5d | resources none → Camion grua 20 ton [19.2 h] |
| 5 | **INSTALACIÓN DE ALCORQUES** | 2024-03-15 → 2025-04-15 (+396d) | 2024-03-16 → 2025-04-16 (+396d) |  |  |
| A4010 | ALCORQUES DE PIEDRA DE CANTO RODADO PARA ARBOLES | 2024-03-15 → 2025-04-15 (+396d) | 2024-03-16 → 2025-04-16 (+396d) | 34d → 5d | resources none → Camion grua 20 ton [12.8 h] |
| 4 | **PROGRAMA DE CIERRE DE OBRA** | 2023-11-07 → 2024-11-06 (+365d) | 2024-04-22 → 2025-04-22 (+365d) |  |  |
| A1770 | ACONDICIONAMIENTO DE DEPOSITOS DE MATERIALES EXCEDENTES (DME) | 2023-11-07 → 2024-11-06 (+365d) | 2024-04-14 → 2025-04-14 (+365d) | 3d → 7d | resources none → EXCAVADORA CAT 336 [320 h]; TRACTOR SOBRE ORUGAS CAT D6D [1280 h] |
| A1780 | RESTAURACIÓN DE ÁREAS DE INSTALACIONES PROVISIONALES | 2024-04-15 → 2025-04-15 (+365d) | 2024-04-22 → 2025-04-22 (+365d) | 3d → 7d | resources none → TRACTOR SOBRE ORUGAS CAT D6D [64 h] |
